# KAUST-Baseline Schedule

How a schedule from Primavera P6 changed from version to version. A marks actual dates.

## Version 1 (data date 2011-01-09, saved 2011-08-15, file KAUST Baseline Schedule(Main).xer)

| ID | WBS | Task | Duration | Start | Finish | Predecessors | Total float |
| --- | --- | --- | --- | --- | --- | --- | --- |
|  | M | **MILESTONE DATES** |  | 2011-01-09 | 2013-06-29 |  |  |
|  | 1 | **Milestone Dates** |  | 2011-01-09 | 2013-06-29 |  |  |
| M1.00 |  | Notice to Proceed (NTP) | 0d | 2011-01-09 | 2011-01-09 |  | 0d |
| M1.01 |  | PMT & Contractor Design Office | 0d | 2011-01-19 | 2011-01-19 | 1.2.1.010 | 63.75d |
| M1.02 |  | Submit 120 Days Schedule | 0d | 2011-02-08 | 2011-02-08 | 1.2.2.010, M1.01 | 65.75d |
| M1.03 |  | Complet Site Prep'n detailed design package | 0d | 2011-02-08 | 2011-02-08 | M1.02 | 85d |
| M1.04 |  | Submit Project Execution Plan (PEP) | 0d | 2011-02-23 | 2011-02-23 | 1.2.3.010, M1.03 | 81d |
| M1.05 |  | Submit Procurement Plan & Quality Plan | 0d | 2011-02-23 | 2011-02-23 | 1.2.3.015, M1.04 | 81d |
| M1.06 |  | Submit Work Schedule | 0d | 2011-03-10 | 2011-03-10 | 1.2.4.010, M1.05 | 63.75d |
| M2.01 |  | Compl't mobilization | 0d | 2011-03-10 | 2011-03-10 | M1.00, 1.4.1.1.230 | 117.5d |
| M2.02 |  | Compl't temporary construction site offices | 0d | 2011-03-10 | 2011-03-10 | M1.00 FS+43d, 1.4.1.1.230, 1.4.1.1.120 | 117.5d |
| M2.03 |  | Compl't inst'n of jersey barrier & gates for zone 1 | 0d | 2011-04-09 | 2011-04-09 | 1.4.1.3.1.010 | 86.25d |
| M1.08 |  | Complete 50% Engineering Design | 0d | 2011-05-09 | 2011-05-09 | 1.2.6.040 | 93.75d |
| M2.04 |  | Compl't inst'n of jersey barrier & gates for zone 3 | 0d | 2011-06-08 | 2011-06-08 | 1.4.1.3.3.010 | 90d |
| M2.05 |  | Compl't site prep & access road for zone 1 | 0d | 2011-06-08 | 2011-06-08 | Z1.1030, Z1.1030 FF | 110d |
| M1.11 |  | Compl't 90% Engineering Design | 0d | 2011-07-07 | 2011-07-07 | 1.2.6.120 | 30d |
| M2.06 |  | Compl't inst'n of jersey barrier & gates for zone 4 | 0d | 2011-07-23 | 2011-07-23 | 1.4.1.3.4.010 | 112.5d |
| M2.07 |  | Compl't inst'n of jersey barrier & gates for zone 2 | 0d | 2011-07-23 | 2011-07-23 | 1.4.1.3.2.010 | 62.5d |
| M1.12 |  | Issue 100% IFC Drwaings | 0d | 2011-08-07 | 2011-08-07 | 1.2.6.200, M1.11 | 179.75d |
| M1.07 |  | Place PO for Long Lead Items | 0d | 2011-08-13 | 2011-08-13 | M1.06, 1.2.5.010 SF | 174.75d |
| M2.08 |  | Compl't site prep & access road for zone 3 | 0d | 2011-09-06 | 2011-09-06 | Z3.1020, Z3.2030, Z3.3020, Z3.4020, Z3.5020 | 37.5d |
| M1.09 |  | Compl't PO Placement of Engineered Items | 0d | 2011-10-20 | 2011-10-20 | M1.08, 1.2.5.020, M1.07 | 99.75d |
| M2.09 |  | Compl't site prep & access roads for zone 2 & 4 | 0d | 2011-11-05 | 2011-11-05 | Z2.1020, Z2.2020, Z4.1020, Z2.2330 | 130d |
| M1.10 |  | Compl't PO Placement of Bulk Items | 0d | 2011-11-30 | 2011-11-30 | M1.09, 1.2.5.030 | 56d |
| M2.10 |  | Energize Substation 4 and 5 | 0d | 2012-08-21 | 2012-08-21 | 1.4.3.1.1.570, 1.4.3.1.2.570, 1.4.2.7.4.213, 1.4.2.7.4.153, 1.4.2.7.4.231, 1.4.2.7.4.233, 1.4.2.7.4.193, 1.4.2.7.4.025, 1.4.2.7.4.055 | 37.75d |
| M2.11 |  | Compl't Communications and Security Cabling | 0d | 2012-09-20 | 2012-09-20 | 1.4.2.8.1.090, 1.4.2.8.1.110, 1.4.3.2.1.1010 | 94.25d |
| M2.12 |  | Communications and Security Systems | 0d | 2012-09-20 | 2012-09-20 | 1.4.3.2.1.1110 | 94d |
| M2.13 |  | Compl't Power System | 0d | 2012-09-20 | 2012-09-20 | 1.4.2.7.4.015, 1.4.2.7.4.211, 1.4.2.7.4.271, 1.4.2.7.2.050, 1.4.2.7.2.090, 1.4.2.7.4.273 | 93.75d |
| M2.14 |  | Compl't Const'n & Energize the Comm'n Bld'g | 0d | 2012-09-30 | 2012-09-30 | 1.4.3.2.1.1340, 1.4.3.2.1.1520, 1.4.3.2.1.890, 1.4.3.2.1.940 | 51.5d |
| M2.19 |  | Compl't Spare Part Data Packages | 0d | 2012-10-20 | 2012-10-20 | 1.4.4.2.010, 1.4.4.1.030 | 62.75d |
| M2.15 |  | Compl't Potable and Fire Water Systems | 0d | 2012-10-20 | 2012-10-20 | Z3.1320, Z3.2290, Z3.3270, Z2.1110, Z2.2310, Z4.1160, Z1.1060 | 62.5d |
| M2.16 |  | Compl't Irrigation System | 0d | 2012-10-20 | 2012-10-20 | 1.3.5.3.4.020, 1.3.5.3.3.020, Z3.1330, Z3.2300, Z2.2290 | 62.5d |
| M2.17 |  | Compl't Sanitary Sewer System | 0d | 2012-10-20 | 2012-10-20 | 1.4.2.3.5.140, 1.4.2.3.6.140, 1.4.2.3.7.140, 1.4.2.3.8.140, 1.4.2.7.4.121, 1.4.2.7.4.171, 1.4.2.3.7.150, 1.4.2.3.5.150, 1.4.2.3.8.150, 1.4.2.3.6.160, 1.4.2.3.7.160, 1.4.2.3.8.160, 1.4.2.3.5.160, 1.4.2.7.4.173, 1.4.2.7.4.175, 1.4.2.7.4.177, 1.4.2.7.4.123, 1.4.2.7.4.125, 1.4.2.7.4.127 | 30d |
| M2.18 |  | Compl't Storm Drainage System | 0d | 2012-10-20 | 2012-10-20 | 1.4.2.4.2.050B, 1.4.2.4.2.090B, 1.4.2.4.2.040, 1.4.2.4.3.040, 1.4.2.4.1.015, 1.4.2.4.2.093C, 1.4.2.4.2.053C, 1.4.2.4.3.106C, 1.4.2.4.3.116C, 1.4.2.4.3.340, 1.4.2.4.4.120C, Z3.4060, Z3.5080, 1.4.2.4.2.054C, 1.4.2.4.3.070, 1.4.2.4.3.450, 1.4.2.4.3.530, 1.4.2.4.3.500, 1.4.2.4.3.720, 1.4.2.4.4.080 | 62.5d |
| M2.20 |  | Compl't Redlined As-Built drawings | 0d | 2012-11-19 | 2012-11-19 | 1.4.4.5.040, 1.4.1.1.200 | 30d |
| M2.21 |  | Mech'l Compl'n Certific'n of all works | 0d | 2012-12-29 | 2012-12-29 | 1.4.4.6.010, M1.12, M2.01, M2.02, M2.03, M2.04, M2.05, M2.06, M2.07, M2.08, M2.09, M2.10, M2.11, M2.12, M2.13, M2.14, M2.15, M2.16, M2.17, M2.18, M2.19, M2.20, 1.4.2.5.6.020A, 1.4.2.5.5.010C, 1.4.2.6.140, 1.4.3.3.1.3.120, 1.4.3.3.1.3.150, 1.4.3.3.1.3.180, 1.4.3.3.1.3.210, 1.4.3.3.1.3.300, 1.4.3.3.1.2.120, 1.4.3.5.1.140, 1.4.3.6.1.150, 1.4.3.4.4.170, 1.4.3.7.1.140, 1.4.3.7.1.100, 1.4.3.1.1.780, 1.4.3.1.1.820, 1.4.2.6.150, 1.4.3.6.1.100, 1.4.3.3.1.2.210, 1.4.3.3.1.2.180, 1.4.3.3.1.2.300, 1.4.3.3.1.1.210, 1.4.3.3.1.1.120, 1.4.3.3.1.1.300, 1.4.2.7.4.075, 1.4.2.6.120, 1.4.2.6.090, 1.4.2.5.6.020D, 1.4.2.5.5.050C, 1.4.2.6.170, 1.4.2.5.3.110, 1.4.2.5.4.050, 1.4.3.4.3.170 | 80d |
| M2.22 |  | Compl't all As-Built CAD work | 0d | 2013-01-28 | 2013-01-28 | 1.2.9.020 | 80d |
| M2.23 |  | Scheduled Completion Date and Demobilization | 0d | 2013-06-29 | 2013-06-29 | M2.21, M2.22, M2.10, 1.4.5.1.040 | 0d |
|  | E | **DETAILED ENGINEERING / DESIGN** |  | 2011-01-09 | 2013-01-28 |  |  |
|  | 1 | **Categories 1** |  | 2011-01-09 | 2011-01-19 |  |  |
|  | 1 | **Categories 1** |  | 2011-01-09 | 2011-01-19 |  |  |
| 1.2.1.010 |  | PMT & Contractor Design office | 12d | 2011-01-09 | 2011-01-19 | M1.00 | 0d |
|  | 2 | **Categories 2** |  | 2011-01-19 | 2011-02-22 |  |  |
|  | 1 | **Categories 2** |  | 2011-01-19 | 2011-02-22 |  |  |
| 1.2.2.010 |  | Submit 120 days schedule | 21d | 2011-01-19 | 2011-02-08 | 1.2.1.010, M1.01 | 63.75d |
| 1.2.2.020 |  | Submit drawing & document control index | 21d | 2011-02-02 | 2011-02-22 | 1.2.2.010 SS+15d | 63.75d |
|  | 3 | **Categories 3** |  | 2011-02-10 | 2011-02-23 |  |  |
|  | 1 | **Categories 3** |  | 2011-02-10 | 2011-02-23 |  |  |
| 1.2.3.010 |  | Submit project execution plan PEP | 14d | 2011-02-10 | 2011-02-23 | 1.2.2.020 SS+8d, M1.02 | 63.75d |
| 1.2.3.015 |  | Submit Procurement plan & Quality Plan | 12d | 2011-02-12 | 2011-02-23 | 1.2.2.020 SS+10d, M1.03 | 81d |
|  | 4 | **Categories 4** |  | 2011-02-20 | 2011-03-10 |  |  |
|  | 1 | **Categories 4** |  | 2011-02-20 | 2011-03-10 |  |  |
| 1.2.4.010 |  | Submit contractor deliverables & Work Schedule | 21.25d | 2011-02-20 | 2011-03-10 | 1.2.3.010 SS+10d | 63.75d |
|  | 5 | **Categories 5** |  | 2011-08-13 | 2011-11-30 |  |  |
|  | 1 | **Categories 5** |  | 2011-08-13 | 2011-11-30 |  |  |
| 1.2.5.010 |  | Purchase orders placed for long lead items | 37.5d | 2011-08-13 | 2011-09-15 | 1.3.2.1.010 | 56d |
| 1.2.5.020 |  | Purchase orders placed for all engineered items | 37.5d | 2011-09-17 | 2011-10-20 | 1.2.5.010 | 56d |
| 1.2.5.030 |  | Purchase orders placed for all bulk items | 43.75d | 2011-10-22 | 2011-11-30 | 1.3.1.1.010 SS, 1.2.5.020 | 56d |
|  | 6 | **Categories 6** |  | 2011-01-27 | 2011-08-07 |  |  |
|  | 1 | **Categories 6** |  | 2011-01-27 | 2011-08-07 |  |  |
| 1.2.6.010 |  | Preparation of 50% Civil drawings | 37.5d | 2011-01-27 | 2011-03-02 | 1.2.1.010 FS+8d | 0d |
| 1.2.6.020 |  | Preparation of 50% Mechanical drawings | 37.5d | 2011-02-20 | 2011-03-26 | 1.2.6.010 SS+25d | 0d |
| 1.2.6.030 |  | Preparation of 50% Electrical drawings | 37.5d | 2011-03-15 | 2011-04-18 | 1.2.6.020 SS+25d | 0d |
| 1.2.6.040 |  | Preparation of 50% Communication drawings | 37.5d | 2011-04-05 | 2011-05-09 | 1.2.6.030 SS+22.5d | 0d |
| 1.2.6.090 |  | Preparation of 90% Civil drawings | 25d | 2011-05-10 | 2011-06-01 | 1.2.6.040, M1.04, M1.05, M1.06 | 0d |
| 1.2.6.100 |  | Preparation of 90% Mechancial drawings | 25d | 2011-05-22 | 2011-06-13 | 1.2.6.090 SS+12.5d | 0d |
| 1.2.6.110 |  | Preparation of 90% Electrical drawings | 25d | 2011-06-02 | 2011-06-25 | 1.2.6.100 SS+12.5d | 0d |
| 1.2.6.120 |  | Preparation of 90% Communication drawings | 26.25d | 2011-06-14 | 2011-07-07 | 1.2.6.110 SS+12.5d | 0d |
| 1.2.6.200 |  | Submit 100% IFC drawings | 32.5d | 2011-07-09 | 2011-08-07 | 1.2.6.120, 1.2.2.010, 1.2.2.020, 1.2.3.010, 1.2.3.015, 1.2.4.010, M1.08, M1.11 | 30d |
|  | 7 | **Categories 7** |  | 2012-09-29 | 2012-10-27 |  |  |

| ID | WBS | Task | Duration | Start | Finish | Predecessors | Total float |
| --- | --- | --- | --- | --- | --- | --- | --- |
|  | 1 | **Categories 7** |  | 2012-09-29 | 2012-10-27 |  |  |
| 1.2.7.010 |  | Submit Project Record books | 30d | 2012-09-29 | 2012-10-27 | 1.2.6.200 FS+300d, 1.2.5.030, 1.4.4.3.010 | 147.75d |
|  | 8 | **Categories 8** |  | 2012-01-24 | 2012-06-11 |  |  |
|  | 1 | **Categories 8** |  | 2012-01-24 | 2012-06-11 |  |  |
| 1.2.8.010 |  | Submit Pre-commissioning Plans | 75d | 2012-01-24 | 2012-04-02 | 1.2.6.200 FS+181.25d | 95d |
| 1.2.8.020 |  | Approved Pre-commissioning Plans | 75d | 2012-04-03 | 2012-06-11 | 1.2.8.010 | 95d |
|  | 9 | **Categories 9** |  | 2012-12-30 | 2013-01-28 |  |  |
|  | 1 | **Categories 9** |  | 2012-12-30 | 2013-01-28 |  |  |
| 1.2.9.010 |  | Complete As built Red lined drawings & CAD-work | 32.5d | 2012-12-30 | 2013-01-28 | 1.4.3.1.2.570, 1.4.4.5.040, 1.2.7.010, 1.4.4.6.010, M2.21 | 80d |
| 1.2.9.020 |  | Complete Intergraph CADD | 32.5d | 2012-12-30 | 2013-01-28 | 1.2.9.010 SS | 80d |
|  | P.1.3 | **PROCUREMENT** |  | 2011-02-01 | 2012-11-03 |  |  |
|  | 1 | **CIVIL WORKS** |  | 2011-02-01 | 2012-11-03 |  |  |
|  | 1 | **Civil Works & Road Related Materials** |  | 2011-02-01 | 2012-11-03 |  |  |
|  | 01 | **FBE coated rebars** |  | 2011-07-20 | 2012-06-26 |  |  |
| 1.3.1.1.010 |  | Place PO for FBE coated rebars | 32.5d | 2011-07-20 | 2011-08-18 | 1.2.6.120 FS+12.5d | 0d |
| 1.3.1.1.020 |  | Delivery of FBE coated rebars on site | 312.5d | 2011-09-10 | 2012-06-26 | 1.3.1.1.010 FS+22.5d | 110d |
| 1.3.1.1.030 |  | Material receiving inspection & approval | 312.5d | 2011-09-10 | 2012-06-26 | 1.3.1.1.020 SS | 110d |
|  | 02 | **Structural Steel** |  | 2011-07-23 | 2011-09-29 |  |  |
| 1.3.1.1.110 |  | Place PO for structural stell | 37.5d | 2011-07-23 | 2011-08-27 | 1.3.1.1.010 SS+3d | 0d |
| 1.3.1.1.120 |  | Delivery of structural steel on site | 5d | 2011-09-19 | 2011-09-24 | 1.3.1.1.110 FS+25d | 88.5d |
| 1.3.1.1.130 |  | Material receiving inspection & approval | 6d | 2011-09-24 | 2011-09-29 | 1.3.1.1.120 | 88.5d |
|  | 03 | **Geogrid & Geotextile Materials** |  | 2011-08-29 | 2012-04-04 |  |  |
| 1.3.1.1.210 |  | Place PO for geogrid/geotextile materials | 37.5d | 2011-08-29 | 2011-10-03 | 1.3.1.1.110 SS+40d | 0d |
| 1.3.1.1.220 |  | Delivery of geogrid/geotextile materials on site | 6d | 2012-03-25 | 2012-03-31 | 1.3.1.1.210 FS+186.25d | 0d |
| 1.3.1.1.230 |  | Material receiving inspection & approval | 6d | 2012-03-31 | 2012-04-04 | 1.3.1.1.220 | 0d |
|  | 04 | **Ceramic Tiles** |  | 2011-07-27 | 2012-01-29 |  |  |
| 1.3.1.2.010 |  | Place PO for ceramic tiles | 37.5d | 2011-07-27 | 2011-08-31 | 1.3.1.1.110 SS+5d | 48.75d |
| 1.3.1.2.020 |  | Delivery of ceramic tiles on site | 5d | 2012-01-18 | 2012-01-23 | 1.3.1.2.010 FS+150d | 48.75d |
| 1.3.1.2.030 |  | Material receiving inspection & approval | 6d | 2012-01-23 | 2012-01-29 | 1.3.1.2.020 | 48.75d |
|  | 05 | **CMU Blocks** |  | 2011-10-03 | 2012-01-09 |  |  |
| 1.3.1.3.010 |  | Place PO for CMU blocks | 37.5d | 2011-10-03 | 2011-11-07 | 1.3.1.1.210 | 39d |
| 1.3.1.3.020 |  | Delivery of CMU blocks | 6d | 2011-12-29 | 2012-01-04 | 1.3.1.3.010 FS+56.25d | 39d |
| 1.3.1.3.030 |  | Material receiving inspection & approval | 6d | 2012-01-04 | 2012-01-09 | 1.3.1.3.020 | 39d |
|  | 06 | **Concrete Tiles** |  | 2011-09-04 | 2012-04-11 |  |  |
| 1.3.1.2.040 |  | Place PO for concrete tiles | 37.5d | 2011-09-04 | 2011-10-09 | 1.3.1.1.210 SS+6.25d | 37.25d |
| 1.3.1.2.050 |  | Delivery of concrete tiles | 5d | 2012-04-01 | 2012-04-05 | 1.3.1.2.040 FS+187.5d | 37.25d |
| 1.3.1.2.060 |  | Material receiving inspection & approval | 6d | 2012-04-05 | 2012-04-11 | 1.3.1.2.050 | 37.25d |
|  | 07 | **Doors & Frames** |  | 2011-09-15 | 2012-03-07 |  |  |
| 1.3.1.4.010 |  | Place PO for doors & frames | 37.5d | 2011-09-15 | 2011-10-20 | 1.3.1.2.040 SS+12.5d | 66.75d |
| 1.3.1.4.020 |  | Delivery of doors & frames on site | 5d | 2012-02-26 | 2012-03-01 | 1.3.1.4.010 FS+137.5d | 201d |
| 1.3.1.4.030 |  | Material receiving inspection & approval | 6d | 2012-03-01 | 2012-03-07 | 1.3.1.4.020 | 201d |
|  | 08 | **Aluminium Windows** |  | 2011-09-18 | 2012-03-10 |  |  |
| 1.3.1.4.040 |  | Place PO for windows | 37.5d | 2011-09-18 | 2011-10-23 | 1.3.1.4.010 SS+2.5d | 66.75d |
| 1.3.1.4.050 |  | Delivery of windows on site | 5d | 2012-02-28 | 2012-03-04 | 1.3.1.4.040 FS+137.5d | 198.5d |
| 1.3.1.4.060 |  | Material receiving inspection & approval | 6d | 2012-03-04 | 2012-03-10 | 1.3.1.4.050 | 198.5d |
|  | 09 | **Jersey Barriers** |  | 2011-02-01 | 2011-07-17 |  |  |
| 1.3.1.5.010 |  | Place PO for Jersey Barriers materials Materials | 7.5d | 2011-02-01 | 2011-02-07 | M1.00 FS+25d | 37.5d |
| 1.3.1.5.020 |  | Fabrication & Delivery of materials for jersey bariers | 150d | 2011-02-19 | 2011-07-07 | 1.3.1.5.010 FS+11.25d | 57.5d |
| 1.3.1.5.030 |  | Insp/Transporation of Jersey Barriers | 150d | 2011-02-28 | 2011-07-17 | 1.3.1.5.020 SS+10d | 57.5d |
|  | 10 | **Sliding & Swing Gates** |  | 2011-02-14 | 2011-03-17 |  |  |
| 1.3.1.5.110 |  | Place PO for sliding & swing gates | 7.5d | 2011-02-14 | 2011-02-20 | 1.3.1.5.010 FS+6.25d | 37.5d |
| 1.3.1.5.120 |  | Delivery of sliding & swing gates | 5d | 2011-03-10 | 2011-03-14 | 1.3.1.5.110 FS+18.75d | 37.5d |
| 1.3.1.5.130 |  | Material receiving inspection & approval | 3.75d | 2011-03-15 | 2011-03-17 | 1.3.1.5.120 | 37.5d |
|  | 11 | **Suspended Ceiling System** |  | 2011-10-10 | 2012-04-28 |  |  |
| 1.3.1.5.210 |  | Place PO for suspended ceiling system | 37.5d | 2011-10-10 | 2011-11-14 | 1.3.1.4.040 SS+23.75d | 66.75d |
| 1.3.1.5.220 |  | Delivery of suspended ceiling system | 6d | 2012-04-17 | 2012-04-23 | 1.3.1.5.210 FS+166.25d | 122.5d |
| 1.3.1.5.230 |  | Material receiving inspection & approval | 6d | 2012-04-23 | 2012-04-28 | 1.3.1.5.220 | 122.5d |
|  | 12 | **Dry Wall Partition** |  | 2011-10-10 | 2012-04-28 |  |  |
| 1.3.1.5.310 |  | Place PO for dry wall partition | 37.5d | 2011-10-10 | 2011-11-14 | 1.3.1.5.210 SS | 66.75d |
| 1.3.1.5.320 |  | Delivery of dry wall partition on site | 6d | 2012-04-17 | 2012-04-23 | 1.3.1.5.310 FS+166.25d | 70.5d |
| 1.3.1.5.330 |  | Material receiving inspection & approval | 6d | 2012-04-23 | 2012-04-28 | 1.3.1.5.320 | 70.5d |
|  | 13 | **Pre-Cast Concrete Wall** |  | 2011-10-15 | 2012-05-01 |  |  |
| 1.3.1.5.410 |  | Place PO for precast concrete wall | 37.5d | 2011-10-15 | 2011-11-19 | 1.3.1.5.310 SS+5d | 66.75d |
| 1.3.1.5.420 |  | Delivery of precast concrete wall | 6d | 2012-04-21 | 2012-04-26 | 1.3.1.5.410 FS+165d | 66.75d |
| 1.3.1.5.430 |  | Material receiving inspection & approval | 6d | 2012-04-26 | 2012-05-01 | 1.3.1.5.420 | 66.75d |
|  | 14 | **Concrete** |  | 2011-02-01 | 2012-11-03 |  |  |
| 1.3.1.6.110 |  | Place PO for Concrete | 6.25d | 2011-02-01 | 2011-02-06 | 1.3.1.5.010 SS | 48.75d |
| 1.3.1.6.120 |  | Delivery of concrete on site | 650d | 2011-03-08 | 2012-11-03 | 1.3.1.6.110 SS+37.5d | 48.75d |
|  | 15 | **Aggregate, Crushed Stone & Backfilling Materials** |  | 2011-02-16 | 2011-09-25 |  |  |
| 1.3.1.6.130 |  | Place PO for Aggregate & Backfill materials | 37.5d | 2011-02-16 | 2011-03-22 | 1.3.1.6.110 FS+10d | 49d |

| ID | WBS | Task | Duration | Start | Finish | Predecessors | Total float |
| --- | --- | --- | --- | --- | --- | --- | --- |
| 1.3.1.6.140 |  | Delivery of Aggregate & Backfill materials | 187.5d | 2011-04-04 | 2011-09-25 | 1.3.1.6.130 FS+12.5d | 131.25d |
|  | 16 | **Premix** |  | 2011-07-06 | 2012-04-15 |  |  |
| 1.3.1.6.150 |  | Place PO for Premix | 37.5d | 2011-07-06 | 2011-08-09 | 1.3.1.6.130 FS+112.5d | 49d |
| 1.3.1.6.160 |  | Delivery of Premix | 5d | 2012-04-11 | 2012-04-15 | 1.3.1.6.150 FS+262.5d | 120d |
|  | 17 | **Road Signange & Markings** |  | 2011-10-15 | 2012-03-08 |  |  |
| 1.3.1.6.170 |  | Place PO for road signage, markings | 37.5d | 2011-10-15 | 2011-11-19 | 1.3.1.5.410 SS | 198.25d |
| 1.3.1.6.180 |  | Delivery of road signage , markings | 6.25d | 2012-03-03 | 2012-03-08 | 1.3.1.6.170 FS+112.5d | 198.25d |
|  | 18 | **Ironmongery** |  | 2011-09-03 | 2012-01-25 |  |  |
| 1.3.1.6.190 |  | Place PO for Ironmongery | 37.5d | 2011-09-03 | 2011-10-06 | 1.3.1.6.150 FS+25d | 49d |
| 1.3.1.6.200 |  | Delivery of Ironmongery | 6.25d | 2012-01-21 | 2012-01-25 | 1.3.1.6.190 FS+112.5d | 71d |
|  | 19 | **Paint** |  | 2011-09-07 | 2012-02-11 |  |  |
| 1.3.1.6.210 |  | Place PO for Paint | 37.5d | 2011-09-07 | 2011-10-11 | 1.3.1.6.190 SS+5d | 49d |
| 1.3.1.6.220 |  | Delivery of Paint | 6.25d | 2012-02-06 | 2012-02-11 | 1.3.1.6.210 FS+125d | 49d |
|  | 20 | **Roofing Materials, membrane etc.** |  | 2011-10-12 | 2012-03-01 |  |  |
| 1.3.1.6.230 |  | Place PO for Roofing Materials & Membrane | 37.5d | 2011-10-12 | 2011-11-15 | 1.3.1.6.210 SS+37.5d | 206.25d |
| 1.3.1.6.240 |  | Delivery of roofing Materials & Membrane | 2.5d | 2012-02-29 | 2012-03-01 | 1.3.1.6.230 FS+112.5d | 206.25d |
|  | 21 | **Building Signage** |  | 2011-10-12 | 2012-03-15 |  |  |
| 1.3.1.6.250 |  | Place PO for Building Signage | 37.5d | 2011-10-12 | 2011-11-15 | 1.3.1.6.210 SS+37.5d | 178.75d |
| 1.3.1.6.260 |  | Delivery of Buiding Signage | 5d | 2012-03-12 | 2012-03-15 | 1.3.1.6.250 FS+125d | 191.25d |
|  | 22 | **Wood Terrlis** |  | 2011-10-12 | 2012-03-27 |  |  |
| 1.3.1.6.270 |  | Place PO for Wood Terrlis | 37.5d | 2011-10-12 | 2011-11-15 | 1.3.1.6.250 SS | 178.75d |
| 1.3.1.6.280 |  | Delivery of Wood Terrlis | 5d | 2012-03-24 | 2012-03-27 | 1.3.1.6.270 FS+137.5d | 178.75d |
|  | 2 | **ELECTRICAL WORKS** |  | 2011-07-09 | 2012-06-21 |  |  |
|  | 1 | **Switchgears** |  | 2011-07-09 | 2012-04-12 |  |  |
|  | 1 | **Switchgears** |  | 2011-07-09 | 2012-04-12 |  |  |
| 1.3.2.1.010 |  | Place PO for switchgears | 37.5d | 2011-07-09 | 2011-08-11 | 1.2.6.120 | 19.25d |
| 1.3.2.1.020 |  | Delivery of switchgears | 6d | 2012-04-02 | 2012-04-07 | 1.3.2.1.010 FS+250d | 43d |
| 1.3.2.1.030 |  | Provision of startup spare parts & Non-material-req'ts | 6d | 2012-04-07 | 2012-04-12 | 1.3.2.1.020 | 43d |
|  | 2 | **MCC -Motor Control Center** |  | 2011-08-09 | 2012-03-29 |  |  |
| 1.3.2.1.040 |  | Place PO for MCC | 37.5d | 2011-08-09 | 2011-09-12 | 1.3.2.1.010 SS+33.75d | 132.75d |
| 1.3.2.1.050 |  | Delivery of MCC | 7.5d | 2012-03-18 | 2012-03-24 | 1.3.2.1.040 FS+200d | 132.75d |
| 1.3.2.1.060 |  | Provision of startup spare parts & Non-material-req'ts | 6d | 2012-03-25 | 2012-03-29 | 1.3.2.1.050 | 132.75d |
|  | 2 | **Package Substations** |  | 2011-07-09 | 2012-04-26 |  |  |
|  | 1 | **Package Substations** |  | 2011-07-09 | 2012-04-25 |  |  |
| 1.3.2.2.1.010 |  | Place PO for package substations | 37.5d | 2011-07-09 | 2011-08-11 | 1.3.2.1.010 SS | 19.25d |
| 1.3.2.2.1.020 |  | Delivery of package substations | 7.5d | 2012-04-14 | 2012-04-19 | 1.3.2.2.1.010 FS+262.5d | 40.75d |
| 1.3.2.2.1.030 |  | Provision of startup spare parts & Non-material-req'ts | 6d | 2012-04-21 | 2012-04-25 | 1.3.2.2.1.020 | 40.75d |
|  | 2 | **RMU - Ring Main Units** |  | 2011-07-09 | 2012-04-26 |  |  |
| 1.3.2.2.2.010 |  | Place PO for RMU | 37.5d | 2011-07-09 | 2011-08-11 | 1.3.2.2.1.010 SS | 19.25d |
| 1.3.2.2.2.020 |  | Delivery of RMU | 6d | 2012-04-16 | 2012-04-21 | 1.3.2.2.2.010 FS+265d | 50.5d |
| 1.3.2.2.2.030 |  | Provision of startup spare parts & Non-material-req'ts | 6d | 2012-04-21 | 2012-04-26 | 1.3.2.2.2.020 | 50.5d |
|  | 3 | **Medium Voltage Cables** |  | 2011-07-09 | 2011-12-06 |  |  |
|  | 1 | **Medium Voltage Cables** |  | 2011-07-09 | 2011-12-06 |  |  |
| 1.3.2.3.010 |  | Place PO for medium voltage cables | 37.5d | 2011-07-09 | 2011-08-11 | 1.3.2.2.2.010 SS | 19.25d |
| 1.3.2.3.020 |  | Delivery of medium voltage cables | 6.25d | 2011-11-26 | 2011-11-30 | 1.3.2.3.010 FS+112.5d | 37.75d |
| 1.3.2.3.030 |  | Provision of startup spare parts & Non-material-req'ts | 6d | 2011-12-01 | 2011-12-06 | 1.3.2.3.020 | 37.75d |
|  | 4 | **Submersible Pumps (Lift Station Pumps)** |  | 2011-07-09 | 2012-05-12 |  |  |
|  | 1 | **Submersible Pumps (Lift Station Pumps)** |  | 2011-07-09 | 2012-05-12 |  |  |
| 1.3.2.4.010 |  | Place PO for Submersible pumps | 37.5d | 2011-07-09 | 2011-08-11 | 1.3.2.3.010 SS | 19.25d |
| 1.3.2.4.020 |  | Delivery of Submersible pumps | 6d | 2012-05-01 | 2012-05-06 | 1.3.2.4.010 FS+281.25d | 89.25d |
| 1.3.2.4.030 |  | Provision of startup spare parts & Non-material-req'ts | 6d | 2012-05-06 | 2012-05-12 | 1.3.2.4.020 | 89.25d |
|  | 5 | **Diesel Generators** |  | 2011-07-09 | 2012-05-06 |  |  |
|  | 1 | **Diesel Generator** |  | 2011-07-09 | 2012-05-06 |  |  |
| 1.3.2.5.010 |  | Place PO for diesel generators | 37.5d | 2011-07-09 | 2011-08-11 | 1.3.2.4.010 SS | 19.25d |
| 1.3.2.5.020 |  | Delivery of diesel generators | 6d | 2012-04-25 | 2012-04-30 | 1.3.2.5.010 FS+275d | 133d |
| 1.3.2.5.030 |  | SPDP/monthof diesel generators | 6d | 2012-04-30 | 2012-05-06 | 1.3.2.5.020 | 133d |
|  | 6 | **Transformers** |  | 2011-07-09 | 2012-05-09 |  |  |
|  | 1 | **Transformers** |  | 2011-07-09 | 2012-05-09 |  |  |
| 1.3.2.6.010 |  | Place PO for transformers | 37.5d | 2011-07-09 | 2011-08-11 | 1.3.2.5.010 SS | 19.25d |
| 1.3.2.6.020 |  | Delivery of transformers | 6d | 2012-04-29 | 2012-05-03 | 1.3.2.6.010 FS+278.75d | 61.75d |
| 1.3.2.6.030 |  | Provision of startup spare parts & Non-material-req'ts | 6d | 2012-05-03 | 2012-05-09 | 1.3.2.6.020 | 61.75d |
|  | 7 | **Miscellaneous Items** |  | 2011-07-09 | 2012-06-21 |  |  |
|  | 1 | **Circuit Breaker** |  | 2011-09-24 | 2012-06-05 |  |  |
| 1.3.2.7.1.010 |  | Place PO for circuit breaker | 37.5d | 2011-09-24 | 2011-10-27 | 1.3.2.6.010 FS+45d | 49.25d |
| 1.3.2.7.1.020 |  | Delivery of circuit breaker | 6d | 2012-05-26 | 2012-05-30 | 1.3.2.7.1.010 FS+225d | 71.75d |
| 1.3.2.7.1.030 |  | Provision of startup spare parts & Non-material-req'ts | 6d | 2012-05-30 | 2012-06-05 | 1.3.2.7.1.020 | 71.75d |
|  | 2 | **ATS - Automatic Transfer Switch** |  | 2011-07-09 | 2012-04-07 |  |  |
| 1.3.2.7.2.010 |  | Place PO for ATS | 37.5d | 2011-07-09 | 2011-08-11 | 1.3.2.6.010 SS | 19.25d |
| 1.3.2.7.2.020 |  | Delivery of ATS | 6d | 2012-03-27 | 2012-04-01 | 1.3.2.7.2.010 FS+243.75d | 156.75d |
| 1.3.2.7.2.030 |  | Provision of startup spare parts & Non-material-req'ts | 6d | 2012-04-01 | 2012-04-07 | 1.3.2.7.2.020 | 156.75d |

| ID | WBS | Task | Duration | Start | Finish | Predecessors | Total float |
| --- | --- | --- | --- | --- | --- | --- | --- |
|  | 3 | **Switchboard** |  | 2011-10-29 | 2012-06-05 |  |  |
| 1.3.2.7.3.010 |  | Place PO for switchboards | 37.5d | 2011-10-29 | 2011-12-01 | 1.3.2.7.1.010 SS+37.5d | 49.25d |
| 1.3.2.7.3.020 |  | Delivery of switchboards | 6d | 2012-05-26 | 2012-05-30 | 1.3.2.7.3.010 FS+187.5d | 49.25d |
| 1.3.2.7.3.030 |  | Provision of startup spare parts & Non-material-req'ts | 6d | 2012-05-30 | 2012-06-05 | 1.3.2.7.3.020 | 49.25d |
|  | 4 | **Distribution Panel / Panel Boards** |  | 2011-08-07 | 2012-04-18 |  |  |
| 1.3.2.7.4.010 |  | Place PO for Distribution panel boards | 37.5d | 2011-08-07 | 2011-09-10 | 1.3.2.7.2.010 SS+31.25d | 56.75d |
| 1.3.2.7.4.020 |  | Delivery of Distribution panel boards | 6d | 2012-04-08 | 2012-04-12 | 1.3.2.7.4.010 FS+225d | 111.75d |
| 1.3.2.7.4.030 |  | Provision of startup spare parts & Non-material-req'ts | 6d | 2012-04-12 | 2012-04-18 | 1.3.2.7.4.020 | 111.75d |
|  | 5 | **Annunciator Panel** |  | 2011-09-05 | 2012-06-21 |  |  |
| 1.3.2.7.5.010 |  | Place PO for Annunciator panels | 37.5d | 2011-09-05 | 2011-10-09 | 1.3.2.7.4.010 SS+31.25d | 56.75d |
| 1.3.2.7.5.020 |  | Delivery of Annunciator panels | 6d | 2012-06-11 | 2012-06-16 | 1.3.2.7.5.010 FS+262.5d | 65.5d |
| 1.3.2.7.5.030 |  | Provision of startup spare parts & Non-material-req'ts | 6d | 2012-06-16 | 2012-06-21 | 1.3.2.7.5.020 | 65.5d |
|  | 6 | **Battery Bank, Battery Charger** |  | 2011-10-10 | 2012-06-21 |  |  |
| 1.3.2.7.6.010 |  | Place PO for Battery bank & charger | 37.5d | 2011-10-10 | 2011-11-13 | 1.3.2.7.5.010 SS+37.5d | 76.75d |
| 1.3.2.7.6.020 |  | Delivery of Battery bank & charger | 6d | 2012-06-11 | 2012-06-16 | 1.3.2.7.6.010 FS+225d | 76.75d |
| 1.3.2.7.6.030 |  | Provision of startup spare parts & Non-material-req'ts | 6d | 2012-06-16 | 2012-06-21 | 1.3.2.7.6.020 | 76.75d |
|  | 7 | **UPS System** |  | 2011-07-09 | 2012-04-26 |  |  |
| 1.3.2.7.6.110 |  | Place PO for UPS | 37.5d | 2011-07-09 | 2011-08-11 | 1.3.2.7.2.010 SS | 19.25d |
| 1.3.2.7.6.120 |  | Delivery of UPS | 8.75d | 2012-04-14 | 2012-04-21 | 1.3.2.7.6.110 FS+262.5d | 133d |
| 1.3.2.7.6.130 |  | Provision of startup spare parts & Non-material-req'ts | 6d | 2012-04-22 | 2012-04-26 | 1.3.2.7.6.120 | 133d |
|  | 8 | **Electrical Grounding System** |  | 2011-08-30 | 2012-01-10 |  |  |
| 1.3.2.7.7.010 |  | Place PO for Electrical grounding system & Cables | 37.5d | 2011-08-30 | 2011-10-03 | 1.3.2.7.6.110 FS+18.75d | 38d |
| 1.3.2.7.7.020 |  | Delivery of Electrical grounding system & Cables | 6d | 2011-12-31 | 2012-01-04 | 1.3.2.7.7.010 FS+93.75d | 156.75d |
| 1.3.2.7.7.030 |  | Provision of startup spare parts & Non-material-req'ts | 6d | 2012-01-04 | 2012-01-10 | 1.3.2.7.7.020 | 156.75d |
|  | 9 | **Electrical Conduits & Fittings** |  | 2011-08-30 | 2011-12-06 |  |  |
| 1.3.2.7.8.010 |  | Place PO for electrical conduits & fittings | 37.5d | 2011-08-30 | 2011-10-03 | 1.3.2.7.7.010 SS | 38d |
| 1.3.2.7.8.020 |  | Delivery of electrical conduits & fittings | 6d | 2011-11-26 | 2011-11-30 | 1.3.2.7.8.010 FS+56.25d | 38d |
| 1.3.2.7.8.030 |  | Provision of startup spare parts & Non-material-req'ts | 6d | 2011-11-30 | 2011-12-06 | 1.3.2.7.8.020 | 38d |
|  | 10 | **Fire Detection System & FACP** |  | 2011-10-04 | 2012-05-12 |  |  |
| 1.3.2.7.9.010 |  | Place PO for fire detection sytem & FACP | 37.5d | 2011-10-04 | 2011-11-07 | 1.3.2.7.8.010 SS+37.5d | 71.75d |
| 1.3.2.7.9.020 |  | Delivery of fire detection sytem & FACP | 6d | 2012-05-01 | 2012-05-06 | 1.3.2.7.9.010 FS+187.5d | 71.75d |
| 1.3.2.7.9.030 |  | Provision of startup spare parts & Non-material-req'ts | 6d | 2012-05-06 | 2012-05-12 | 1.3.2.7.9.020 | 71.75d |
|  | 3 | **COMMUNICATION WORKS** |  | 2011-07-13 | 2012-08-14 |  |  |
|  | 1 | **Fiber Optic Cables** |  | 2011-09-14 | 2012-07-19 |  |  |
|  | 1 | **Fiber Optic Cables** |  | 2011-09-14 | 2012-04-22 |  |  |
| 1.3.3.1.1.010 |  | Place PO for fiber optic cables | 37.5d | 2011-09-14 | 2011-10-18 | 1.2.6.040 FS+10d, 1.3.2.7.5.010 SS+10d | 56.75d |
| 1.3.3.1.1.020 |  | Delivery of fiber optic cables | 6d | 2012-04-11 | 2012-04-16 | 1.3.3.1.1.010 FS+187.5d | 59.25d |
| 1.3.3.1.1.030 |  | Provision of startup spare parts & Non-material-req'ts | 6d | 2012-04-16 | 2012-04-22 | 1.3.3.1.1.020 | 59.25d |
|  | 2 | **Patch Panels** |  | 2011-10-19 | 2012-07-01 |  |  |
| 1.3.3.1.2.010 |  | Place PO for fiber optic patch panels | 37.5d | 2011-10-19 | 2011-11-22 | 1.3.3.1.1.010 SS+37.5d | 56.75d |
| 1.3.3.1.2.020 |  | Delivery of fiber optic patch panels | 6d | 2012-06-20 | 2012-06-25 | 1.3.3.1.2.010 FS+225d | 69.25d |
| 1.3.3.1.2.030 |  | Provision of startup spare parts & Non-material-req'ts | 6d | 2012-06-25 | 2012-07-01 | 1.3.3.1.2.020 | 69.25d |
|  | 3 | **Splice Enclosure** |  | 2011-11-12 | 2012-07-19 |  |  |
| 1.3.3.1.3.010 |  | Place PO for fiber optic splice closure | 37.5d | 2011-11-12 | 2011-12-15 | 1.3.3.1.2.010 SS+25d | 56.75d |
| 1.3.3.1.3.020 |  | Delivery of fiber optic splice closure | 6d | 2012-07-09 | 2012-07-14 | 1.3.3.1.3.010 FS+220d | 69.25d |
| 1.3.3.1.3.030 |  | Provision of startup spare parts & Non-material-req'ts | 6d | 2012-07-14 | 2012-07-19 | 1.3.3.1.3.020 | 69.25d |
|  | 4 | **Copper Cables** |  | 2011-11-12 | 2012-07-19 |  |  |
| 1.3.3.1.4.010 |  | Place PO for copper cables | 37.5d | 2011-11-12 | 2011-12-15 | 1.3.3.1.3.010 SS | 56.75d |
| 1.3.3.1.4.020 |  | Delivery of copper cables | 6d | 2012-07-09 | 2012-07-14 | 1.3.3.1.4.010 FS+220d | 56.75d |
| 1.3.3.1.4.030 |  | Provision of startup spare parts & Non-material-req'ts | 6d | 2012-07-14 | 2012-07-19 | 1.3.3.1.4.020 | 56.75d |
|  | 2 | **Communication Duct bank systems** |  | 2011-07-13 | 2012-06-25 |  |  |
|  | 1 | **Comm Duct & Sub-duct Conduits & Fittings** |  | 2011-07-13 | 2012-01-15 |  |  |
| 1.3.3.2.1.010 |  | Place PO for comm duct & subduct conduits & fittings | 37.5d | 2011-07-13 | 2011-08-16 | 1.3.2.7.6.110 SS+5d | 19.25d |
| 1.3.3.2.1.020 |  | Delivery of comm duct & subduct conduits & fittings | 6d | 2012-01-04 | 2012-01-09 | 1.3.3.2.1.010 FS+150d | 88d |
| 1.3.3.2.1.030 |  | Provision of startup spare parts & Non-material-req'ts | 6d | 2012-01-09 | 2012-01-15 | 1.3.3.2.1.020 | 88d |
|  | 2 | **Communication Cabinet & Accs** |  | 2011-07-31 | 2012-03-07 |  |  |
| 1.3.3.2.1.110 |  | Place PO for comm cabinet & accs | 37.5d | 2011-07-31 | 2011-09-03 | 1.3.3.2.1.010 SS+18.75d | 19.25d |
| 1.3.3.2.1.120 |  | Delivery of comm cabinet & accs | 6d | 2012-02-26 | 2012-03-01 | 1.3.3.2.1.110 FS+187.5d | 91.75d |
| 1.3.3.2.1.130 |  | Provision of startup spare parts & Non-material-req'ts | 6d | 2012-03-01 | 2012-03-07 | 1.3.3.2.1.120 | 91.75d |
|  | 3 | **Comm Cable Trays** |  | 2011-08-07 | 2012-03-03 |  |  |
| 1.3.3.2.2.010 |  | Place PO for cable trays | 25d | 2011-08-07 | 2011-08-29 | 1.3.2.7.6.110 SS+31.25d | 66.75d |
| 1.3.3.2.2.020 |  | Delivery of cabel trays | 6d | 2012-02-21 | 2012-02-26 | 1.3.3.2.2.010 FS+187.5d | 66.75d |
| 1.3.3.2.2.030 |  | Material receiving inspection & approval | 6d | 2012-02-26 | 2012-03-03 | 1.3.3.2.2.020 | 66.75d |
|  | 4 | **Telecomm Equipments** |  | 2011-08-30 | 2012-04-07 |  |  |
| 1.3.3.2.2.110 |  | Place PO for Telecfomm equipments | 37.5d | 2011-08-30 | 2011-10-03 | 1.3.3.2.1.110 SS+32.5d | 19.25d |
| 1.3.3.2.2.120 |  | Delivery of telecomm equipments | 6d | 2012-03-27 | 2012-04-01 | 1.3.3.2.2.110 FS+187.5d | 104.25d |
| 1.3.3.2.2.130 |  | Material receiving inspection & approval | 6d | 2012-04-01 | 2012-04-07 | 1.3.3.2.2.120 | 104.25d |
|  | 5 | **Comm FOC [Fiber Optic Cable] Manholes** |  | 2011-07-13 | 2012-01-15 |  |  |
| 1.3.3.2.3.010 |  | Place PO for FOC Manholes | 37.5d | 2011-07-13 | 2011-08-16 | 1.3.2.7.6.110 SS+5d | 64.25d |
| 1.3.3.2.3.020 |  | Delivery of comm manhole materials | 6.25d | 2012-01-04 | 2012-01-09 | 1.3.3.2.3.010 FS+150d | 132.75d |

| ID | WBS | Task | Duration | Start | Finish | Predecessors | Total float |
| --- | --- | --- | --- | --- | --- | --- | --- |
| 1.3.3.2.3.030 |  | Material receiving inspection & approval | 6d | 2012-01-10 | 2012-01-15 | 1.3.3.2.3.020 | 132.75d |
|  | 6 | **Comm Copper Cable Manholes** |  | 2011-07-13 | 2012-02-19 |  |  |
| 1.3.3.2.4.010 |  | Place PO for Copper cable Manholes | 37.5d | 2011-07-13 | 2011-08-16 | 1.3.3.2.3.010 SS | 64.25d |
| 1.3.3.2.4.020 |  | Delivery of comm copper cable manhole materials | 6d | 2012-02-08 | 2012-02-13 | 1.3.3.2.4.010 FS+187.5d | 95.5d |
| 1.3.3.2.4.030 |  | Material receiving inspection & approval | 6d | 2012-02-13 | 2012-02-19 | 1.3.3.2.4.020 | 95.5d |
|  | 7 | **Comm Copper Cable Closure** |  | 2011-08-30 | 2012-05-02 |  |  |
| 1.3.3.2.5.010 |  | Place PO for comm copper cable closure | 27.5d | 2011-08-30 | 2011-09-24 | 1.3.3.2.2.110 SS | 19.25d |
| 1.3.3.2.5.020 |  | Delivery of comm copper cable closure | 6d | 2012-04-22 | 2012-04-26 | 1.3.3.2.5.010 FS+225d | 153d |
| 1.3.3.2.5.030 |  | Provision of startup spare parts & Non-material-req'ts | 6d | 2012-04-26 | 2012-05-02 | 1.3.3.2.5.020 | 153d |
|  | 8 | **Comm Grounding System** |  | 2011-09-08 | 2012-06-25 |  |  |
| 1.3.3.2.6.010 |  | Place PO for comm grounding system | 37.5d | 2011-09-08 | 2011-10-12 | 1.3.3.2.5.010 SS+10d | 19.25d |
| 1.3.3.2.6.020 |  | Delivery of comm grounding system | 6d | 2012-06-14 | 2012-06-19 | 1.3.3.2.6.010 FS+262.5d | 150.5d |
| 1.3.3.2.6.030 |  | Provision of startup spare parts & Non-material-req'ts | 6d | 2012-06-19 | 2012-06-25 | 1.3.3.2.6.020 | 150.5d |
|  | 9 | **Comm Concrete Ductbank Materials** |  | 2011-07-19 | 2011-12-17 |  |  |
| 1.3.3.2.7.010 |  | Place PO for comm concrete ductbank materials | 37.5d | 2011-07-19 | 2011-08-22 | 1.3.3.2.4.010 SS+6.25d | 64.25d |
| 1.3.3.2.7.020 |  | Delivery of comm ductbank materials | 6d | 2011-12-06 | 2011-12-11 | 1.3.3.2.7.010 SS+150d | 176.75d |
| 1.3.3.2.7.030 |  | Material receiving inspection & approval | 6d | 2011-12-11 | 2011-12-17 | 1.3.3.2.7.020 | 176.75d |
|  | 10 | **Electrical Ductbank Materials** |  | 2011-07-19 | 2011-11-12 |  |  |
| 1.3.3.2.8.010 |  | Place PO for comm electrical ductbank materials | 37.5d | 2011-07-19 | 2011-08-22 | 1.3.3.2.7.010 SS | 64.25d |
| 1.3.3.2.8.020 |  | Delivery of electrical ductbank materials | 6d | 2011-11-01 | 2011-11-06 | 1.3.3.2.8.010 SS+112.5d | 64.25d |
| 1.3.3.2.8.030 |  | Material receiving inspection & approval | 6d | 2011-11-06 | 2011-11-12 | 1.3.3.2.8.020 | 64.25d |
|  | 3 | **Miscellaneous Communication Items** |  | 2011-09-24 | 2012-08-14 |  |  |
|  | 1 | **Communication CCTV System** |  | 2011-09-24 | 2012-06-05 |  |  |
| 1.3.3.3.010 |  | Place PO for CCTV system materials | 37.5d | 2011-09-24 | 2011-10-27 | 1.3.3.2.6.010 SS+16.25d | 19.25d |
| 1.3.3.3.020 |  | Delivery of CCTV system materials | 6d | 2012-05-26 | 2012-05-30 | 1.3.3.3.010 FS+225d | 75.5d |
| 1.3.3.3.030 |  | Provision of startup spare parts & Non-material-req'ts | 6d | 2012-05-30 | 2012-06-05 | 1.3.3.3.020 | 75.5d |
|  | 2 | **Communication SACS System** |  | 2011-10-29 | 2012-08-14 |  |  |
| 1.3.3.3.110 |  | Place PO for Comm SACS System | 37.5d | 2011-10-29 | 2011-12-01 | 1.3.3.3.010 SS+37.5d | 69d |
| 1.3.3.3.120 |  | Delivery of comm SACS system | 6.25d | 2012-08-04 | 2012-08-08 | 1.3.3.3.110 FS+262.5d | 69d |
| 1.3.3.3.130 |  | Provision of startup spare parts & Non-material-req'ts | 6d | 2012-08-09 | 2012-08-14 | 1.3.3.3.120 | 69d |
|  | 4 | **LANDSCAPING WORKS** |  | 2011-09-24 | 2012-06-14 |  |  |
|  | 1 | **Landscaping & Playground Materials** |  | 2011-09-24 | 2012-06-14 |  |  |
|  | 1 | **Landscaping Materials** |  | 2011-09-24 | 2012-03-27 |  |  |
| 1.3.4.1.010 |  | Place PO for trees/shrubs/ground covers | 37.5d | 2011-09-24 | 2011-10-27 | 1.3.3.3.010 SS | 19.25d |
| 1.3.4.1.020 |  | Delivery of trees/shrubs/ground covers | 6d | 2012-03-17 | 2012-03-21 | 1.3.4.1.010 FS+150d | 19.25d |
| 1.3.4.1.030 |  | Material receiving inspection & approval | 6d | 2012-03-21 | 2012-03-27 | 1.3.4.1.020 | 19.25d |
|  | 2 | **Playground Materials** |  | 2011-10-03 | 2012-06-14 |  |  |
| 1.3.4.1.110 |  | Place PO for playground utilities | 37.5d | 2011-10-03 | 2011-11-06 | 1.3.4.1.010 SS+10d | 67.75d |
| 1.3.4.1.120 |  | Delivery of playground utilities | 6.25d | 2012-06-04 | 2012-06-09 | 1.3.4.1.110 FS+225d | 67.75d |
| 1.3.4.1.130 |  | Provision of startup spare parts & Non-material-req'ts | 6d | 2012-06-10 | 2012-06-14 | 1.3.4.1.120 | 67.75d |
|  | 5 | **UTILITIES & SERVICE WORKS** |  | 2011-06-25 | 2012-07-28 |  |  |
|  | 1 | **Potable & Fire Water Pipelines & Fittings** |  | 2011-07-16 | 2012-07-28 |  |  |
|  | 2 | **Potable / Fire water /Sewer Pipes (RTR) & Fittings** |  | 2011-07-16 | 2011-12-06 |  |  |
| 1.3.5.1.2.010 |  | Place PO for potable / fire water /sewer pipe (RTR) | 30d | 2011-07-16 | 2011-08-11 | 1.3.2.1.010 SS+7.5d | 25d |
| 1.3.5.1.2.020 |  | Delivery of RTR & fittings | 6d | 2011-11-26 | 2011-11-30 | 1.3.5.1.2.010 FS+112.5d | 104.25d |
| 1.3.5.1.2.030 |  | Provision of startup spare parts & Non-material-req'ts | 6d | 2011-11-30 | 2011-12-06 | 1.3.5.1.2.020 | 104.25d |
|  | 3 | **Potable & Fire water valves & accs** |  | 2011-07-20 | 2012-04-01 |  |  |
| 1.3.5.1.3.010 |  | Place PO for potable & fire water valves | 37.5d | 2011-07-20 | 2011-08-23 | 1.3.5.1.2.010 SS+5d | 38d |
| 1.3.5.1.3.020 |  | Delivery of valves & accs | 6d | 2012-03-21 | 2012-03-26 | 1.3.5.1.3.010 FS+225d | 158d |
| 1.3.5.1.3.030 |  | Provision of startup spare parts & Non-material-req'ts | 6d | 2012-03-26 | 2012-04-01 | 1.3.5.1.3.020 | 158d |
|  | 4 | **Fire Hydrants & Accs** |  | 2011-12-19 | 2012-07-28 |  |  |
| 1.3.5.1.3.040 |  | Place PO for fire hydrants & accs | 37.5d | 2011-12-19 | 2012-01-22 | 1.3.5.1.3.010 FS+125d | 63d |
| 1.3.5.1.3.050 |  | Delivery of fire hydranst | 6d | 2012-07-17 | 2012-07-22 | 1.3.5.1.3.040 FS+188.75d | 63d |
| 1.3.5.1.3.060 |  | Provision of startup spare parts & Non-material-req'ts | 6d | 2012-07-22 | 2012-07-28 | 1.3.5.1.3.050 | 63d |
|  | 2 | **Sanitary Sewer Pipeline & Related Equipments** |  | 2011-07-16 | 2012-05-06 |  |  |
|  | 1 | **Sewer FRP Manholes** |  | 2011-07-16 | 2011-09-20 |  |  |
| 1.3.5.2.1.010 |  | Place PO for sewer FRP Manhole | 28.75d | 2011-07-16 | 2011-08-10 | 1.3.5.1.2.010 SS | 25d |
| 1.3.5.2.1.020 |  | Delivery of sewer FRP Manhole | 3.75d | 2011-09-12 | 2011-09-14 | 1.3.5.2.1.010 FS+33.75d | 45.25d |
| 1.3.5.2.1.030 |  | Provision of startup spare parts & Non-material-req'ts | 6d | 2011-09-15 | 2011-09-20 | 1.3.5.2.1.020 | 45.25d |
|  | 2 | **Sewer pipes (uPVC) & Fittings** |  | 2011-07-16 | 2011-09-20 |  |  |
| 1.3.5.2.2.010 |  | Place PO for sewer (uPVC) pipes | 33.75d | 2011-07-16 | 2011-08-15 | 1.3.5.1.2.010 SS | 76.5d |
| 1.3.5.2.2.020 |  | Delivery of sewer (uPVC) pipes | 2.5d | 2011-09-13 | 2011-09-14 | 1.3.5.2.2.010 FS+30d | 76.5d |
| 1.3.5.2.2.030 |  | Provision of startup spare parts & Non-material-req'ts | 6d | 2011-09-15 | 2011-09-20 | 1.3.5.2.2.020 | 76.5d |
|  | 3 | **Plumbing Fixtures & Accs** |  | 2011-07-30 | 2012-01-31 |  |  |
| 1.3.5.2.3.010 |  | Place PO for Plumbing fixtures & accs | 37.5d | 2011-07-30 | 2011-09-01 | 1.3.5.1.3.010 SS+10d | 38d |
| 1.3.5.2.3.020 |  | Delivery of Plumbing fixtures & accs | 6d | 2012-01-21 | 2012-01-25 | 1.3.5.2.3.010 FS+150d | 38d |
| 1.3.5.2.3.030 |  | Provision of startup spare parts & Non-material-req'ts | 6d | 2012-01-25 | 2012-01-31 | 1.3.5.2.3.020 | 38d |
|  | 4 | **Sewer pipes valve & accs** |  | 2011-07-30 | 2012-05-06 |  |  |
| 1.3.5.2.4.010 |  | Place PO for sewer valves & accs | 27.5d | 2011-07-30 | 2011-08-23 | 1.3.5.2.3.010 SS | 71.75d |
| 1.3.5.2.4.020 |  | Delivery of sewer valves & accs | 6d | 2012-04-25 | 2012-04-30 | 1.3.5.2.4.010 FS+262.5d | 71.75d |

| ID | WBS | Task | Duration | Start | Finish | Predecessors | Total float |
| --- | --- | --- | --- | --- | --- | --- | --- |
| 1.3.5.2.4.030 |  | Provision of startup spare parts & Non-material-req'ts | 6d | 2012-04-30 | 2012-05-06 | 1.3.5.2.4.020 | 71.75d |
|  | 5 | **Sewer - odour control system** |  | 2011-07-16 | 2012-04-24 |  |  |
| 1.3.5.2.5.010 |  | Place PO for sewer odour control system | 30d | 2011-07-16 | 2011-08-11 | 1.3.5.2.1.010 SS | 25d |
| 1.3.5.2.5.020 |  | Delivery of sewer odour control system | 6d | 2012-04-14 | 2012-04-18 | 1.3.5.2.5.010 FS+262.5d | 94.25d |
| 1.3.5.2.5.030 |  | Provision of startup spare parts & Non-material-req'ts | 6d | 2012-04-18 | 2012-04-24 | 1.3.5.2.5.020 | 94.25d |
|  | 6 | **Ductile Iron pipes & Fittings** |  | 2011-09-28 | 2012-04-26 |  |  |
| 1.3.5.2.6.010 |  | Place PO for ductile iron pipes & fittings | 30d | 2011-09-28 | 2011-10-25 | 1.3.5.2.5.010 FS+50d | 91.5d |
| 1.3.5.2.6.020 |  | Delivery of ductile iron pipes & fittings | 3.75d | 2012-04-18 | 2012-04-21 | 1.3.5.2.6.010 FS+187.5d | 91.5d |
| 1.3.5.2.6.030 |  | Provision of startup spare parts & Non-material-req'ts | 6d | 2012-04-22 | 2012-04-26 | 1.3.5.2.6.020 | 91.5d |
|  | 3 | **Irrigation Pipeline & related equipments** |  | 2011-07-16 | 2012-05-09 |  |  |
|  | 1 | **Irrigation pipeline & fittings** |  | 2011-07-16 | 2012-01-19 |  |  |
| 1.3.5.3.1.010 |  | Place PO for irrigation pipeline & fittings | 40d | 2011-07-16 | 2011-08-21 | 1.3.5.2.5.010 SS | 25d |
| 1.3.5.3.1.020 |  | Delivery of irrigation pipeline & fittings | 6d | 2012-01-09 | 2012-01-14 | 1.3.5.3.1.010 FS+150d | 56.75d |
| 1.3.5.3.1.030 |  | Provision of startup spare parts & Non-material-req'ts | 6d | 2012-01-14 | 2012-01-19 | 1.3.5.3.1.020 | 56.75d |
|  | 2 | **Irrigation valves & accs** |  | 2011-07-27 | 2012-05-06 |  |  |
| 1.3.5.3.2.010 |  | Place PO for irrigation valves & accs | 30d | 2011-07-27 | 2011-08-23 | 1.3.5.3.1.010 SS+12.5d | 25d |
| 1.3.5.3.2.020 |  | Delivery of irrigation valves & accs | 6d | 2012-04-25 | 2012-04-30 | 1.3.5.3.2.010 FS+262.5d | 120.5d |
| 1.3.5.3.2.030 |  | Provision of startup spare parts & Non-material-req'ts | 6d | 2012-04-30 | 2012-05-06 | 1.3.5.3.2.020 | 120.5d |
|  | 3 | **Irrigation controllers** |  | 2011-09-01 | 2012-05-09 |  |  |
| 1.3.5.3.3.010 |  | Place PO for irrigation controllers | 30d | 2011-09-01 | 2011-09-28 | 1.3.5.3.2.010 SS+38.75d | 25d |
| 1.3.5.3.3.020 |  | Delivery of irrigation controllers | 8d | 2012-04-26 | 2012-05-03 | 1.3.5.3.3.010 FS+225d | 36d |
| 1.3.5.3.3.030 |  | Provision of startup spare parts & Non-material-req'ts | 6d | 2012-05-03 | 2012-05-09 | 1.3.5.3.3.020 | 36d |
|  | 4 | **Irrigation Junction Boxes** |  | 2011-09-25 | 2012-04-26 |  |  |
| 1.3.5.3.4.010 |  | Place PO for irrigation junction boxes | 30d | 2011-09-25 | 2011-10-22 | 1.3.5.3.3.010 SS+25d | 49.75d |
| 1.3.5.3.4.020 |  | Delivery of irrigation junction boxes | 8d | 2012-04-14 | 2012-04-21 | 1.3.5.3.4.010 FS+186.25d | 49.75d |
| 1.3.5.3.4.030 |  | Provision of startup spare parts & Non-material-req'ts | 6d | 2012-04-21 | 2012-04-26 | 1.3.5.3.4.020 | 49.75d |
|  | 4 | **Street Lighting Network & Related Equipments** |  | 2011-06-25 | 2012-05-13 |  |  |
|  | 01 | **Street Lighting Poles (For Patrol Roads)** |  | 2011-06-25 | 2011-08-14 |  |  |
| 1.3.5.4.1.010 |  | Place PO for street lighting poles (Patrol Roads) | 7.5d | 2011-06-25 | 2011-06-30 | 1.3.1.6.130 FS+100d | 59d |
| 1.3.5.4.1.020 |  | Delivery of street lighting poles (Patrol Roads) | 6d | 2011-08-06 | 2011-08-10 | 1.3.5.4.1.010 FS+37.5d | 101.5d |
| 1.3.5.4.1.030 |  | Provision of startup spare parts & Non-material-req'ts | 3.75d | 2011-08-10 | 2011-08-14 | 1.3.5.4.1.020 | 101.5d |
|  | 02 | **Street Lighting Fixtures (For Patrol Roads)** |  | 2011-06-25 | 2011-08-13 |  |  |
| 1.3.5.4.2.010 |  | Place PO for street lighting fixtures (Patrol Roads) | 7.5d | 2011-06-25 | 2011-06-30 | 1.3.5.4.1.010 SS | 59d |
| 1.3.5.4.2.020 |  | Delivery of street lighting fixtures (Patrol Roads) | 5d | 2011-08-06 | 2011-08-09 | 1.3.5.4.2.010 FS+37.5d | 102.5d |
| 1.3.5.4.2.030 |  | Provision of startup spare parts & Non-material-req'ts | 3.75d | 2011-08-10 | 2011-08-13 | 1.3.5.4.2.020 | 102.5d |
|  | 03 | **LV Cables (For Patrol Roads)** |  | 2011-06-25 | 2011-08-10 |  |  |
| 1.3.5.4.3.010 |  | Place PO for LV cables (Patrol Roads) | 5d | 2011-06-25 | 2011-06-28 | 1.3.5.4.2.010 SS | 59d |
| 1.3.5.4.3.020 |  | Delivery of LV cables (Patrol Roads) | 5d | 2011-08-03 | 2011-08-07 | 1.3.5.4.3.010 FS+37.5d | 105d |
| 1.3.5.4.3.030 |  | Provision of startup spare parts & Non-material-req'ts | 3.75d | 2011-08-08 | 2011-08-10 | 1.3.5.4.3.020 | 105d |
|  | 04 | **Street Light Poles (For Permanent Roads)** |  | 2011-09-11 | 2012-04-12 |  |  |
| 1.3.5.4.4.010 |  | Place PO for Light Poles (Permanent Roads) | 30d | 2011-09-11 | 2011-10-08 | 1.4.5.4.6.010 SS+10d | 76.25d |
| 1.3.5.4.4.020 |  | Delivery of Light Poles (Permenent Roads) | 7.5d | 2012-03-31 | 2012-04-05 | 1.3.5.4.4.010 FS+186.25d | 83.75d |
| 1.3.5.4.4.030 |  | Provision of startup spare parts & Non-material-req'ts | 7.5d | 2012-04-07 | 2012-04-12 | 1.3.5.4.4.020 | 83.75d |
|  | 05 | **Street Light Fixtures (For Permenent Roads)** |  | 2011-09-11 | 2012-04-19 |  |  |
| 1.4.5.4.5.010 |  | Place PO for Light Fixtures (Permanent Roads) | 37.5d | 2011-09-11 | 2011-10-15 | 1.3.5.4.4.010 SS | 76.25d |
| 1.4.5.4.5.020 |  | Delivery of Light Fixtures (Permanent Roads) | 7.5d | 2012-04-07 | 2012-04-12 | 1.4.5.4.5.010 FS+186.25d | 76.25d |
| 1.4.5.4.5.030 |  | Provision of startup spare parts & Non-material-req'ts | 7.5d | 2012-04-14 | 2012-04-19 | 1.4.5.4.5.020 | 76.25d |
|  | 06 | **LV Cables (For Permanent Roads)** |  | 2011-09-01 | 2012-02-22 |  |  |
| 1.4.5.4.6.010 |  | Place PO for LV cables (Permanent Roads) | 30d | 2011-09-01 | 2011-09-28 | 1.3.5.3.3.010 SS | 25d |
| 1.4.5.4.6.020 |  | Delivery of LV Cables (Permanent Roads) | 7.5d | 2012-02-16 | 2012-02-22 | 1.4.5.4.6.010 FS+150d | 25d |
| 1.4.5.4.6.030 |  | Provision of startup spare parts & Non-material-req'ts | 7.5d | 2012-02-16 | 2012-02-22 | 1.4.5.4.6.020 SS | 25d |
|  | 07 | **HVAC Equipments** |  | 2011-06-25 | 2012-04-10 |  |  |
| 1.3.5.4.7.010 |  | Place PO for HVAC Equipments | 30d | 2011-06-25 | 2011-07-21 | 1.3.5.4.3.010 SS | 59d |
| 1.3.5.4.7.020 |  | Delivery of HVAC Equipments | 10d | 2012-03-24 | 2012-04-01 | 1.3.5.4.7.010 FS+262.5d | 89.75d |
| 1.3.5.4.7.030 |  | Provision of startup spare parts & Non-material-req'ts | 10d | 2012-04-02 | 2012-04-10 | 1.3.5.4.7.020 | 89.75d |
|  | 08 | **Volume & Fire Dampers** |  | 2011-07-06 | 2012-04-22 |  |  |
| 1.3.5.4.9.010 |  | Place PO for volume & fire dampers | 30d | 2011-07-06 | 2011-08-02 | 1.3.5.4.7.010 SS+12.5d | 59d |
| 1.3.5.4.9.020 |  | Delivery of volume & fire dampers | 10d | 2012-04-04 | 2012-04-12 | 1.3.5.4.9.010 FS+262.5d | 77.25d |
| 1.3.5.4.9.030 |  | Provision of startup spare parts & Non-material-req'ts | 10d | 2012-04-14 | 2012-04-22 | 1.3.5.4.9.020 | 77.25d |
|  | 09 | **Moduler Rectifier / Inverter** |  | 2011-07-06 | 2012-04-22 |  |  |
| 1.3.5.4.10.010 |  | Place PO for moduler rectifier / inverter | 30d | 2011-07-06 | 2011-08-02 | 1.3.5.4.9.010 SS | 59d |
| 1.3.5.4.10.020 |  | Delivery of moduler rectifier / inverter | 10d | 2012-04-04 | 2012-04-12 | 1.3.5.4.10.010 FS+262.5d | 77.25d |
| 1.3.5.4.10.030 |  | Provision of startup spare parts & Non-material-req'ts | 10d | 2012-04-14 | 2012-04-22 | 1.3.5.4.10.020 | 77.25d |
|  | 10 | **Exhaust Fans** |  | 2011-07-27 | 2012-05-13 |  |  |
| 1.3.5.4.10.040 |  | Place PO for exhaust fans | 30d | 2011-07-27 | 2011-08-23 | 1.3.5.4.10.010 SS+22.5d | 59d |
| 1.3.5.4.10.050 |  | Delivery of exhasust fans | 10d | 2012-04-25 | 2012-05-03 | 1.3.5.4.10.040 FS+262.5d | 116.75d |
| 1.3.5.4.10.060 |  | Provision of startup spare parts & Non-material-req'ts | 10d | 2012-05-05 | 2012-05-13 | 1.3.5.4.10.050 | 116.75d |
|  | 5 | **Fitness Shelter equipemnts & Furnitures** |  | 2011-12-08 | 2012-07-19 |  |  |
|  | 1 | **Fitness Shelter equipments & furniture** |  | 2011-12-08 | 2012-07-19 |  |  |
| 1.3.5.5.010 |  | Place PO for fitness & art shelters furniture | 37.5d | 2011-12-08 | 2012-01-11 | 1.3.5.4.10.040 FS+113.75d | 59d |

| ID | WBS | Task | Duration | Start | Finish | Predecessors | Total float |
| --- | --- | --- | --- | --- | --- | --- | --- |
| 1.3.5.5.020 |  | Delivery of fitness & art shelters furniture | 6d | 2012-07-05 | 2012-07-10 | 1.3.5.5.010 SS+225d | 59d |
| 1.3.5.5.030 |  | SPDP/monthof fitness & art shelters furniture | 10d | 2012-07-10 | 2012-07-19 | 1.3.5.5.020 | 59d |
|  | C.1.4 | **CONSTRUCTION** |  | 2011-01-09 | 2013-06-29 |  |  |
|  | 1 | **MOBILIZATION** |  | 2011-01-09 | 2011-09-28 |  |  |
|  | 1 | **Mobilization** |  | 2011-01-09 | 2011-03-10 |  |  |
|  | 2 | **Mobilization of Temp. Fac. @ Zone 4** |  | 2011-01-09 | 2011-03-10 |  |  |
| 1.4.1.1.110 |  | Install of temp fence at zone 4 | 40d | 2011-01-09 | 2011-02-14 | M1.00 | 46.25d |
| 1.4.1.1.210 |  | Construction of contractor site offices | 40d | 2011-01-18 | 2011-02-23 | 1.4.1.1.110 SS+10d | 46.25d |
| 1.4.1.1.130 |  | Const/Install of laydown yards | 40d | 2011-01-20 | 2011-02-26 | 1.4.1.1.110 SS+12.5d | 117.5d |
| 1.4.1.1.120 |  | Construction of SAPMT office | 31.25d | 2011-02-01 | 2011-03-01 | 1.4.1.1.210 SS+15d | 127.5d |
| 1.4.1.1.220 |  | Mobilization of equipments | 30d | 2011-02-01 | 2011-02-28 | 1.4.1.1.130 SS+12.5d | 117.5d |
| 1.4.1.1.140 |  | Install electric lighting system for site offices | 20d | 2011-02-10 | 2011-02-28 | 1.4.1.1.210 SS+25d | 46.25d |
| 1.4.1.1.230 |  | Mobilization of Manpower | 31.25d | 2011-02-10 | 2011-03-10 | 1.4.1.1.220 SS+10d, 1.4.1.1.110 SS+10d | 117.5d |
| 1.4.1.1.150 |  | Install water supply system for offices | 15d | 2011-02-22 | 2011-03-07 | 1.4.1.1.140 SS+12.5d | 46.25d |
| 1.4.1.1.160 |  | Install sanitary system for offices | 11.25d | 2011-02-28 | 2011-03-09 | 1.4.1.1.150 SS+6.25d | 46.25d |
| 1.4.1.1.170 |  | Install fire protection sytem for offices | 8.75d | 2011-03-02 | 2011-03-09 | 1.4.1.1.160 SS+2.5d | 118.75d |
| 1.4.1.1.180 |  | Install furniture & accs in offices | 8.75d | 2011-03-02 | 2011-03-09 | 1.4.1.1.170 SS | 118.75d |
| 1.4.1.1.190 |  | Install computers / equipments & accs in offices | 8.75d | 2011-03-02 | 2011-03-09 | 1.4.1.1.180 SS | 118.75d |
| 1.4.1.1.200 |  | Install telecomm system for offices | 8.75d | 2011-03-02 | 2011-03-09 | 1.4.1.1.190 SS | 118.75d |
|  | 2 | **Demolition of existing structure** |  | 2011-06-09 | 2011-09-28 |  |  |
|  | 1 | **Demolition of existing structure** |  | 2011-06-09 | 2011-09-28 |  |  |
|  | 1 | **Zone 2** |  | 2011-07-24 | 2011-09-17 |  |  |
| 1.4.1.2.1.010 |  | Demolition of existing laydown yard etc. | 30d | 2011-07-24 | 2011-08-20 | 1.4.1.3.2.010, M1.00 FS+15d, 1.4.1.1.120, 1.4.1.1.200 | 195d |
| 1.4.1.2.1.020 |  | Demolition of existing asphalt pavement | 30d | 2011-08-21 | 2011-09-17 | 1.4.1.2.1.010 | 195d |
|  | 2 | **Zone 3** |  | 2011-06-09 | 2011-09-28 |  |  |
| 1.4.1.2.2.010 |  | Demolition of existing concrete pad/structure | 30d | 2011-06-09 | 2011-07-06 | 1.4.1.3.3.010 | 106.25d |
| 1.4.1.2.2.020 |  | Demolition of existing porta cabin , tank | 30d | 2011-07-07 | 2011-08-03 | 1.4.1.2.2.010 | 106.25d |
| 1.4.1.2.2.030 |  | Demolition of existing temporary bldgs | 30d | 2011-08-04 | 2011-08-31 | 1.4.1.2.2.020 | 106.25d |
| 1.4.1.2.2.040 |  | Demolition of existing generator shed | 30d | 2011-09-01 | 2011-09-28 | 1.4.1.2.2.030 | 106.25d |
|  | 2 | **UTILITIES & SERVICES WORKS** |  | 2011-03-19 | 2012-12-17 |  |  |
|  | 1 | **Site Preparations** |  | 2011-04-10 | 2011-11-05 |  |  |
|  | 1 | **Site Topographic Survey & Layout** |  | 2011-05-03 | 2011-06-28 |  |  |
|  | 1 | **Site Topographic Survey & Layout** |  | 2011-05-03 | 2011-06-28 |  |  |
| 1.4.1.3.1.200 |  | Site topographic survey & survey layout & stacking | 31.25d | 2011-05-03 | 2011-05-31 | 1.4.1.3.3.010 SS+25d, M2.01, M2.02, M2.03, 1.4.1.1.200 | 61.25d |
| 1.4.1.3.1.210 |  | Geotechnical Soil Investigation | 31.25d | 2011-05-31 | 2011-06-28 | 1.4.1.3.1.200 SS+30d | 61.25d |
|  | 2 | **Zone 1** |  | 2011-04-10 | 2011-06-08 |  |  |
|  | 2 | **Site Preparation** |  | 2011-04-10 | 2011-06-08 |  |  |
| Z1.1010 |  | Site clearing/grubbing/disposal zone1 | 15d | 2011-04-10 | 2011-04-23 | 1.4.1.3.1.010 | 110d |
| Z1.1020 |  | Cutting/backfilling/grading zone1 | 25d | 2011-04-24 | 2011-05-16 | Z1.1010, 1.3.1.6.140 SS | 110d |
| Z1.1030 |  | Install temporary access for Zone 1 | 25d | 2011-05-17 | 2011-06-08 | Z1.1020 | 110d |
|  | 3 | **Zone 3** |  | 2011-07-06 | 2011-09-06 |  |  |
|  | 01 | **Site Preparation** |  |  |  |  |  |
|  | 02 | **A3-1** |  | 2011-07-06 | 2011-08-15 |  |  |
| Z3.1010 |  | Site Clearing/Grubbing/Disposal | 12.5d | 2011-07-06 | 2011-07-17 | 1.4.1.3.1.210 FS+7.5d, M2.04 | 61.25d |
| Z3.1020 |  | Backfill/Compaction of soil upto desired level | 31.25d | 2011-07-18 | 2011-08-15 | Z3.1010, 1.3.1.6.140 SS | 61.25d |
|  | 03 | **A3-2** |  | 2011-07-09 | 2011-08-17 |  |  |
| Z3.2020 |  | Site Clearing/Grubbing/Disposal | 12.5d | 2011-07-09 | 2011-07-19 | 1.4.1.3.3.010 FS+31.25d | 47.5d |
| Z3.2030 |  | Backfill/Compaction of soil upto desired level | 31.25d | 2011-07-20 | 2011-08-17 | Z3.2020 | 47.5d |
|  | 04 | **A3-3** |  | 2011-07-09 | 2011-08-23 |  |  |
| Z3.3010 |  | Site Clearing/Grubbing/Disposal | 18.75d | 2011-07-09 | 2011-07-25 | 1.4.1.3.3.010 FS+31.25d | 37.5d |
| Z3.3020 |  | Backfill/Compaction of soil upto desired level | 31.25d | 2011-07-26 | 2011-08-23 | Z3.3010 | 37.5d |
|  | 05 | **A3-4** |  | 2011-08-07 | 2011-08-30 |  |  |
| Z3.4010 |  | Site Clearing/Grubbing/Disposal | 8.75d | 2011-08-07 | 2011-08-14 | Z3.3020 SS+12.5d | 37.5d |
| Z3.4020 |  | Backfill/Compaction of soil upto desired level | 17.5d | 2011-08-15 | 2011-08-30 | Z3.4010 | 45d |
|  | 06 | **A3-5** |  | 2011-08-18 | 2011-09-06 |  |  |
| Z3.5010 |  | Site Clearing/Grubbing/Disposal | 7.5d | 2011-08-18 | 2011-08-24 | Z3.4010 FS+3.75d | 37.5d |
| Z3.5020 |  | Backfill/Compaction of soil upto desired level | 13.75d | 2011-08-25 | 2011-09-06 | Z3.5010 | 37.5d |
|  | 4 | **Zone 2** |  | 2011-07-24 | 2011-09-07 |  |  |
|  | 1 | **Site Preparation** |  |  |  |  |  |
|  | 2 | **A2-1** |  | 2011-07-24 | 2011-08-21 |  |  |
| Z2.1010 |  | Site clearing/grubbing/disposal | 7.5d | 2011-07-24 | 2011-07-30 | 1.4.1.3.2.010, M2.07, M2.05 | 62.5d |
| Z2.1020 |  | Backfill/Compaction of soil upto desired level | 23.75d | 2011-07-31 | 2011-08-21 | Z2.1010 | 62.5d |
|  | 3 | **A2-2** |  | 2011-07-24 | 2011-09-07 |  |  |
| Z2.2010 |  | Site clearing/grubbing/disposal | 18.75d | 2011-07-24 | 2011-08-09 | 1.4.1.3.2.010 | 62.5d |
| Z2.2020 |  | Backfill/Compaction of soil upto desired level | 31.25d | 2011-08-10 | 2011-09-07 | Z2.2010 | 62.5d |
| Z2.2330 |  | Temoraru access road for zone 2 | 12.5d | 2011-08-28 | 2011-09-07 | Z2.2020 SS+18.75d | 87.5d |
|  | 5 | **Zone 4** |  | 2011-09-08 | 2011-11-05 |  |  |
|  | 1 | **Site Preparation** |  | 2011-09-08 | 2011-11-05 |  |  |
| Z4.1010 |  | Site clearing/grubbing/disposal zone4 | 25d | 2011-09-08 | 2011-10-01 | 1.4.1.3.4.010 FS+18.75d, M2.06, Z2.2020 | 62.5d |
| Z4.1020 |  | Supp/backfill/compact gen soil upto des level zone4 | 37.5d | 2011-10-02 | 2011-11-05 | Z4.1010, Z2.2330 | 62.5d |

| ID | WBS | Task | Duration | Start | Finish | Predecessors | Total float |
| --- | --- | --- | --- | --- | --- | --- | --- |
|  | 2 | **Sewer Sanitary System** |  | 2011-07-14 | 2012-06-19 |  |  |
|  | 1 | **Zone 1** |  |  |  |  |  |
|  | 1 | **A1** |  |  |  |  |  |
|  | 2 | **Zone 3** |  | 2011-07-14 | 2012-06-19 |  |  |
|  | 1 | **A3-1** |  | 2011-08-16 | 2012-06-06 |  |  |
| Z3.1180 |  | Excavation for sewer trench SMH02RA-SMH08RA+Dewatering | 12.5d | 2011-08-16 | 2011-08-27 | Z3.1020 | 70d |
| Z3.1190 |  | Installation of Sewer Manholes 01 - 07 (7) | 31.25d | 2011-08-28 | 2011-09-25 | Z3.1180 | 70d |
| Z3.1030 |  | Excavation for gravity trench SMH19R3-SMH11R3+Dewatering | 22.5d | 2011-09-07 | 2011-09-27 | Z3.1020, M2.08 | 37.5d |
| Z3.1210 |  | Installation of sewer pipe (560LM) | 20d | 2011-09-26 | 2011-10-13 | Z3.1190 | 70d |
| Z3.1040 |  | Installation of Sewer Manholes SMH19R3-SMH11R3(9) | 31.25d | 2011-09-28 | 2011-10-26 | Z3.1030, 1.3.5.2.1.030 | 37.5d |
| Z3.1211 |  | Excavation for sewer trench SMH06RA- SMH08RA | 10d | 2011-10-15 | 2011-10-23 | Z3.1210 | 70d |
| Z3.1212 |  | Install sewer manholes (3) | 31.25d | 2011-10-24 | 2011-11-21 | Z3.1211 | 70d |
| Z3.1050 |  | Installation of sewer pipe (750LM) | 25d | 2011-10-27 | 2011-11-19 | Z3.1040, 1.3.5.2.2.030 | 37.5d |
| Z3.1051 |  | Install sewer manhoels SMH11R2-SMH08R4 (03) | 31.25d | 2011-11-20 | 2011-12-18 | Z3.1050 | 37.5d |
| Z3.1213 |  | Install sewer pipe line (210LM) | 12.5d | 2011-11-22 | 2011-12-03 | Z3.1212 | 70d |
| Z3.1214 |  | Excavation for sewer trench SMH01RP- SMH07RP | 18.75d | 2011-12-04 | 2011-12-20 | Z3.1213 | 70d |
| Z3.1052 |  | Install sewer pipe (325LM) | 25d | 2011-12-19 | 2012-01-10 | Z3.1051 | 37.5d |
| Z3.1215 |  | Install sewer manholes (7) | 31.25d | 2011-12-21 | 2012-01-18 | Z3.1214 | 70d |
| Z3.1060 |  | Partial Backfilling | 7.5d | 2012-01-11 | 2012-01-17 | Z3.1052 | 37.5d |
| Z3.1216 |  | Install sewer pipeline (575LM) | 30d | 2012-01-19 | 2012-02-15 | Z3.1215 | 70d |
| Z3.1220 |  | Partial Backfilling | 7.5d | 2012-02-16 | 2012-02-22 | Z3.1210, Z3.1216 | 70d |
| Z3.1100 |  | Excavation for sewer trench SMH11R3-LS10+Dewatering | 6.25d | 2012-03-25 | 2012-03-29 | Z3.1090 | 37.5d |
| Z3.1110 |  | Installation of Sewer Manholes SMH11R3-LS10 (5) | 25d | 2012-03-31 | 2012-04-22 | Z3.1100 | 37.5d |
| Z3.1120 |  | Installation of Sewer Pipe (225LM) | 15d | 2012-04-23 | 2012-05-06 | Z3.1110 | 37.5d |
| Z3.1130 |  | Installation of Sewer Manholes SMHRL1-SMH07RP (4) | 21.25d | 2012-05-07 | 2012-05-26 | Z3.1120 | 37.5d |
| Z3.1140 |  | Installation of Sewer Pipe SMHRL1-SMH07RP (290LM) | 12.5d | 2012-05-27 | 2012-06-06 | Z3.1130 | 37.5d |
|  | 2 | **A3-2** |  | 2011-07-14 | 2012-03-06 |  |  |
| Z3.2075 |  | Installation of Manholes SMH01R2-SMH28RA(5) | 25d | 2011-07-14 | 2011-08-06 | 1.4.1.3.3.010 FS+37.5d | 62.5d |
| Z3.2080 |  | Installation of sewer pipe SMH01R2-SMH28RA (300LM) | 27.5d | 2011-08-07 | 2011-08-31 | Z3.2075 | 62.5d |
| Z3.2040 |  | Excavation for sanitary trench SMH06R3 -SMH05R4 | 25d | 2011-08-18 | 2011-09-10 | Z3.2030, 1.2.6.200 | 47.5d |
| Z3.2090 |  | Installation of Manholes SMHRL16 -SMH28RA (7) | 31.25d | 2011-09-01 | 2011-09-29 | Z3.2080 | 62.5d |
| Z3.2045 |  | Installation of Manholes SMH06R3 -SMH05R4 (5) | 25d | 2011-09-11 | 2011-10-03 | Z3.2040 | 47.5d |
| Z3.2110 |  | Excavation for sanitary trench SMH01R3-LS11 | 18.75d | 2011-10-01 | 2011-10-17 | Z3.2090 | 62.5d |
| Z3.2050 |  | Installation of sewer pipe SMH06R3 -SMH05R4 (400LM) | 31.25d | 2011-10-04 | 2011-11-01 | Z3.2045 | 47.5d |
| Z3.2120 |  | Installation of sewer pipe SMH01R3-LS11(327LM) | 31.25d | 2011-10-18 | 2011-11-15 | Z3.2110 | 62.5d |
| Z3.2051 |  | Excavation for sanitary trench SMH05R3-SMH01R | 15d | 2011-11-02 | 2011-11-15 | Z3.2050 | 136.25d |
| Z3.2055 |  | Installation of Manholes SMH05R3 -SMH01R3 (5) | 25d | 2011-11-16 | 2011-12-08 | Z3.2050, Z3.2051 | 136.25d |
| Z3.2130 |  | Excavation of sanitary trench SMHRL16 -LS11 | 12.5d | 2011-11-16 | 2011-11-27 | Z3.2120 | 62.5d |
| Z3.2140 |  | Installation of Manholes SMHRL16 -LS11 (7) | 26.25d | 2011-11-28 | 2011-12-21 | Z3.2130 | 62.5d |
| Z3.2060 |  | Installation of sewer pipe SMH05R3 -SMH01R3 (360LM) | 27.5d | 2011-12-10 | 2012-01-03 | Z3.2055 | 136.25d |
| Z3.2150 |  | Installation of sewer pipe SMHRL16 -LS11 (730LM) | 22.5d | 2011-12-22 | 2012-01-11 | Z3.2140 | 62.5d |
| Z3.2065 |  | Installation of Manholes SMH01R3 -SMH28RA (5) | 25d | 2012-01-04 | 2012-01-26 | Z3.2060 | 136.25d |
| Z3.2066 |  | Excavation of sewer trench SMH01R3-SMH28RA | 15d | 2012-01-28 | 2012-02-09 | Z3.2065 | 136.25d |
| Z3.2070 |  | Installation of sewer pipe SMH01R3 -SMH28RA (380LM) | 27.5d | 2012-02-11 | 2012-03-06 | Z3.2066 | 136.25d |
|  | 3 | **A3-3** |  | 2011-08-24 | 2012-06-19 |  |  |
| Z3.3110 |  | Excavation for sewer line SMH13RA-SMH09RA | 18.75d | 2011-08-24 | 2011-09-10 | Z3.3020 | 62.5d |
| Z3.3120 |  | Instalaltion of sewer Manholes SMH13RA-SMH09RA (5) | 31.25d | 2011-09-11 | 2011-10-09 | Z3.3110 | 62.5d |
| Z3.3130 |  | Instalaltion of sewer line SMH13RA-SMH09RA (285LM) | 18.75d | 2011-10-10 | 2011-10-26 | Z3.3120 | 62.5d |
| Z3.3140 |  | Excavation for sewer line SMH09RA-SMH11R2 | 12.5d | 2011-10-27 | 2011-11-07 | Z3.3130 | 62.5d |
| Z3.3150 |  | Installation of sewer manhole SMH09RA-SMH11R2 (3) | 18.75d | 2011-11-08 | 2011-11-24 | Z3.3140 | 62.5d |
| Z3.3160 |  | Installaiton of sewer line SMH09RA-SMH11R2 (270LM) | 16.25d | 2011-11-26 | 2011-12-10 | Z3.3150 | 62.5d |
| Z3.3170 |  | Excavation for sewer line SMH13RA - SMH01R2 | 25d | 2011-12-11 | 2012-01-02 | Z3.3160 | 62.5d |
| Z3.3180 |  | Installaiton of manholes SMH13RA - SMH01R2 (7) | 31.25d | 2012-01-03 | 2012-01-31 | Z3.3170 | 62.5d |
| Z3.3190 |  | Installation of sewer line SMH13RA - SMH01R2 (598LM) | 31.25d | 2012-02-01 | 2012-02-29 | Z3.3180 | 62.5d |
| Z3.3200 |  | Excavation for sewer line SM10R2 - SM02R2 | 25d | 2012-03-01 | 2012-03-24 | Z3.3190, Z3.1220 | 62.5d |
| Z3.3210 |  | Installation of sewer manholes SM10R2 - SM02R2 (9) | 31.25d | 2012-03-25 | 2012-04-22 | Z3.3200 | 62.5d |
| Z3.3220 |  | Installation of sewer line SM10R2 - SM02R2 (780)A | 31.25d | 2012-04-23 | 2012-05-21 | Z3.3210 | 62.5d |
| Z3.3230 |  | Installation of sewer line SM10R2 - SM02R2 (780)B | 31.25d | 2012-05-22 | 2012-06-19 | Z3.3220 | 62.5d |
|  | 4 | **A3-4** |  |  |  |  |  |
|  | 5 | **A3-5** |  | 2012-02-01 | 2012-04-10 |  |  |
| Z3.5030 |  | Excvation for sewer line SMH10R3-SMH01R4 | 18.75d | 2012-02-01 | 2012-02-18 | Z3.5020, Z3.4030 | 97.5d |
| Z3.5040 |  | Installation of sewer manholes SMH10R3-SMH01R4(5) | 25d | 2012-02-19 | 2012-03-12 | Z3.5030 | 97.5d |
| Z3.5050 |  | Installation of sewer line SMH10R3-SMH01R4 (350LM) | 31.25d | 2012-03-13 | 2012-04-10 | Z3.5040 | 97.5d |
|  | 3 | **Zone 2** |  | 2011-07-24 | 2012-04-22 |  |  |
|  | 1 | **A2-1** |  | 2011-08-22 | 2011-10-31 |  |  |
| Z2.1030 |  | Excavation for sewer line SMH01RC-SMH04R7 | 18.75d | 2011-08-22 | 2011-09-07 | Z2.1020 | 62.5d |
| Z2.1040 |  | Install sewer manholes SMH01RC-SMH04R7 (5) | 26.25d | 2011-09-08 | 2011-10-02 | Z2.1030 | 62.5d |
| Z2.1050 |  | Install sewer line SMH01RC-SMH04R7 (350LM) | 31.25d | 2011-10-03 | 2011-10-31 | Z2.1040 | 62.5d |
|  | 2 | **A2-2** |  | 2011-07-24 | 2012-04-22 |  |  |
| Z2.2120 |  | Excavation for sewer trench SMH01R7-SMH04R7 | 18.75d | 2011-07-24 | 2011-08-09 | 1.4.1.3.2.010 | 86.25d |

| ID | WBS | Task | Duration | Start | Finish | Predecessors | Total float |
| --- | --- | --- | --- | --- | --- | --- | --- |
| Z2.2130 |  | Install sewer manholes SMH01R7-SMH04R7 (5) | 25d | 2011-08-10 | 2011-09-01 | Z2.2120 | 86.25d |
| Z2.2140 |  | Install sewer line SMH01R7-SMH04R7 (330LM) | 18.75d | 2011-09-03 | 2011-09-19 | Z2.2130 | 86.25d |
| Z2.2030 |  | Excavation for sewer trench SMH05R7 - SMH18RC | 18.75d | 2011-09-08 | 2011-09-25 | Z2.2020 | 117.5d |
| Z2.2150 |  | Excavation for sewer trench SMH04R7-SMH12RC | 25d | 2011-09-20 | 2011-10-12 | Z2.2140 | 86.25d |
| Z2.2040 |  | Install sewer manholes SMH05R7 - SMH18RC (6) | 31.25d | 2011-09-26 | 2011-10-24 | Z2.2030 | 117.5d |
| Z2.2160 |  | Installation of manhoels SMH04R7-SMH12RC (11) | 31.25d | 2011-10-13 | 2011-11-10 | Z2.2150 | 86.25d |
| Z2.2050 |  | Install sewer line SMH05R7 - SMH18RC (406LM) | 25d | 2011-10-25 | 2011-11-16 | Z2.2040 | 117.5d |
| Z2.2170 |  | Installation of sewer line SMH04R7-SMH12RC (652LM)A | 18.75d | 2011-11-12 | 2011-11-28 | Z2.2160 | 86.25d |
| Z2.2060 |  | Excavation for sewer line SMH13R7-SMH17RC | 18.75d | 2011-11-17 | 2011-12-04 | Z2.2050, M2.09 | 117.5d |
| Z2.2180 |  | Installation of sewer line SMH04R7-SMH12RC (652LM)B | 18.75d | 2011-11-29 | 2011-12-15 | Z2.2170 | 86.25d |
| Z2.2070 |  | Install sewer line manhole SMH13R7-SMH17RC (5) | 25d | 2011-12-05 | 2011-12-27 | Z2.2060 | 117.5d |
| Z2.2190 |  | Excavation for sewer line SMH02AR7-interface point-A | 18.75d | 2011-12-17 | 2012-01-02 | Z2.2180 | 86.25d |
| Z2.2080 |  | Install sewer line SMH13R7-SMH17RC (294LM) | 18.75d | 2011-12-28 | 2012-01-14 | Z2.2070 | 117.5d |
| Z2.2200 |  | Instal F.sewer line SMH02AR7-interface point (29040LM)A | 25d | 2012-01-03 | 2012-01-25 | Z2.2190 | 86.25d |
| Z2.2090 |  | Excavation for sewer line SMH17RC-SMH12RC | 18.75d | 2012-01-15 | 2012-01-31 | Z2.2080 | 117.5d |
| Z2.2202 |  | Excavation for sewer line SMH02AR7-interface point-B | 18.75d | 2012-01-26 | 2012-02-12 | Z2.2200 | 86.25d |
| Z2.2100 |  | Install sewer manholes SMH17RC-SMH12RC (7) | 31.25d | 2012-02-01 | 2012-02-29 | Z2.2090 | 117.5d |
| Z2.2210 |  | Instal F.sewer line SMH02AR7-interface point (2940LM)B | 25d | 2012-02-13 | 2012-03-06 | Z2.2202 | 86.25d |
| Z2.2110 |  | Install sewer line SMH17RC-SMH12RC (410LM) | 25d | 2012-03-01 | 2012-03-24 | Z2.2100 | 117.5d |
| Z2.2212 |  | Excavation for sewer line SMH02AR7-interface point-C | 18.75d | 2012-03-07 | 2012-03-24 | Z2.2210 | 86.25d |
| Z2.2220 |  | Instal F.sewer line SMH02AR7-interface point (2940LM)C | 25d | 2012-03-25 | 2012-04-16 | Z2.2212 | 86.25d |
| Z2.2340 |  | Backfilling | 31.25d | 2012-03-25 | 2012-04-22 | Z2.2220 SS | 86.25d |
|  | 4 | **Zone 4** |  | 2011-11-06 | 2012-06-07 |  |  |
|  | 1 | **A4** |  | 2011-11-06 | 2012-06-07 |  |  |
| Z4.1030 |  | Excavation for sewer line SMH18R2-SMH29R3+Dewatering | 25d | 2011-11-06 | 2011-11-28 | Z4.1020 | 62.5d |
| Z4.1040 |  | Install sewer manholes SMH18R2-SMH29R3 (7) | 31.25d | 2011-11-29 | 2011-12-27 | Z4.1030 | 62.5d |
| Z4.1050 |  | Install sewer line SMH18R2-SMH29R3 (405LM) | 25d | 2011-12-28 | 2012-01-19 | Z4.1040 | 62.5d |
| Z4.1060 |  | Excavation for sewer line SMH20R3-SMH29R3 | 31.25d | 2012-01-21 | 2012-02-18 | Z4.1050 | 62.5d |
| Z4.1070 |  | Install sewer manholes SMH20R3-SMH29R3 (7) | 31.25d | 2012-02-19 | 2012-03-18 | Z4.1060, Z1.1060 | 62.5d |
| Z4.1080 |  | Install sewr line SMH20R3-SMH29R3 (630LM) | 31.25d | 2012-03-19 | 2012-04-16 | Z4.1070 | 62.5d |
| Z4.1090 |  | Excvation for sewer line SMH20R3- SD CHAMBER | 25d | 2012-04-17 | 2012-05-09 | Z4.1080 | 62.5d |
| Z4.1100 |  | Install sewer line SMH20R3- SD CHAMBER | 31.25d | 2012-05-10 | 2012-06-07 | Z4.1090 | 62.5d |
| Z4.1180 |  | Backfilling | 31.25d | 2012-05-10 | 2012-06-07 | Z4.1100 SS | 62.5d |
|  | 3 | **PW / FW / CTMU(Cooling Tower Make Up) / Irrigation / Sea water Line** |  | 2011-08-21 | 2012-10-20 |  |  |
|  | 1 | **Zone 1** |  | 2011-08-21 | 2011-10-17 |  |  |
|  | 1 | **A1** |  | 2011-08-21 | 2011-10-17 |  |  |
| Z1.1040 |  | Excavation for water line & Valve boxes(2) | 25d | 2011-08-21 | 2011-09-12 | Z1.1030 FS+37.5d, 1.4.1.2.1.020 SS | 195d |
| Z1.1050 |  | Construction of vale boxes(2) | 31.25d | 2011-09-13 | 2011-10-11 | Z1.1040 | 195d |
| Z1.1060 |  | Install PW/FW/CTMU line +Irrigation line (375LM) | 25d | 2011-09-25 | 2011-10-17 | Z1.1050 SS+12.5d | 195d |
|  | 2 | **Zone 3** |  | 2011-09-29 | 2012-10-20 |  |  |
|  | 1 | **A3-1** |  | 2011-09-29 | 2012-10-20 |  |  |
| Z3.1230 |  | Construction of Valve boxes for water line (7) | 31.25d | 2011-09-29 | 2011-10-27 | 1.4.1.2.2.040 | 106.25d |
| Z3.1240 |  | Installation of PW/FW/CTMU line-A(825) + Irrigation line | 31.25d | 2011-10-29 | 2011-11-26 | Z3.1230 | 106.25d |
| Z3.1250 |  | Installation of PW/FW/CTMU line-B(825) + Irrigation line | 31.25d | 2011-11-27 | 2011-12-25 | Z3.1240 | 106.25d |
| Z3.1260 |  | Installation of PW/FW/CTMU line-C(825) + Irrigation line | 31.25d | 2011-12-26 | 2012-01-23 | Z3.1250 | 106.25d |
| Z3.1070 |  | Construction of Valve boxes for water line (4) | 21.25d | 2012-01-18 | 2012-02-06 | Z3.1060 | 37.5d |
| Z3.1270 |  | Installation of PW/FW/CTMU line-D(825) + Irrigation line | 31.25d | 2012-01-24 | 2012-02-21 | Z3.1260 | 106.25d |
| Z3.1080 |  | Installation of PW/FW/CTMU line-A(375LM) + irrigation line | 25d | 2012-02-07 | 2012-02-29 | Z3.1070, 1.3.5.1.2.030, 1.3.5.3.1.030 | 37.5d |
| Z3.1280 |  | Instalaltion of seawater line (825LM) A | 31.25d | 2012-02-22 | 2012-03-21 | Z3.1270 | 106.25d |
| Z3.1090 |  | Installation of PW/FW/CTMU line-B(375LM) + irrigation line | 25d | 2012-03-01 | 2012-03-24 | Z3.1080 | 37.5d |
| Z3.1290 |  | Instalaltion of seawater line (825LM) B | 31.25d | 2012-03-22 | 2012-04-19 | Z3.1280 | 106.25d |
| Z3.1300 |  | Instalaltion of seawater line (825LM) C | 31.25d | 2012-04-21 | 2012-05-19 | Z3.1290 | 106.25d |
| Z3.1340 |  | Install valves | 31.25d | 2012-05-06 | 2012-06-04 | Z3.1230 FS+37.5d, 1.3.5.1.3.030, 1.3.5.3.2.030 | 120.5d |
| Z3.1310 |  | Instalaltion of seawater line (825LM) D | 31.25d | 2012-05-20 | 2012-06-17 | Z3.1300 | 106.25d |
| Z3.1320 |  | Install fire hydrants | 56.25d | 2012-07-28 | 2012-09-18 | Z3.1310, Z3.1340, 1.3.5.1.3.060 | 63d |
| Z3.1330 |  | Install irrigation system & accs | 40d | 2012-09-12 | 2012-10-20 | Z3.1320 SS+50d | 63d |
|  | 2 | **A3-2** |  | 2011-10-04 | 2012-10-20 |  |  |
| Z3.2160 |  | Construction for valve boxes (11) | 27.5d | 2011-10-04 | 2011-10-29 | Z3.2050 SS | 47.5d |
| Z3.2170 |  | Install PW/FW/CTMU line + Irrigation line A(1200LM) | 31.25d | 2011-10-30 | 2011-11-27 | Z3.2160 | 47.5d |
| Z3.2180 |  | Install PW/FW/CTMU line + Irrigation line B(1200LM) | 31.25d | 2011-11-28 | 2011-12-26 | Z3.2170 | 47.5d |
| Z3.2190 |  | Install PW/FW/CTMU line + Irrigation line C(1200LM) | 31.25d | 2011-12-27 | 2012-01-24 | Z3.2180 | 80d |
| Z3.2210 |  | Install Seawater line (1650LM) A | 31.25d | 2012-01-12 | 2012-02-09 | Z3.2150 | 62.5d |
| Z3.2200 |  | Install PW/FW/CTMU line + Irrigation line D(1200LM) | 31.25d | 2012-01-25 | 2012-02-22 | Z3.2190 | 80d |
| Z3.2220 |  | Install Seawater line (1650LM) B | 31.25d | 2012-02-11 | 2012-03-10 | Z3.2210 | 62.5d |
| Z3.2230 |  | Install Seawater line (1650LM) C | 31.25d | 2012-03-11 | 2012-04-08 | Z3.2220, Z3.2200 | 62.5d |
| Z3.2310 |  | Install valves | 31.25d | 2012-03-18 | 2012-04-15 | Z3.2160 FS+150d | 211.25d |
| Z3.2240 |  | Install Seawater line (1650LM) D | 31.25d | 2012-04-09 | 2012-05-07 | Z3.2230 | 62.5d |
| Z3.2250 |  | Install Seawater line (1650LM) E | 31.25d | 2012-05-08 | 2012-06-05 | Z3.2240 | 62.5d |
| Z3.2260 |  | Install seawater line (600LM)A | 31.25d | 2012-06-06 | 2012-07-04 | Z3.2250 | 62.5d |
| Z3.2270 |  | Install seawater line (600LM)B | 31.25d | 2012-07-05 | 2012-08-02 | Z3.2260 | 62.5d |

| ID | WBS | Task | Duration | Start | Finish | Predecessors | Total float |
| --- | --- | --- | --- | --- | --- | --- | --- |
| Z3.2280 |  | Install seawater line (600LM)C | 31.25d | 2012-08-04 | 2012-09-01 | Z3.2270 | 62.5d |
| Z3.2290 |  | Install fire hydrants | 52.5d | 2012-09-02 | 2012-10-20 | Z3.2280, Z3.2310, 1.3.5.1.3.060 | 62.5d |
| Z3.2300 |  | Install irrigation system & accs | 52.5d | 2012-09-02 | 2012-10-20 | Z3.2290 SS | 62.5d |
|  | 3 | **A3-3** |  | 2012-06-20 | 2012-10-20 |  |  |
| Z3.3235 |  | Construction of valve boxes (12) A | 31.25d | 2012-06-20 | 2012-07-18 | Z3.3230 | 62.5d |
| Z3.3236 |  | Construction of valve boxes (12) B | 31.25d | 2012-07-19 | 2012-08-16 | Z3.3235 | 75d |
| Z3.3240 |  | Installation of PW/FW/CTMU line + Irrigation line A | 25d | 2012-07-19 | 2012-08-11 | Z3.3235 | 62.5d |
| Z3.3250 |  | Installation of PW/FW/CTMU line + Irrigation line B | 25d | 2012-08-12 | 2012-09-03 | Z3.3240 | 62.5d |
| Z3.3280 |  | Install valves | 31.25d | 2012-08-18 | 2012-09-15 | Z3.3236 | 75d |
| Z3.3260 |  | Installation of PW/FW/CTMU line + Irrigation line C | 25d | 2012-09-04 | 2012-09-26 | Z3.3250 | 62.5d |
| Z3.3270 |  | Install fire hydrants | 25d | 2012-09-27 | 2012-10-20 | Z3.3260, Z3.3280, 1.3.5.1.3.060 | 62.5d |
|  | 4 | **A3-4** |  | 2012-01-03 | 2012-04-28 |  |  |
| Z3.4030 |  | Install seawater line (1050LM)A | 31.25d | 2012-01-03 | 2012-01-31 | Z3.4020, Z3.3170 | 97.5d |
| Z3.4040 |  | Install seawater line (1050LM)B | 31.25d | 2012-02-01 | 2012-02-29 | Z3.4030 | 110d |
| Z3.4050 |  | Install seawater line (1050LM)C | 31.25d | 2012-03-01 | 2012-03-29 | Z3.4040 | 110d |
| Z3.4060 |  | Install seawater line (1050LM)D | 31.25d | 2012-03-31 | 2012-04-28 | Z3.4050 | 110d |
|  | 5 | **A3-5** |  | 2012-04-11 | 2012-07-07 |  |  |
| Z3.5060 |  | Install seawater line (600LM)A | 31.25d | 2012-04-11 | 2012-05-09 | Z3.5050 | 97.5d |
| Z3.5070 |  | Install seawater line (600LM)B | 31.25d | 2012-05-10 | 2012-06-07 | Z3.5060, Z3.4060 | 97.5d |
| Z3.5080 |  | Install seawater line (600LM)C | 31.25d | 2012-06-09 | 2012-07-07 | Z3.5070 | 97.5d |
|  | 3 | **Zone 2** |  | 2011-10-02 | 2012-09-18 |  |  |
|  | 1 | **A2-1** |  | 2011-11-01 | 2012-09-18 |  |  |
| Z2.1060 |  | Excavation for valve boxes & water line trench | 25d | 2011-11-01 | 2011-11-23 | Z2.1050 | 62.5d |
| Z2.1070 |  | Construction of vale boxes for water line (5) | 31.25d | 2011-11-24 | 2011-12-22 | Z2.1060 | 62.5d |
| Z2.1080 |  | Install PW/FW/CTMU line+irrigation line (1200LM)A+Seawater | 31.25d | 2011-12-24 | 2012-01-21 | Z2.1070 | 62.5d |
| Z2.1120 |  | Install valves | 31.25d | 2011-12-24 | 2012-01-21 | Z2.1070 | 93.75d |
| Z2.1090 |  | Install PW/FW/CTMU line+irrigation line (1200LM)B+Seawater | 31.25d | 2012-01-22 | 2012-02-19 | Z2.1080 | 62.5d |
| Z2.1100 |  | Install PW/FW/CTMU line+irrigation line (1200LM)C+Seawater | 31.25d | 2012-02-20 | 2012-03-19 | Z2.1090, Z2.1120 | 62.5d |
| Z2.1110 |  | Install fire hydrants | 56.25d | 2012-07-28 | 2012-09-18 | Z2.1100, 1.3.5.1.3.060 | 96.75d |
|  | 2 | **A2-2** |  | 2011-10-02 | 2012-09-18 |  |  |
| Z2.2230 |  | Excavation for water line trench & valve boxesA | 12.5d | 2011-10-02 | 2011-10-12 | 1.4.1.3.2.010 FS+75d | 128.75d |
| Z2.2240 |  | Construction of valve boxesA (2) | 31.25d | 2011-10-13 | 2011-11-10 | Z2.2230 | 128.75d |
| Z2.2250 |  | Install PW/FW/CTMU line +irrigation line (225LM)A | 15d | 2011-11-12 | 2011-11-24 | Z2.2240 | 128.75d |
| Z2.2252 |  | Excavation for water line trench & valve boxesB | 15d | 2011-11-26 | 2011-12-08 | Z2.2250 | 128.75d |
| Z2.2254 |  | Construction of valve boxesB (2) | 31.25d | 2011-12-10 | 2012-01-07 | Z2.2252 | 128.75d |
| Z2.2260 |  | Install PW/FW/CTMU line +irrigation line (450LM)B | 22.5d | 2012-01-08 | 2012-01-28 | Z2.2254 | 128.75d |
| Z2.2262 |  | Excavation for water line trench & valve boxesC | 18.75d | 2012-01-29 | 2012-02-14 | Z2.2260 | 128.75d |
| Z2.2264 |  | Construction of valve boxesC (2) | 31.25d | 2012-02-15 | 2012-03-14 | Z2.2262 | 128.75d |
| Z2.2270 |  | Install PW/FW/CTMU line +irrigation line (825LM)C | 31.25d | 2012-03-15 | 2012-04-12 | Z2.2264 | 128.75d |
| Z2.2320 |  | Install valves | 31.25d | 2012-03-15 | 2012-04-12 | Z2.2264 | 210d |
| Z2.2280 |  | Excavation for irrigation line to exisitng facilities | 18.75d | 2012-04-14 | 2012-04-30 | Z2.2270 | 128.75d |
| Z2.2290 |  | Installation of irrigation line to existing facilities(900LM)A | 31.25d | 2012-05-01 | 2012-05-29 | Z2.2280 | 128.75d |
| Z2.2300 |  | Installation of irrigation line to existing facilities(900LM)B | 31.25d | 2012-05-30 | 2012-06-27 | Z2.2290 | 128.75d |
| Z2.2310 |  | Install fire hydrants | 56.25d | 2012-07-28 | 2012-09-18 | Z2.2300, Z2.2320, 1.3.5.1.3.060 | 96.75d |
|  | 4 | **Zone 4** |  | 2012-06-09 | 2012-10-20 |  |  |
|  | 1 | **A4** |  | 2012-06-09 | 2012-10-20 |  |  |
| Z4.1110 |  | Excavation for water lineA | 12.5d | 2012-06-09 | 2012-06-19 | Z4.1100, Z4.1180 | 62.5d |
| Z4.1120 |  | Construction of valve boxes (3) | 31.25d | 2012-06-20 | 2012-07-18 | Z4.1110 | 62.5d |
| Z4.1130 |  | Install PW/FW/CTMU line(180LM)A | 12.5d | 2012-07-19 | 2012-07-30 | Z4.1120 | 62.5d |
| Z4.1170 |  | Install valves | 18.75d | 2012-07-19 | 2012-08-05 | Z4.1120 | 106.25d |
| Z4.1140 |  | Excavation for water lineB | 18.75d | 2012-07-31 | 2012-08-16 | Z4.1130 | 62.5d |
| Z4.1150 |  | Install PW/FW/CTMU line(495LM)B | 31.25d | 2012-08-18 | 2012-09-15 | Z4.1140 | 62.5d |
| Z4.1160 |  | Install fire hydrants | 37.5d | 2012-09-16 | 2012-10-20 | Z4.1150, Z4.1170, 1.3.5.1.3.060 | 62.5d |
|  | 4 | **Lift Station Buildings** |  | 2011-08-08 | 2012-10-20 |  |  |
|  | 8 | **Lift Station # 9 Zone 4** |  | 2011-09-11 | 2012-10-02 |  |  |
|  | 1 | **LS 9 Building - Zone 4** |  | 2011-09-11 | 2012-10-02 |  |  |
| 1.4.2.3.5.010 |  | Excavation leveling & compaction for LS9 | 25d | 2011-09-11 | 2011-10-03 | 1.4.2.3.8.010 SS | 56d |
| 1.4.2.3.5.020 |  | Install lean concrete & water proofing works LS9 | 31.25d | 2011-10-04 | 2011-11-01 | 1.4.2.3.5.010 | 56d |
| 1.4.2.3.5.025 |  | Install Base slab for LS9 | 31.25d | 2011-11-02 | 2011-11-30 | 1.4.2.3.5.020 | 56d |
| 1.4.2.3.5.030 |  | Construction for retaining walls LS9 | 25d | 2011-12-01 | 2011-12-24 | 1.4.2.3.5.010 SS+12.5d, M1.10, M1.12, 1.4.2.3.5.025 | 56d |
| 1.4.2.3.5.040 |  | Constrcution for sump pit LS9 | 25d | 2011-12-25 | 2012-01-16 | 1.4.2.3.5.030 | 56d |
| 1.4.2.3.5.050 |  | Construction for top slab LS9 | 31.25d | 2012-01-17 | 2012-02-14 | 1.4.2.3.5.040 | 56d |
| 1.4.2.3.5.060 |  | Construction of wall with water proofing LS9 | 37.5d | 2012-02-09 | 2012-03-14 | 1.4.2.3.5.050 SS+25d, 1.3.1.6.200 | 56d |
| 1.4.2.3.5.070 |  | Backfilling & Compaction LS9 | 25d | 2012-03-13 | 2012-04-04 | 1.4.2.3.5.060 SS+35d | 56d |
| 1.4.2.3.5.080 |  | Plastering & Painting work LS9 -Door installation | 31.25d | 2012-04-05 | 2012-05-03 | 1.4.2.3.5.070, 1.4.2.3.5.020 SS | 56d |
| 1.4.2.3.5.130 |  | Install precast concrete fence & gate LS9 | 30d | 2012-04-23 | 2012-05-21 | 1.4.2.3.5.080 SS+19d | 56d |
| 1.4.2.3.5.140 |  | Install asphalt pavement LS9 | 30d | 2012-05-02 | 2012-05-30 | 1.4.2.3.5.130 SS+10d | 56d |
| 1.4.2.3.5.150 |  | Install piping System & odour control system | 30d | 2012-05-30 | 2012-06-27 | 1.4.2.3.5.140, 1.3.5.2.5.030, 1.3.5.2.6.030 | 56d |
| 1.4.2.3.5.155 |  | Install electrical/instr work / fire alarm system in LS9 | 30d | 2012-06-27 | 2012-07-25 | 1.4.2.3.5.150 | 78.5d |
| 1.4.2.3.5.160 |  | Testing & Commissioning of LS 9 | 45d | 2012-08-21 | 2012-10-02 | 1.4.2.7.4.108, 1.4.2.3.5.155, Z3.5080, 1.4.3.1.1.570, 1.4.3.1.2.570, M2.10 | 49d |

| ID | WBS | Task | Duration | Start | Finish | Predecessors | Total float |
| --- | --- | --- | --- | --- | --- | --- | --- |
|  | 9 | **Lift Station # 10 Zone 3** |  | 2011-08-08 | 2012-10-13 |  |  |
|  | 1 | **LS 10 - Building - Zone 3** |  | 2011-08-08 | 2012-10-13 |  |  |
| 1.4.2.3.6.010 |  | Excavation leveling & compaction for LS10 | 25d | 2011-08-08 | 2011-08-30 | 1.2.6.200 | 30d |
| 1.4.2.3.6.020 |  | Install lean concrete & water proofing works LS10 | 31.25d | 2011-08-31 | 2011-09-28 | 1.4.2.3.6.010 | 57.5d |
| 1.4.2.3.6.025 |  | Install base slab for LS10 | 31.25d | 2011-09-29 | 2011-10-27 | 1.4.2.3.6.020 | 57.5d |
| 1.4.2.3.6.030 |  | Construction for retaining walls LS10 | 25d | 2011-10-29 | 2011-11-20 | 1.4.2.3.6.010 SS+12.5d, 1.3.1.1.030 SS, 1.3.1.1.130, 1.4.2.3.6.025 | 57.5d |
| 1.4.2.3.6.040 |  | Constrcution for sump pit LS10 | 25d | 2011-11-19 | 2011-12-11 | 1.4.2.3.6.030 SS+22.5d, 1.3.1.6.120 SS | 57.5d |
| 1.4.2.3.6.050 |  | Construction for top slab LS10 | 31.25d | 2011-12-12 | 2012-01-09 | 1.4.2.3.6.040 | 57.5d |
| 1.4.2.3.6.060 |  | Construction of wall with water proofing LS10 | 37.5d | 2012-01-10 | 2012-02-13 | 1.4.2.3.6.050 | 57.5d |
| 1.4.2.3.6.070 |  | Backfilling & Compaction LS10 | 25d | 2012-02-12 | 2012-03-05 | 1.4.2.3.6.060 SS+35d | 57.5d |
| 1.4.2.3.6.080 |  | Plastering & Painting work LS10 -Door installation | 31.25d | 2012-03-06 | 2012-04-03 | 1.4.2.3.6.070 | 57.5d |
| 1.4.2.3.6.130 |  | Install precast concrete fence & gate LS10 | 30d | 2012-03-25 | 2012-04-21 | 1.4.2.3.6.080 SS+20d | 57.5d |
| 1.4.2.3.6.140 |  | Install asphalt pavement LS10 | 30d | 2012-04-22 | 2012-05-19 | 1.4.2.3.6.130 | 57.5d |
| 1.4.2.3.6.150 |  | Install piping system & odour control sytem | 31.25d | 2012-06-07 | 2012-07-05 | 1.4.2.3.6.140, 1.3.5.2.4.030, Z3.2070, Z3.2150, Z3.1140, Z2.2110, Z2.2220, Z2.2340 | 37.5d |
| 1.4.2.3.6.155 |  | Install electrical/instr work/fire detection system LS10 | 31.25d | 2012-07-07 | 2012-08-04 | 1.4.2.3.6.150 | 67.5d |
| 1.4.2.3.6.160 |  | Testing & Commissioning of LS 10 | 45d | 2012-09-02 | 2012-10-13 | 1.4.2.7.4.102, 1.4.2.3.6.155, 1.4.3.1.1.570, 1.4.3.1.2.570, M2.10 | 37.5d |
|  | 10 | **Lift Station # 11 Zone 3** |  | 2011-08-31 | 2012-10-20 |  |  |
|  | 1 | **LS 11 - Building - Zone 3** |  | 2011-08-31 | 2012-10-20 |  |  |
| 1.4.2.3.7.010 |  | Excavation leveling & compaction for LS11 | 25d | 2011-08-31 | 2011-09-22 | 1.4.2.3.6.010 | 30d |
| 1.4.2.3.7.020 |  | Install lean concrete & water proofing works LS11 | 31.25d | 2011-09-24 | 2011-10-22 | 1.4.2.3.7.010 | 30d |
| 1.4.2.3.7.025 |  | Install base slab for LS11 | 31.25d | 2011-10-23 | 2011-11-20 | 1.4.2.3.7.020 | 30d |
| 1.4.2.3.7.030 |  | Construction for retaining walls LS11 | 25d | 2011-11-21 | 2011-12-13 | 1.4.2.3.7.025 | 30d |
| 1.4.2.3.7.040 |  | Constrcution for sump pit LS11 | 25d | 2011-12-08 | 2011-12-31 | 1.4.2.3.7.030 SS+18.75d | 30d |
| 1.4.2.3.7.050 |  | Construction for top slab LS11 | 31.25d | 2012-01-01 | 2012-01-29 | 1.4.2.3.7.040 | 30d |
| 1.4.2.3.7.060 |  | Construction of wall with water proofing LS11 | 37.5d | 2012-02-02 | 2012-03-07 | 1.4.2.3.7.050 SS+35d | 30d |
| 1.4.2.3.7.070 |  | Backfilling & Compaction LS11 | 25d | 2012-03-06 | 2012-03-28 | 1.4.2.3.7.060 SS+35d | 30d |
| 1.4.2.3.7.080 |  | Plastering & Painting work LS11 -Door installation | 20d | 2012-03-29 | 2012-04-16 | 1.4.2.3.7.070, 1.4.2.3.7.020 SS | 30d |
| 1.4.2.3.7.130 |  | Install precast concrete fence & gate LS11 | 30d | 2012-04-17 | 2012-05-14 | 1.4.2.3.7.080 | 30d |
| 1.4.2.3.7.140 |  | Install asphalt pavement LS11 | 25d | 2012-05-15 | 2012-06-06 | 1.4.2.3.7.130 | 30d |
| 1.4.2.3.7.150 |  | Install piping System & odour control system | 31.25d | 2012-06-07 | 2012-07-05 | 1.4.2.3.7.140 | 30d |
| 1.4.2.3.7.155 |  | Install electrical/instr work / fire alarm system LS11 | 31.25d | 2012-07-07 | 2012-08-04 | 1.4.2.3.7.150 | 68.75d |
| 1.4.2.3.7.160 |  | Testing & Commissioning of LS 11 | 43.75d | 2012-09-10 | 2012-10-20 | 1.4.2.7.4.104, 1.4.2.3.7.155, 1.4.3.1.1.570, 1.4.3.1.2.570, M2.10 | 30d |
|  | 11 | **Lift Station #12 Zone 2** |  | 2011-09-11 | 2012-10-18 |  |  |
|  | 1 | **LS 12 - Building - Zone 2** |  | 2011-09-11 | 2012-10-18 |  |  |
| 1.4.2.3.8.010 |  | Excavation leveling & compaction for LS12 | 25d | 2011-09-11 | 2011-10-03 | 1.4.2.3.7.010 SS+11.25d | 31.25d |
| 1.4.2.3.8.020 |  | Install lean concrete & water proofing works LS12 | 31.25d | 2011-10-04 | 2011-11-01 | 1.4.2.3.8.010 | 31.25d |
| 1.4.2.3.8.025 |  | Install base slab for LS12 | 31.25d | 2011-11-02 | 2011-11-30 | 1.4.2.3.8.020 | 31.25d |
| 1.4.2.3.8.030 |  | Construction for retaining walls LS12 | 25d | 2011-12-01 | 2011-12-24 | 1.4.2.3.8.025 | 31.25d |
| 1.4.2.3.8.040 |  | Constrcution for sump pit LS12 | 25d | 2011-12-22 | 2012-01-14 | 1.4.2.3.8.030 SS+22.5d | 31.25d |
| 1.4.2.3.8.050 |  | Construction for top slab LS12 | 31.25d | 2012-01-15 | 2012-02-12 | 1.4.2.3.8.040 | 31.25d |
| 1.4.2.3.8.060 |  | Construction of wall with water proofing LS12 | 31.25d | 2012-02-13 | 2012-03-12 | 1.4.2.3.8.050 | 31.25d |
| 1.4.2.3.8.070 |  | Backfilling & Compaction LS12 | 25d | 2012-03-13 | 2012-04-04 | 1.4.2.3.8.060 | 31.25d |
| 1.4.2.3.8.080 |  | Plastering & Painting work LS11 -Door installation | 20d | 2012-04-05 | 2012-04-23 | 1.4.2.3.8.070, 1.4.2.3.8.020 SS | 31.25d |
| 1.4.2.3.8.130 |  | Install precast concrete fence & gate LS12 | 30d | 2012-04-24 | 2012-05-21 | 1.4.2.3.8.080 | 31.25d |
| 1.4.2.3.8.140 |  | Install asphalt pavement LS12 | 30d | 2012-05-22 | 2012-06-18 | 1.4.2.3.8.130 | 31.25d |
| 1.4.2.3.8.150 |  | Install piping System & odour control system | 43.75d | 2012-06-19 | 2012-07-29 | 1.4.2.3.8.140 | 31.25d |
| 1.4.2.3.8.155 |  | Install electrical/instr work / fire alarm system LS12 | 31.25d | 2012-07-30 | 2012-08-27 | 1.4.2.3.8.150 | 31.25d |
| 1.4.2.3.8.160 |  | Testing & Commissioning of LS 12 | 56.25d | 2012-08-28 | 2012-10-18 | 1.4.2.7.4.106, 1.4.2.3.8.155, 1.4.3.1.1.570, 1.4.3.1.2.570, M2.10 | 31.25d |
|  | 5 | **Storm water drainage system** |  | 2012-01-28 | 2012-10-20 |  |  |
|  | 1 | **Zone 1** |  | 2012-04-12 | 2012-06-30 |  |  |
|  | 1 | **Storm Drainage Ditches** |  | 2012-04-12 | 2012-06-30 |  |  |
| 1.4.2.4.1.010 |  | Excavation for storm water drainage ditch (750LM) | 25d | 2012-04-12 | 2012-05-05 | 1.4.2.4.2.090A SS+25d | 80d |
| 1.4.2.4.1.020 |  | Construction of concrete drainage ditch | 25d | 2012-05-03 | 2012-05-26 | 1.4.2.4.1.010 SS+22.5d | 182.5d |
| 1.4.2.4.1.015 |  | Leveling -compaction of drainage ditch | 31.25d | 2012-06-02 | 2012-06-30 | 1.4.2.4.1.020 SS+31.25d | 182.5d |
|  | 2 | **Zone 2** |  | 2012-03-20 | 2012-10-20 |  |  |
|  | 1 | **Storm Drainage Ditches** |  | 2012-03-20 | 2012-08-20 |  |  |
| 1.4.2.4.2.090A |  | Excavation for storm water drainage ditch (2550LM)A | 10d | 2012-03-20 | 2012-03-28 | Z2.1100 | 62.5d |
| 1.4.2.4.2.090B |  | Leveling - compaction of drainage ditchA | 12.5d | 2012-03-29 | 2012-04-09 | 1.4.2.4.2.090A | 127.5d |
| 1.4.2.4.2.090C |  | Construction of concrete drainage ditchA | 18.75d | 2012-04-10 | 2012-04-26 | 1.4.2.4.2.090B | 127.5d |
| 1.4.2.4.2.091A |  | Excavation for storm water drainage ditch (2550LM)B | 10d | 2012-04-28 | 2012-05-06 | 1.4.2.4.2.090C | 127.5d |
| 1.4.2.4.2.091B |  | Leveling - compaction of drainage ditchB | 12.5d | 2012-05-07 | 2012-05-17 | 1.4.2.4.2.091A | 127.5d |
| 1.4.2.4.2.091C |  | Construction of concrete drainage ditchB | 18.75d | 2012-05-19 | 2012-06-04 | 1.4.2.4.2.091B | 127.5d |
| 1.4.2.4.2.092A |  | Excavation for storm water drainage ditch (2550LM)C | 10d | 2012-06-05 | 2012-06-13 | 1.4.2.4.2.091C | 127.5d |
| 1.4.2.4.2.092B |  | Leveling - compaction of drainage ditchC | 12.5d | 2012-06-14 | 2012-06-25 | 1.4.2.4.2.092A | 127.5d |
| 1.4.2.4.2.092D |  | Construction of concrete drainage ditchC | 18.75d | 2012-06-26 | 2012-07-12 | 1.4.2.4.2.092B | 127.5d |
| 1.4.2.4.2.093A |  | Excavation for storm water drainage ditch (2550LM)D | 10d | 2012-07-14 | 2012-07-22 | 1.4.2.4.2.092D | 127.5d |
| 1.4.2.4.2.093B |  | Leveling - compaction of drainage ditchD | 12.5d | 2012-07-23 | 2012-08-02 | 1.4.2.4.2.093A | 127.5d |
| 1.4.2.4.2.093C |  | Construction of concrete drainage ditchD | 18.75d | 2012-08-04 | 2012-08-20 | 1.4.2.4.2.093B | 127.5d |
|  | 2 | **Strom Drainage Ponds & Box Culverts** |  | 2012-03-20 | 2012-10-20 |  |  |
| 1.4.2.4.2.010 |  | Excavation for storm water drainage pond | 10d | 2012-03-20 | 2012-03-28 | 1.4.2.4.2.090A SS | 62.5d |

| ID | WBS | Task | Duration | Start | Finish | Predecessors | Total float |
| --- | --- | --- | --- | --- | --- | --- | --- |
| 1.4.2.4.2.050A |  | Excavation for Box culvert-1 | 7.5d | 2012-03-20 | 2012-03-26 | 1.4.2.4.2.010 SS | 62.5d |
| 1.4.2.4.2.050B |  | Leveling -compaction of box culvert-1 | 7.5d | 2012-03-27 | 2012-04-02 | 1.4.2.4.2.050A | 62.5d |
| 1.4.2.4.2.020 |  | Construction of RC spillways | 25d | 2012-03-29 | 2012-04-21 | 1.4.2.4.2.010 | 212.5d |
| 1.4.2.4.2.050C |  | Construction of box culvert-1 | 43.75d | 2012-04-03 | 2012-05-13 | 1.4.2.4.2.050B | 62.5d |
| 1.4.2.4.2.015 |  | Leveling - compaction for drainage pond | 12.5d | 2012-04-22 | 2012-05-02 | 1.4.2.4.2.020 | 212.5d |
| 1.4.2.4.2.040 |  | Marl caping for drainage pond | 25d | 2012-05-10 | 2012-06-02 | 1.4.2.4.2.015 SS+20d | 212.5d |
| 1.4.2.4.2.051A |  | Excavation for Box culvert-2 | 7.5d | 2012-05-14 | 2012-05-20 | 1.4.2.4.2.050C | 62.5d |
| 1.4.2.4.2.051B |  | Leveling -compaction of box culvert-2 | 7.5d | 2012-05-21 | 2012-05-27 | 1.4.2.4.2.051A | 62.5d |
| 1.4.2.4.2.051C |  | Construction of box culvert-2 | 43.75d | 2012-05-28 | 2012-07-07 | 1.4.2.4.2.051B | 62.5d |
| 1.4.2.4.2.052A |  | Excavation for Box culvert-3 | 7.5d | 2012-07-08 | 2012-07-14 | 1.4.2.4.2.051C | 62.5d |
| 1.4.2.4.2.052B |  | Leveling -compaction of box culvert-3 | 7.5d | 2012-07-15 | 2012-07-21 | 1.4.2.4.2.052A | 62.5d |
| 1.4.2.4.2.052C |  | Construction of box culvert-3 | 43.75d | 2012-07-22 | 2012-08-30 | 1.4.2.4.2.052B | 62.5d |
| 1.4.2.4.2.053A |  | Excavation for Box culvert-4 | 7.5d | 2012-09-01 | 2012-09-06 | 1.4.2.4.2.052C | 62.5d |
| 1.4.2.4.2.054A |  | Excavation for Box culvert-5 | 7.5d | 2012-09-01 | 2012-09-06 | 1.4.2.4.2.053A SS | 62.5d |
| 1.4.2.4.2.053B |  | Leveling -compaction of box culvert-4 | 7.5d | 2012-09-08 | 2012-09-13 | 1.4.2.4.2.053A | 62.5d |
| 1.4.2.4.2.054B |  | Leveling -compaction of box culvert-5 | 7.5d | 2012-09-08 | 2012-09-13 | 1.4.2.4.2.054A | 62.5d |
| 1.4.2.4.2.053C |  | Construction of box culvert-4 | 38.75d | 2012-09-15 | 2012-10-20 | 1.4.2.4.2.053B | 62.5d |
| 1.4.2.4.2.054C |  | Construction of box culvert-5 | 38.75d | 2012-09-15 | 2012-10-20 | 1.4.2.4.2.054B | 62.5d |
|  | 3 | **Zone 3** |  | 2012-01-28 | 2012-10-20 |  |  |
|  | 1 | **Storm Drainage Ditches-A3-1** |  | 2012-01-28 | 2012-06-20 |  |  |
| 1.4.2.4.3.090A |  | Excavation for storm water drainage ditchA3-1-1 | 7.5d | 2012-01-28 | 2012-02-04 | 1.4.2.7.3.030 SS+31.25d | 62.75d |
| 1.4.2.4.3.090B |  | Leveling -compaction of drainage ditchA3-1-1 | 12.5d | 2012-02-04 | 2012-02-15 | 1.4.2.4.3.090A | 66.5d |
| 1.4.2.4.3.090C |  | Construction of concrete drainage ditchA3-1-1 | 18.75d | 2012-02-15 | 2012-03-04 | 1.4.2.4.3.090B | 66.5d |
| 1.4.2.4.3.092A |  | Excavation for storm water drainage ditchA3-1-2 | 7.5d | 2012-03-04 | 2012-03-11 | 1.4.2.4.3.090C | 66.5d |
| 1.4.2.4.3.092B |  | Leveling -compaction of drainage ditchA3-1-2 | 12.5d | 2012-03-11 | 2012-03-22 | 1.4.2.4.3.092A | 66.5d |
| 1.4.2.4.3.092C |  | Construction of concrete drainage ditchA3-1-2 | 18.75d | 2012-03-22 | 2012-04-09 | 1.4.2.4.3.092B | 66.5d |
| 1.4.2.4.3.094A |  | Excavation for storm water drainage ditchA3-1-3 | 7.5d | 2012-04-09 | 2012-04-16 | 1.4.2.4.3.092C | 66.5d |
| 1.4.2.4.3.094B |  | Leveling -compaction of drainage ditchA3-1-3 | 12.5d | 2012-04-16 | 2012-04-28 | 1.4.2.4.3.094A | 66.5d |
| 1.4.2.4.3.094C |  | Construction of concrete drainage ditchA3-1-3 | 18.75d | 2012-04-28 | 2012-05-15 | 1.4.2.4.3.094B | 66.5d |
| 1.4.2.4.3.096A |  | Excavation for storm water drainage ditchA3-1-4 | 7.5d | 2012-05-15 | 2012-05-22 | 1.4.2.4.3.094C | 66.5d |
| 1.4.2.4.3.096B |  | Leveling -compaction of drainage ditchA3-1-4 | 12.5d | 2012-05-22 | 2012-06-03 | 1.4.2.4.3.096A | 66.5d |
| 1.4.2.4.3.096C |  | Construction of concrete drainage ditchA3-1-4 | 18.75d | 2012-06-03 | 2012-06-20 | 1.4.2.4.3.096B | 66.5d |
|  | 2 | **Strom Drainage Ponds-A3-1** |  | 2012-06-20 | 2012-10-16 |  |  |
| 1.4.2.4.3.010 |  | Excavation for storm water drainage pond (1) | 7.5d | 2012-06-20 | 2012-06-27 | 1.4.2.4.3.096C | 66.5d |
| 1.4.2.4.3.015 |  | Leveling- compaction for drainage pond | 15d | 2012-06-27 | 2012-07-11 | 1.4.2.4.3.010 | 66.5d |
| 1.4.2.4.3.020 |  | Construction of RC spillwaysA | 25d | 2012-07-11 | 2012-08-04 | 1.4.2.4.3.015 | 66.5d |
| 1.4.2.4.3.030 |  | Construction of RC spillwaysB | 25d | 2012-08-04 | 2012-08-27 | 1.4.2.4.3.020 | 66.5d |
| 1.4.2.4.3.040 |  | Marl caping for drainage pond | 25d | 2012-08-27 | 2012-09-19 | 1.4.2.4.3.020, 1.4.2.4.3.030 | 66.5d |
| 1.4.2.4.3.050 |  | Excavation for Box culvert | 7.5d | 2012-08-27 | 2012-09-03 | 1.4.2.4.3.040 SS | 66.5d |
| 1.4.2.4.3.060 |  | Leveling -compaction of box culvert | 7.5d | 2012-09-03 | 2012-09-10 | 1.4.2.4.3.050 | 66.5d |
| 1.4.2.4.3.070 |  | Construction of box culvert | 38.75d | 2012-09-10 | 2012-10-16 | 1.4.2.4.3.060 | 66.5d |
|  | 3 | **Storm Drainage Ditches-A3-2** |  | 2012-02-04 | 2012-09-03 |  |  |
| 1.4.2.4.3.100A |  | Excavation for storm water drainage ditchA3-2.-1 | 18.75d | 2012-02-04 | 2012-02-21 | 1.4.2.4.3.090A | 62.75d |
| 1.4.2.4.3.100B |  | Leveling -compaction of drainage ditchA3-2-1 | 15d | 2012-02-21 | 2012-03-06 | 1.4.2.4.3.100A | 112.75d |
| 1.4.2.4.3.100C |  | Construction of concrete drainage ditchA3-2-1 | 25d | 2012-03-06 | 2012-03-29 | 1.4.2.4.3.100B | 112.75d |
| 1.4.2.4.3.102A |  | Excavation for storm water drainage ditchA3-2-2 | 18.75d | 2012-03-29 | 2012-04-16 | 1.4.2.4.3.100C | 112.75d |
| 1.4.2.4.3.102B |  | Leveling -compaction of drainage ditchA3-2-2 | 12.5d | 2012-04-16 | 2012-04-28 | 1.4.2.4.3.102A | 112.75d |
| 1.4.2.4.3.102C |  | Construction of concrete drainage ditchA3-2-2 | 25d | 2012-04-28 | 2012-05-21 | 1.4.2.4.3.102B | 112.75d |
| 1.4.2.4.3.104A |  | Excavation for storm water drainage ditchA3-2-3 | 18.75d | 2012-05-21 | 2012-06-07 | 1.4.2.4.3.102C | 112.75d |
| 1.4.2.4.3.104B |  | Leveling -compaction of drainage ditchA3-2-3 | 12.5d | 2012-06-07 | 2012-06-19 | 1.4.2.4.3.104A | 112.75d |
| 1.4.2.4.3.104C |  | Construction of concrete drainage ditchA3-2-3 | 25d | 2012-06-19 | 2012-07-12 | 1.4.2.4.3.104B | 112.75d |
| 1.4.2.4.3.106A |  | Excavation for storm water drainage ditchA3-2-4 | 18.75d | 2012-07-12 | 2012-07-30 | 1.4.2.4.3.104C | 112.75d |
| 1.4.2.4.3.106B |  | Leveling -compaction of drainage ditchA3-2-4 | 12.5d | 2012-07-30 | 2012-08-11 | 1.4.2.4.3.106A | 112.75d |
| 1.4.2.4.3.106C |  | Construction of concrete drainage ditchA3-2-4 | 25d | 2012-08-11 | 2012-09-03 | 1.4.2.4.3.106B | 112.75d |
|  | 5 | **Storm Drainage Ditches & Box Culvert -A3-3** |  | 2012-02-21 | 2012-09-10 |  |  |
| 1.4.2.4.3.110A |  | Excavation for storm water drainage ditchA3-3-1 | 18.75d | 2012-02-21 | 2012-03-10 | 1.4.2.4.3.100A | 62.75d |
| 1.4.2.4.3.110B |  | Leveling -compaction of drainage ditchA3-3-1 | 15d | 2012-03-10 | 2012-03-24 | 1.4.2.4.3.110A | 62.75d |
| 1.4.2.4.3.110C |  | Construction of concrete drainage ditchA3-3-1 | 25d | 2012-03-24 | 2012-04-16 | 1.4.2.4.3.110B | 62.75d |
| 1.4.2.4.3.112A |  | Excavation for storm water drainage ditchA3-3-2 | 18.75d | 2012-04-16 | 2012-05-03 | 1.4.2.4.3.110C | 62.75d |
| 1.4.2.4.3.112B |  | Leveling -compaction of drainage ditchA3-3-2 | 12.5d | 2012-05-03 | 2012-05-15 | 1.4.2.4.3.112A | 62.75d |
| 1.4.2.4.3.112C |  | Construction of concrete drainage ditchA3-3-2 | 25d | 2012-05-15 | 2012-06-07 | 1.4.2.4.3.112B | 62.75d |
| 1.4.2.4.3.114A |  | Excavation for storm water drainage ditchA3-3-3 | 18.75d | 2012-06-07 | 2012-06-25 | 1.4.2.4.3.112C | 62.75d |
| 1.4.2.4.3.114B |  | Leveling -compaction of drainage ditchA3-3-3 | 12.5d | 2012-06-25 | 2012-07-07 | 1.4.2.4.3.114A | 105.25d |
| 1.4.2.4.3.114C |  | Construction of concrete drainage ditchA3-3-3 | 25d | 2012-07-07 | 2012-07-30 | 1.4.2.4.3.114B | 105.25d |
| 1.4.2.4.3.116A |  | Excavation for storm water drainage ditchA3-3-4 | 18.75d | 2012-07-30 | 2012-08-16 | 1.4.2.4.3.114C | 105.25d |
| 1.4.2.4.3.116B |  | Leveling -compaction of drainage ditchA3-3-4 | 12.5d | 2012-08-16 | 2012-08-28 | 1.4.2.4.3.116A | 105.25d |
| 1.4.2.4.3.116C |  | Construction of concrete drainage ditchA3-3-4 | 21.25d | 2012-08-21 | 2012-09-10 | 1.4.2.4.3.116B SS+5d | 105.25d |
|  | 6 | **Strom Drainage Ponds -A3-3** |  | 2012-06-07 | 2012-10-20 |  |  |
| 1.4.2.4.3.310 |  | Excavation for storm water drainage pond (1) | 7.5d | 2012-06-07 | 2012-06-14 | 1.4.2.4.3.114A SS | 62.75d |
| 1.4.2.4.3.320 |  | Leveling- compaction for drainage pond | 10d | 2012-06-14 | 2012-06-24 | 1.4.2.4.3.310 | 62.75d |

| ID | WBS | Task | Duration | Start | Finish | Predecessors | Total float |
| --- | --- | --- | --- | --- | --- | --- | --- |
| 1.4.2.4.3.330 |  | Construction of RC spillways | 25d | 2012-06-24 | 2012-07-17 | 1.4.2.4.3.320 | 62.75d |
| 1.4.2.4.3.340 |  | Marl caping for drainage pond | 10d | 2012-07-17 | 2012-07-26 | 1.4.2.4.3.330 | 62.75d |
| 1.4.2.4.3.350 |  | Excavation for storm water drainage pond (2) | 7.5d | 2012-07-26 | 2012-08-02 | 1.4.2.4.3.340 | 62.75d |
| 1.4.2.4.3.360 |  | Leveling- compaction for drainage pond | 7.5d | 2012-08-02 | 2012-08-09 | 1.4.2.4.3.350 | 62.75d |
| 1.4.2.4.3.370 |  | Construction of RC spillways | 25d | 2012-08-09 | 2012-09-02 | 1.4.2.4.3.360 | 62.75d |
| 1.4.2.4.3.380 |  | Marl caping for drainage pond | 10d | 2012-09-02 | 2012-09-11 | 1.4.2.4.3.370 | 62.75d |
| 1.4.2.4.3.390 |  | Excavation for Box culvert | 7.5d | 2012-09-02 | 2012-09-09 | 1.4.2.4.3.380 SS | 62.75d |
| 1.4.2.4.3.400 |  | Leveling -compaction of box culvert | 7.5d | 2012-09-09 | 2012-09-16 | 1.4.2.4.3.390 | 62.75d |
| 1.4.2.4.3.450 |  | Construction of box culvert | 36.25d | 2012-09-16 | 2012-10-20 | 1.4.2.4.3.400 | 62.75d |
|  | 7 | **Strom Drainage Ponds -A3-4** |  | 2012-06-07 | 2012-10-10 |  |  |
| 1.4.2.4.3.410 |  | Excavation for storm water drainage ditchA | 12.5d | 2012-06-07 | 2012-06-19 | 1.4.2.4.3.310 SS | 72.75d |
| 1.4.2.4.3.420 |  | Leveling -compaction of drainage ditchA | 12.5d | 2012-06-19 | 2012-07-01 | 1.4.2.4.3.410 | 72.75d |
| 1.4.2.4.3.430 |  | Construction of concrete drainage ditchA | 25d | 2012-07-01 | 2012-07-24 | 1.4.2.4.3.420 | 72.75d |
| 1.4.2.4.3.440 |  | Excavation for storm water drainage ditchB | 12.5d | 2012-07-24 | 2012-08-05 | 1.4.2.4.3.430 | 72.75d |
| 1.4.2.4.3.460 |  | Leveling -compaction of drainage ditchB | 12.5d | 2012-08-05 | 2012-08-16 | 1.4.2.4.3.440 | 72.75d |
| 1.4.2.4.3.470 |  | Construction of concrete drainage ditchB | 25d | 2012-08-16 | 2012-09-09 | 1.4.2.4.3.460 | 72.75d |
| 1.4.2.4.3.480 |  | Excavation for Box culvert A | 7.5d | 2012-08-16 | 2012-08-23 | 1.4.2.4.3.470 SS | 72.75d |
| 1.4.2.4.3.490 |  | Leveling -compaction of box culvertA | 7.5d | 2012-08-23 | 2012-08-30 | 1.4.2.4.3.480 | 77.75d |
| 1.4.2.4.3.510 |  | Excavation for Box culvert B | 7.5d | 2012-08-23 | 2012-08-30 | 1.4.2.4.3.480 | 72.75d |
| 1.4.2.4.3.500 |  | Construction of box culvertA | 38.75d | 2012-08-30 | 2012-10-06 | 1.4.2.4.3.490 | 77.75d |
| 1.4.2.4.3.520 |  | Leveling -compaction of box culvertB | 7.5d | 2012-08-30 | 2012-09-06 | 1.4.2.4.3.510 | 72.75d |
| 1.4.2.4.3.530 |  | Construction of box culvertB | 36.25d | 2012-09-06 | 2012-10-10 | 1.4.2.4.3.520 | 72.75d |
|  | 8 | **Strom Drainage Ponds -A3-5** |  | 2012-06-07 | 2012-10-02 |  |  |
| 1.4.2.4.3.610 |  | Excavation for storm water drainage ditchA | 7.5d | 2012-06-07 | 2012-06-14 | 1.4.2.4.3.410 SS | 81.5d |
| 1.4.2.4.3.620 |  | Leveling -compaction of drainage ditchA | 7.5d | 2012-06-14 | 2012-06-21 | 1.4.2.4.3.610 | 81.5d |
| 1.4.2.4.3.630 |  | Construction of concrete drainage ditchA | 18.75d | 2012-06-21 | 2012-07-09 | 1.4.2.4.3.620 | 81.5d |
| 1.4.2.4.3.640 |  | Excavation for storm water drainage ditchB | 7.5d | 2012-07-09 | 2012-07-16 | 1.4.2.4.3.630 | 81.5d |
| 1.4.2.4.3.650 |  | Leveling -compaction of drainage ditchB | 7.5d | 2012-07-16 | 2012-07-23 | 1.4.2.4.3.640 | 81.5d |
| 1.4.2.4.3.660 |  | Construction of concrete drainage ditchB | 18.75d | 2012-07-23 | 2012-08-09 | 1.4.2.4.3.650 | 81.5d |
| 1.4.2.4.3.670 |  | Excavation for Box culvert A | 7.5d | 2012-08-09 | 2012-08-16 | 1.4.2.4.3.660 | 81.5d |
| 1.4.2.4.3.680 |  | Leveling -compaction of box culvertA | 7.5d | 2012-08-16 | 2012-08-23 | 1.4.2.4.3.670 | 292.75d |
| 1.4.2.4.3.700 |  | Excavation for Box culvert B | 7.5d | 2012-08-16 | 2012-08-23 | 1.4.2.4.3.670 | 81.5d |
| 1.4.2.4.3.690 |  | Construction of box culvertA | 38.75d | 2012-08-23 | 2012-09-29 | 1.4.2.4.3.680 | 292.75d |
| 1.4.2.4.3.710 |  | Leveling -compaction of box culvertB | 7.5d | 2012-08-23 | 2012-08-30 | 1.4.2.4.3.700 | 81.5d |
| 1.4.2.4.3.720 |  | Construction of box culvertB | 35d | 2012-08-30 | 2012-10-02 | 1.4.2.4.3.710 | 81.5d |
|  | 4 | **Zone 4** |  | 2012-06-10 | 2012-10-03 |  |  |
|  | 1 | **Storm Drainage Ditches** |  | 2012-06-10 | 2012-08-29 |  |  |
| 1.4.2.4.4.110A |  | Excavation for storm water drainage ditch-A(1200LM) | 10d | 2012-06-10 | 2012-06-18 | 1.4.2.4.1.010 FS+37.5d | 80d |
| 1.4.2.4.4.110B |  | Leveling -compaction of drainage ditch-A | 12.5d | 2012-06-19 | 2012-06-30 | 1.4.2.4.4.110A | 117.5d |
| 1.4.2.4.4.110C |  | Construction of concrete drainage ditch-A | 25d | 2012-07-01 | 2012-07-23 | 1.4.2.4.4.110B | 117.5d |
| 1.4.2.4.4.120A |  | Excavation for storm water drainage ditch-B(1200LM) | 10d | 2012-07-24 | 2012-08-01 | 1.4.2.4.4.110C | 117.5d |
| 1.4.2.4.4.120B |  | Leveling -compaction of drainage ditch-B | 12.5d | 2012-08-02 | 2012-08-13 | 1.4.2.4.4.120A | 117.5d |
| 1.4.2.4.4.120C |  | Construction of concrete drainage ditch-B | 17.5d | 2012-08-14 | 2012-08-29 | 1.4.2.4.4.120B | 117.5d |
|  | 2 | **Storm Drainage Ponds** |  | 2012-06-14 | 2012-10-03 |  |  |
| 1.4.2.4.4.010 |  | Excavation for storm water drainage pond(1) | 7.5d | 2012-06-14 | 2012-06-20 | 1.4.2.4.4.110A SS+5d | 80d |
| 1.4.2.4.4.015 |  | Leveling - compactionfor drainage pond | 15d | 2012-06-21 | 2012-07-04 | 1.4.2.4.4.010 | 80d |
| 1.4.2.4.4.020 |  | Construction of RC spillways | 25d | 2012-07-05 | 2012-07-28 | 1.4.2.4.4.015 | 80d |
| 1.4.2.4.4.040 |  | Marl caping for drainage pond | 12.5d | 2012-07-29 | 2012-08-08 | 1.4.2.4.4.110B SS, 1.4.2.4.4.020 | 80d |
| 1.4.2.4.4.050 |  | Excavation for storm water drainage pond(2) | 7.5d | 2012-08-09 | 2012-08-15 | 1.4.2.4.4.040 | 80d |
| 1.4.2.4.4.060 |  | Leveling - compactionfor drainage pond | 15d | 2012-08-16 | 2012-08-29 | 1.4.2.4.4.050 | 80d |
| 1.4.2.4.4.070 |  | Construction of RC spillways | 25d | 2012-08-30 | 2012-09-22 | 1.4.2.4.4.060 | 80d |
| 1.4.2.4.4.080 |  | Marl caping for drainage pond | 12.5d | 2012-09-23 | 2012-10-03 | 1.4.2.4.4.070 | 80d |
|  | 6 | **Road Networks** |  | 2011-03-19 | 2012-12-17 |  |  |
|  | 1 | **Fencing System & Gates** |  | 2011-03-19 | 2011-07-23 |  |  |
| 1.4.1.3.1.010 |  | Install temp gate & jersey barriers for zone1 | 23.75d | 2011-03-19 | 2011-04-09 | 1.3.1.5.030 SS, 1.4.1.1.160, 1.3.1.5.130, 1.3.1.6.120 SS | 37.5d |
| 1.4.1.3.3.010 |  | Install temp gate & jersey barriers for zone3 | 65d | 2011-04-10 | 2011-06-08 | 1.4.1.3.1.010 | 37.5d |
| 1.4.1.3.2.010 |  | Install temp gate & jersey barriers for zone2 | 62.5d | 2011-05-26 | 2011-07-23 | 1.4.1.3.3.010 SS+50d | 50d |
| 1.4.1.3.4.010 |  | Install temp gate & jersey barriers for zone4 | 43.75d | 2011-06-13 | 2011-07-23 | 1.4.1.3.2.010 SS+18.75d | 93.75d |
|  | 2 | **Patrol Road works** |  | 2011-07-06 | 2011-10-18 |  |  |
| 1.4.2.5.2.010 |  | Install 200mm thk compacted Patrol Roads for Zone 1 | 31.25d | 2011-07-06 | 2011-08-03 | 1.4.1.3.1.010 FS+93.75d | 112.5d |
| 1.4.2.5.2.030 |  | Install 200mm thk compacted Patrol Roads for Zone 3 | 56.25d | 2011-07-14 | 2011-09-04 | 1.4.1.3.3.010 FS+37.5d | 122.5d |
| 1.4.2.5.2.020 |  | Install 200mm thk compacted Patrol Roads for Zone 2 | 56.25d | 2011-08-28 | 2011-10-18 | 1.4.1.3.2.010 FS+37.5d | 50d |
| 1.4.2.5.2.040 |  | Install 200mm thk compacted Patrol Roads for Zone 4 | 25d | 2011-09-14 | 2011-10-06 | 1.4.1.3.4.010 FS+56.25d | 93.75d |
|  | 3 | **Asphalt Road Works A/B/C/D** |  | 2012-04-05 | 2012-12-17 |  |  |
| 1.4.2.5.3.010 |  | Site grading/clearing/grubbing | 37.5d | 2012-04-05 | 2012-05-09 | 1.4.2.7.3.050 SS, 1.3.1.1.230 | 0d |
| 1.4.2.5.3.020 |  | Cut/fill of existing grade | 56.25d | 2012-04-29 | 2012-06-19 | 1.4.2.5.3.010 SS+25d | 75d |
| 1.4.2.5.3.040 |  | Laying of geogrid | 75d | 2012-04-29 | 2012-07-07 | 1.4.2.5.3.010 SS+25d, 1.3.1.1.230 | 0d |
| 1.4.2.5.3.050 |  | backfill with aggregate crushed stone | 75d | 2012-06-03 | 2012-08-11 | 1.4.2.5.3.040 SS+37.5d | 0d |
| 1.4.2.5.3.060 |  | Supp & laying of Alyaf geotextile | 75d | 2012-07-08 | 2012-09-15 | 1.4.2.5.3.050 SS+37.5d | 0d |
| 1.4.2.5.3.070 |  | Supp & lay aggregate base course typeA | 75d | 2012-08-06 | 2012-10-14 | 1.4.2.5.3.060 SS+31.25d, 1.4.2.7.2.090 SS, 1.4.2.5.3.020 SS+31.25d, 1.3.1.6.160 | 0d |

| ID | WBS | Task | Duration | Start | Finish | Predecessors | Total float |
| --- | --- | --- | --- | --- | --- | --- | --- |
| 1.4.2.5.3.080 |  | Install MC70 asphalt prime coat | 75d | 2012-09-04 | 2012-11-12 | 1.4.2.5.3.070 SS+31.25d | 0d |
| 1.4.2.5.3.090 |  | Install asphalt concret binder class A | 75d | 2012-09-04 | 2012-11-12 | 1.4.2.5.3.080 SS | 0d |
| 1.4.2.5.3.100 |  | Install RC 250 asphalt tack coat | 56.25d | 2012-10-03 | 2012-11-24 | 1.4.2.5.3.090 SS+31.25d | 0d |
| 1.4.2.5.3.110 |  | Install asphalt concrt wear course class B | 50d | 2012-11-01 | 2012-12-17 | 1.4.2.5.3.100 SS+31.25d | 0d |
|  | 4 | **Curbs & Walkways** |  | 2012-05-10 | 2012-12-11 |  |  |
| 1.4.2.5.4.010 |  | Install curb & gutter & walkways Zone3 - A3-1 | 56.25d | 2012-05-10 | 2012-07-01 | 1.4.2.5.3.010 SS+37.5d, 1.3.1.2.060 | 6.25d |
| 1.4.2.5.4.020 |  | Install curb & gutter & walkways Zone3 - A3-2 | 50d | 2012-07-02 | 2012-08-16 | 1.4.2.5.4.010 | 6.25d |
| 1.4.2.5.4.030 |  | Install curb & gutter & walkways Zone3 - A3-3 | 56.25d | 2012-08-18 | 2012-10-08 | 1.4.2.5.4.020 | 6.25d |
| 1.4.2.5.4.040 |  | Install curb & gutter & walkways Zone2 - A2-1 | 31.25d | 2012-10-09 | 2012-11-06 | 1.4.2.5.4.030 | 6.25d |
| 1.4.2.5.4.050 |  | Install curb & gutter & walkways Zone2 - A2-2 | 37.5d | 2012-11-07 | 2012-12-11 | 1.4.2.5.4.040 | 6.25d |
|  | 5 | **Segway / Bicycle lane** |  | 2012-05-20 | 2012-12-05 |  |  |
| 1.4.2.5.5.010A |  | Site grading/sub-grade course compaction Zone3 -A3-1 | 18.75d | 2012-05-20 | 2012-06-05 | 1.4.2.5.4.010 SS+10d | 105d |
| 1.4.2.5.5.010B |  | Install agregate grade course type A Zone3 - A3-1 | 12.5d | 2012-06-06 | 2012-06-17 | 1.4.2.5.5.010A | 105d |
| 1.4.2.5.5.010C |  | Install RC pavement for bicycle lane Zone3 - A3-1 | 12.5d | 2012-06-18 | 2012-06-28 | 1.4.2.5.5.010B | 105d |
| 1.4.2.5.5.020A |  | Site grading/sub-grade course compaction Zone3 -A3-2 | 18.75d | 2012-06-30 | 2012-07-16 | 1.4.2.5.5.010C | 105d |
| 1.4.2.5.5.020B |  | Install agregate grade course type A Zone3 - A3-2 | 12.5d | 2012-07-17 | 2012-07-28 | 1.4.2.5.5.020A | 105d |
| 1.4.2.5.5.020C |  | Install RC pavement for bicycle lane Zone3 - A3-2 | 12.5d | 2012-07-29 | 2012-08-08 | 1.4.2.5.5.020B | 105d |
| 1.4.2.5.5.030A |  | Site grading/sub-grade course compaction Zone3 -A3-3 | 27.5d | 2012-08-09 | 2012-09-03 | 1.4.2.5.5.020C | 105d |
| 1.4.2.5.5.030B |  | Install agregate grade course type A Zone3 - A3-3 | 17.5d | 2012-09-04 | 2012-09-19 | 1.4.2.5.5.030A | 105d |
| 1.4.2.5.5.030C |  | Install RC pavement for bicycle lane Zone3 - A3-3 | 17.5d | 2012-09-20 | 2012-10-06 | 1.4.2.5.5.030B | 105d |
| 1.4.2.5.5.040A |  | Site grading/sub-grade course compaction Zone2 -A2-1 | 10d | 2012-10-07 | 2012-10-15 | 1.4.2.5.5.030C | 105d |
| 1.4.2.5.5.040B |  | Install agregate grade course type A Zone2 - A2-1 | 7.5d | 2012-10-16 | 2012-10-22 | 1.4.2.5.5.040A | 105d |
| 1.4.2.5.5.040C |  | Install RC pavement for bicycle lane Zone2 - A2-1 | 7.5d | 2012-10-23 | 2012-10-29 | 1.4.2.5.5.040B | 105d |
| 1.4.2.5.5.050A |  | Site grading/sub-grade course compaction Zone2 -A2-2 | 15d | 2012-10-30 | 2012-11-12 | 1.4.2.5.5.040C | 105d |
| 1.4.2.5.5.050B |  | Install agregate grade course type A Zone2 - A2-2 | 12.5d | 2012-11-13 | 2012-11-24 | 1.4.2.5.5.050A | 105d |
| 1.4.2.5.5.050C |  | Install RC pavement for bicycle lane Zone2 - A2-2 | 12.5d | 2012-11-25 | 2012-12-05 | 1.4.2.5.5.050B | 105d |
|  | 6 | **Traffic Signage** |  | 2012-09-04 | 2012-12-11 |  |  |
| 1.4.2.5.6.010A |  | Install road markings Zone 3 - A3-1 | 18.75d | 2012-09-04 | 2012-09-20 | 1.4.2.5.3.090 SS, 1.3.1.6.180 | 6.25d |
| 1.4.2.5.6.010B |  | Install road markings Zone 3 - A3-2 | 25d | 2012-09-22 | 2012-10-14 | 1.4.2.5.6.010A | 12.5d |
| 1.4.2.5.6.020A |  | Install road signage with GI pipe post Zone3 - A3-1 | 22.5d | 2012-09-22 | 2012-10-11 | 1.4.2.5.6.010A | 6.25d |
| 1.4.2.5.6.020B |  | Install road signage with GI pipe post Zone3 - A3-2 | 25d | 2012-10-13 | 2012-11-04 | 1.4.2.5.6.020A | 6.25d |
| 1.4.2.5.6.010C |  | Install road markings Zone 3 - A3-3 | 31.25d | 2012-10-15 | 2012-11-12 | 1.4.2.5.6.010B | 12.5d |
| 1.4.2.5.6.020C |  | Install road signage with GI pipe post Zone3 - A3-3 | 31.25d | 2012-11-05 | 2012-12-03 | 1.4.2.5.6.020B | 6.25d |
| 1.4.2.5.6.010D |  | Install road markings Zone 2 | 25d | 2012-11-13 | 2012-12-05 | 1.4.2.5.6.010C | 12.5d |
| 1.4.2.5.6.020D |  | Install road signage with GI pipe post Zone2 | 18.75d | 2012-11-25 | 2012-12-11 | 1.4.2.5.6.020C SS+21.25d | 6.25d |
|  | 7 | **Landscaping & Hardscaping** |  | 2012-04-05 | 2012-12-08 |  |  |
|  | 1 | **Landscaping & Hardscaping** |  | 2012-04-05 | 2012-12-08 |  |  |
|  | 1 | **Zone 3** |  | 2012-04-05 | 2012-12-08 |  |  |
| 1.4.2.6.010 |  | Site grading/clearing/grubbing | 75d | 2012-04-05 | 2012-06-13 | 1.4.2.5.3.010 SS, 1.3.4.1.030 | 10d |
| 1.4.2.6.020 |  | Cut/fill upto exisitng grade | 75d | 2012-04-23 | 2012-07-01 | 1.4.2.6.010 SS+18.75d | 68.75d |
| 1.4.2.6.130 |  | constrcution (structural/archt'l) of water fountain | 75d | 2012-04-23 | 2012-07-01 | 1.4.2.6.010 SS+7.5d, 1.4.2.6.020 SS | 68.75d |
| 1.4.2.6.030 |  | Fill/compaction upto lower level | 75d | 2012-04-29 | 2012-07-07 | 1.4.2.6.010 SS+25d | 10d |
| 1.4.2.6.040 |  | Aggregarte basecoarse for sidewalk & walkways | 75d | 2012-05-16 | 2012-07-24 | 1.4.2.6.030 SS+18.75d | 10d |
| 1.4.2.6.140 |  | constrcution (structural/archt'l) of fitness park | 75d | 2012-05-28 | 2012-08-05 | 1.4.2.6.130 SS+37.5d | 68.75d |
| 1.4.2.6.050 |  | Sweet sand basecoarse for sidewalk & walkways | 75d | 2012-06-03 | 2012-08-11 | 1.4.2.6.040 SS+18.75d, 1.3.5.3.3.030, 1.3.5.3.4.030 | 10d |
| 1.4.2.6.060 |  | RC pavement for walkways | 75d | 2012-06-20 | 2012-08-28 | 1.4.2.6.050 SS+18.75d | 10d |
| 1.4.2.6.070 |  | Interlocking tiles for walkways | 75d | 2012-06-27 | 2012-09-04 | 1.4.2.6.060 SS+7.5d | 10d |
| 1.4.2.6.080 |  | Decorative interlocking tiles for wlaslkways | 75d | 2012-07-15 | 2012-09-22 | 1.4.2.6.070 SS+18.75d | 10d |
| 1.4.2.6.090 |  | concrete edging for walkways | 112.5d | 2012-08-01 | 2012-11-13 | 1.4.2.6.080 SS+18.75d | 10d |
| 1.4.2.6.100 |  | sweet sand for playground area | 75d | 2012-08-08 | 2012-10-16 | 1.4.2.6.090 SS+7.5d | 10d |
| 1.4.2.6.150 |  | constrcution (structural/archt'l) of play park fountain & fitting | 75d | 2012-08-08 | 2012-10-16 | 1.4.2.6.100 SS, 1.4.2.6.140 SS+18.75d, 1.3.4.1.130 | 10d |
| 1.4.2.6.110 |  | gravel mulch for trees well | 75d | 2012-08-26 | 2012-11-03 | 1.4.2.6.100 SS+18.75d | 32.5d |
| 1.4.2.6.120 |  | natural stone boulder/sculptured(1each large & 2 small) | 71.25d | 2012-09-12 | 2012-11-17 | 1.4.2.6.110 SS+18.75d | 32.5d |
| 1.4.2.6.160 |  | Install Maze & Labyrinth | 37.5d | 2012-09-30 | 2012-11-03 | 1.4.2.6.150 SS+56.25d, 1.4.2.7.3.040 | 10d |
| 1.4.2.6.170 |  | Install Turfin & ground cover | 37.5d | 2012-11-04 | 2012-12-08 | 1.4.2.6.160 | 10d |
|  | 8 | **Power Distribution** |  | 2011-08-14 | 2012-10-13 |  |  |
|  | 01 | **MV Cables** |  | 2011-12-06 | 2012-05-17 |  |  |
| 1.4.2.7.1.010 |  | Excavation of trench for MV cables & Ductbanks | 31.25d | 2011-12-06 | 2012-01-04 | 1.3.2.7.8.030, 1.3.2.3.030, Z3.2180 SS, 1.3.3.2.8.030 | 37.75d |
| 1.4.2.7.1.060 |  | Splic/hi-pot/termintaion of MV cables | 25d | 2012-02-26 | 2012-03-20 | 1.4.2.7.510 | 37.75d |
| 1.4.2.7.1.070 |  | Testing & Pre-commissioning of MV cables | 25d | 2012-03-20 | 2012-04-12 | 1.4.2.7.1.060, 1.4.2.7.1.130, 1.4.2.7.230, 1.4.2.7.330, 1.4.2.7.510 | 37.75d |
| 1.4.2.7.1.050 |  | Install red tiles/cable markers | 37.5d | 2012-04-12 | 2012-05-17 | 1.4.2.7.1.070, 1.4.2.7.510 | 42.75d |
| 1.4.2.7.1.080 |  | Backfilling of MV cables | 37.5d | 2012-04-12 | 2012-05-17 | 1.4.2.7.1.050 SS | 42.75d |
|  | 1 | **Zone 3 - A3-1 & 4** |  | 2011-12-06 | 2012-01-19 |  |  |
| 1.4.2.7.1.100 |  | Excavation of MV cable trench | 10d | 2011-12-06 | 2011-12-15 | 1.4.2.7.1.010 SS | 102.75d |
| 1.4.2.7.1.110 |  | Install MV cable A | 12.5d | 2011-12-15 | 2011-12-27 | 1.4.2.7.1.010 SS, 1.4.2.7.1.100 | 102.75d |
| 1.4.2.7.1.120 |  | Install MV cable B | 12.5d | 2011-12-27 | 2012-01-08 | 1.4.2.7.1.110 | 102.75d |
| 1.4.2.7.1.130 |  | Install MV cable C | 12.5d | 2012-01-08 | 2012-01-19 | 1.4.2.7.1.120 | 102.75d |
|  | 2 | **Zone 3 - A3-2** |  | 2011-12-15 | 2012-01-29 |  |  |
| 1.4.2.7.200 |  | Excavation of MV cable trench | 10d | 2011-12-15 | 2011-12-25 | 1.4.2.7.1.010 SS+10d | 92.75d |
| 1.4.2.7.210 |  | Install MV cable A | 12.5d | 2011-12-25 | 2012-01-05 | 1.4.2.7.1.010 SS, 1.4.2.7.200 | 92.75d |

| ID | WBS | Task | Duration | Start | Finish | Predecessors | Total float |
| --- | --- | --- | --- | --- | --- | --- | --- |
| 1.4.2.7.220 |  | Install MV cable B | 12.5d | 2012-01-05 | 2012-01-17 | 1.4.2.7.210 | 92.75d |
| 1.4.2.7.230 |  | Install MV cable C | 12.5d | 2012-01-17 | 2012-01-29 | 1.4.2.7.220 | 92.75d |
|  | 3 | **Zone 3 - A3-3** |  | 2011-12-18 | 2012-01-31 |  |  |
| 1.4.2.7.300 |  | Excavation of MV cable trench | 10d | 2011-12-18 | 2011-12-27 | 1.4.2.7.1.010 SS+12.5d | 90.25d |
| 1.4.2.7.310 |  | Install MV cable A | 12.5d | 2011-12-27 | 2012-01-08 | 1.4.2.7.1.010 SS, 1.4.2.7.300 | 90.25d |
| 1.4.2.7.320 |  | Install MV cable B | 12.5d | 2012-01-08 | 2012-01-19 | 1.4.2.7.310 | 90.25d |
| 1.4.2.7.330 |  | Install MV cable C | 12.5d | 2012-01-19 | 2012-01-31 | 1.4.2.7.320 | 90.25d |
|  | 4 | **Zone 3 - A3-4** |  | 2011-12-20 | 2012-01-08 |  |  |
| 1.4.2.7.400 |  | Excavation of MV cable trench | 5d | 2011-12-20 | 2011-12-25 | 1.4.2.7.1.010 SS+15d | 82.75d |
| 1.4.2.7.410 |  | Install MV cable A | 7.5d | 2011-12-25 | 2012-01-01 | 1.4.2.7.1.010 SS, 1.4.2.7.400 | 82.75d |
| 1.4.2.7.420 |  | Install MV cable B | 7.5d | 2012-01-01 | 2012-01-08 | 1.4.2.7.410 | 82.75d |
|  | 5 | **Zone 3 - A3-5** |  | 2012-02-14 | 2012-02-26 |  |  |
| 1.4.2.7.500 |  | Excavation of MV cable trench | 5d | 2012-02-14 | 2012-02-19 | 1.4.2.7.1.010 SS+75d | 37.75d |
| 1.4.2.7.510 |  | Install MV cable A | 7.5d | 2012-02-19 | 2012-02-26 | 1.4.2.7.420, 1.4.2.7.500 | 37.75d |
|  | 6 | **Zone 2 & 1** |  |  |  |  |  |
|  | 02 | **LV Cables - Lighting Power Cables (For Permanent Roads)** |  | 2011-12-18 | 2012-09-20 |  |  |
| 1.4.2.7.2.010 |  | Excavation of trench for lighting power cables | 56.25d | 2011-12-18 | 2012-02-08 | 1.4.2.7.1.010 SS+12.5d | 41.5d |
| 1.4.2.7.2.030 |  | Install lighting power cables | 75d | 2012-02-23 | 2012-05-02 | 1.4.2.7.2.010 SS+18.75d, 1.4.5.4.6.030 | 25d |
| 1.4.2.7.2.050 |  | Install red tiles/cable markers for lighting cables | 37.5d | 2012-04-16 | 2012-05-20 | 1.4.2.7.2.030 SS+56.25d | 25d |
| 1.4.2.7.2.070 |  | Testing & commissioning of lighting cables | 37.5d | 2012-05-03 | 2012-06-06 | 1.4.2.7.2.050 SS+18.75d | 25d |
| 1.4.2.7.2.080 |  | Install lighting poles | 75d | 2012-06-07 | 2012-08-15 | 1.4.2.7.2.070, 1.3.5.4.4.030, 1.4.5.4.5.030 | 25d |
| 1.4.2.7.2.090 |  | Install lighting pole fixture | 75d | 2012-07-14 | 2012-09-20 | 1.4.2.7.2.080 SS+38.75d, 1.4.2.5.2.030 SS | 25d |
|  | 03 | **LV Cables (For Patrol Roads)** |  | 2011-08-14 | 2011-12-10 |  |  |
| 1.4.2.7.2.110 |  | Install LV cables & Lightings in Zone1 | 18.75d | 2011-08-14 | 2011-08-31 | 1.3.5.4.1.030, 1.3.5.4.2.030, 1.3.5.4.3.030, 1.4.2.5.2.010 | 101.5d |
| 1.4.2.7.2.150 |  | Install LV cables & Lightings in Zone3 | 31.25d | 2011-09-05 | 2011-10-03 | 1.4.2.5.2.030 | 122.5d |
| 1.4.2.7.2.130 |  | Install LV cables & Lightings in Zone2 | 31.25d | 2011-10-19 | 2011-11-16 | 1.4.2.5.2.020, 1.4.2.7.2.110 | 50d |
| 1.4.2.7.2.170 |  | Install LV cables & Lightings in Zone4 | 25d | 2011-11-17 | 2011-12-10 | 1.4.2.5.2.040, 1.4.2.7.2.130 | 50d |
|  | 04 | **Irrigation Cables** |  | 2011-12-18 | 2012-05-29 |  |  |
| 1.4.2.7.3.010 |  | Excavation of trench for irrigation cables | 56.25d | 2011-12-18 | 2012-02-08 | 1.4.2.7.2.010 SS, 1.4.2.7.2.150, 1.4.2.7.2.170 | 41.5d |
| 1.4.2.7.3.030 |  | Install irrigation cables | 62.5d | 2011-12-29 | 2012-02-26 | 1.4.2.7.3.010 SS+12.5d | 41.5d |
| 1.4.2.7.3.050 |  | Testing & commissioning of irrigation cables | 31.25d | 2012-02-26 | 2012-03-26 | 1.4.2.7.3.030 | 41.5d |
| 1.4.2.7.3.040 |  | Install solar powered irrigation controller | 75d | 2012-03-20 | 2012-05-29 | 1.4.2.7.3.050 SS+25d | 141.5d |
|  | 05 | **Electrcial Equipments** |  | 2011-11-23 | 2012-10-13 |  |  |
|  | 1 | **Switchgears** |  | 2012-04-17 | 2012-04-28 |  |  |
| 1.4.2.7.4.010 |  | Install switchgear SS4 | 7.5d | 2012-04-17 | 2012-04-24 | 1.4.2.7.1.070 FS+5d, 1.4.3.1.1.440 SS, 1.3.2.1.030 | 37.75d |
| 1.4.2.7.4.020 |  | Install switchgear SS5 | 7.5d | 2012-04-17 | 2012-04-24 | 1.4.2.7.1.070, 1.4.2.7.4.010 SS, 1.3.2.1.020, 1.4.2.7.1.080 SS | 37.75d |
| 1.4.2.7.4.015 |  | Testing & commissioning of switchgears | 3.75d | 2012-04-24 | 2012-04-28 | 1.4.2.7.4.010, 1.4.4.4.010 SS+37.5d | 38.25d |
| 1.4.2.7.4.025 |  | Testing & commissioning of switchgears | 3.75d | 2012-04-24 | 2012-04-28 | 1.4.2.7.4.020 | 37.75d |
|  | 2 | **Package Substations** |  | 2011-11-23 | 2012-05-08 |  |  |
| 1.4.2.7.4.030 |  | Construction of package substation foundations | 120d | 2011-11-23 | 2012-03-13 | 1.4.3.1.1.040 | 116.75d |
| 1.4.2.7.4.040 |  | Install package substation SS4 | 7.5d | 2012-04-28 | 2012-05-05 | 1.3.2.2.1.020, 1.4.2.7.4.030 SS+90d, 1.3.2.2.1.030, 1.4.2.7.4.015 | 38.25d |
| 1.4.2.7.4.050 |  | Install package substation SS5 | 7.5d | 2012-04-28 | 2012-05-05 | 1.4.2.7.4.020 SS+5d, 1.3.2.2.1.020, 1.4.2.7.4.025 | 37.75d |
| 1.4.2.7.4.045 |  | Testing & commissioning of package substations | 3.75d | 2012-05-05 | 2012-05-08 | 1.4.2.7.4.040 SS+7d | 38.25d |
| 1.4.2.7.4.055 |  | Testing & commissioning of package substations | 3.75d | 2012-05-05 | 2012-05-08 | 1.4.2.7.4.050 | 37.75d |
|  | 3 | **RMU** |  | 2011-11-23 | 2012-09-12 |  |  |
| 1.4.2.7.4.060 |  | Constrcution of RMU foundations | 150d | 2011-11-23 | 2012-04-10 | 1.4.2.7.4.030 SS | 122.5d |
| 1.4.2.7.4.070 |  | Install RMU-SS4 | 18.75d | 2012-05-08 | 2012-05-26 | 1.4.2.7.4.040 SS, 1.3.2.2.2.020, 1.4.2.7.4.060 SS+60d, 1.3.2.2.2.030, 1.4.2.7.4.045 | 38.25d |
| 1.4.2.7.4.072 |  | Install RMU-SS5 | 18.75d | 2012-05-08 | 2012-05-26 | 1.4.2.7.4.050 SS, 1.4.2.7.4.070 SS, 1.3.2.2.2.020, 1.4.2.7.4.055 | 37.75d |
| 1.4.2.7.4.071 |  | Testing & commissioning of RMU-SS4 | 6.25d | 2012-05-26 | 2012-05-31 | 1.4.2.7.4.070 | 38.25d |
| 1.4.2.7.4.073 |  | Testing & commissioning of RMU-SS5 | 6.25d | 2012-05-26 | 2012-05-31 | 1.4.2.7.4.072 SS+18.75d | 37.75d |
| 1.4.2.7.4.074 |  | Install RMU-road lighting | 90d | 2012-06-07 | 2012-08-29 | 1.4.2.7.2.070 | 195d |
| 1.4.2.7.4.075 |  | Testing & commissioning of road lighting RMU | 45d | 2012-08-02 | 2012-09-12 | 1.4.2.7.4.074 SS+60d, 1.4.2.7.4.073 | 195d |
|  | 4 | **Generators** |  | 2011-12-21 | 2012-09-09 |  |  |
| 1.4.2.7.4.090 |  | Construction of generator foundations | 90d | 2011-12-21 | 2012-03-13 | 1.4.2.7.4.060 SS+30d | 122.5d |
| 1.4.2.7.4.107 |  | Install generator LS9 | 15d | 2012-07-23 | 2012-08-06 | 1.4.2.7.4.176 | 56d |
| 1.4.2.7.4.105 |  | Install generator LS12 | 15d | 2012-08-06 | 2012-08-19 | 1.4.2.7.4.174 SS+7.5d, 1.3.2.5.030 | 35d |
| 1.4.2.7.4.108 |  | Testing & commissioning of generator LS9 | 10d | 2012-08-06 | 2012-08-15 | 1.4.2.7.4.107 | 56d |
| 1.4.2.7.4.101 |  | Install generator LS10 | 15d | 2012-08-14 | 2012-08-27 | 1.4.2.7.4.090 SS, 1.3.2.5.020, 1.4.2.7.4.170 SS+10d | 37.5d |
| 1.4.2.7.4.106 |  | Testing & commissioning of generator LS12 | 10d | 2012-08-15 | 2012-08-23 | 1.4.2.7.4.105 SS+10d | 35d |
| 1.4.2.7.4.103 |  | Install generator LS11 | 15d | 2012-08-22 | 2012-09-04 | 1.4.2.7.4.172 SS | 30d |
| 1.4.2.7.4.102 |  | Testing & commissioning of generator LS10 | 10d | 2012-08-23 | 2012-09-01 | 1.4.2.7.4.101 SS+10d | 37.5d |
| 1.4.2.7.4.104 |  | Testing & commissioning of generator LS11 | 10d | 2012-09-01 | 2012-09-09 | 1.4.2.7.4.103 SS+10d | 30d |
|  | 5 | **Submersible Pumps** |  | 2012-06-27 | 2012-10-13 |  |  |
| 1.4.2.7.4.126 |  | Install submersible pumps - LS pumps LS9 | 56.25d | 2012-06-27 | 2012-08-19 | 1.4.2.3.5.150 | 56d |
| 1.4.2.7.4.120 |  | Install submersible pumps - LS pumps LS10 | 56.25d | 2012-07-07 | 2012-08-27 | 1.3.2.4.020, 1.3.5.2.4.020, 1.3.5.2.5.020, 1.4.2.3.6.150 | 37.5d |
| 1.4.2.7.4.122 |  | Install submersible pumps - LS pumps LS11 | 56.25d | 2012-07-07 | 2012-08-27 | 1.4.2.3.7.150, 1.3.2.4.030 | 30d |
| 1.4.2.7.4.124 |  | Install submersible pumps - LS pumps LS12 | 56.25d | 2012-07-30 | 2012-09-19 | 1.4.2.3.8.150 | 35d |
| 1.4.2.7.4.127 |  | Testing & commissioning of LS submersible pumps LS9 | 31.25d | 2012-08-13 | 2012-09-11 | 1.4.2.7.4.126 SS+50d | 72.25d |
| 1.4.2.7.4.121 |  | Testing & commissioning of LS submersible pumps LS10 | 31.25d | 2012-08-22 | 2012-09-19 | 1.4.2.7.4.120 SS+50d | 62.5d |
| 1.4.2.7.4.123 |  | Testing & commissioning of LS submersible pumps LS11 | 31.25d | 2012-08-22 | 2012-09-19 | 1.4.2.7.4.122 SS+50d | 62.5d |

| ID | WBS | Task | Duration | Start | Finish | Predecessors | Total float |
| --- | --- | --- | --- | --- | --- | --- | --- |
| 1.4.2.7.4.125 |  | Testing & commissioning of LS submersible pumps LS12 | 31.25d | 2012-09-15 | 2012-10-13 | 1.4.2.7.4.124 SS+50d | 37.5d |
|  | 6 | **Transformers** |  | 2011-12-21 | 2012-06-16 |  |  |
| 1.4.2.7.4.140 |  | Constrcution of transformer foundations | 150d | 2011-12-21 | 2012-05-08 | 1.4.2.7.4.090 SS | 122.5d |
| 1.4.2.7.4.150 |  | Install transformer SS4 | 12.5d | 2012-05-31 | 2012-06-12 | 1.4.2.7.4.140 SS+60d, 1.3.2.6.020, 1.4.2.7.4.070 SS+15d, 1.3.2.6.030, 1.4.2.7.4.071 | 38.25d |
| 1.4.2.7.4.152 |  | Install transformer SS5 | 12.5d | 2012-05-31 | 2012-06-12 | 1.4.2.7.4.072 SS+12.5d, 1.3.2.6.020, 1.4.2.7.4.073 | 37.75d |
| 1.4.2.7.4.151 |  | Testing & commissioning of transformer SS4 | 3.75d | 2012-06-12 | 2012-06-16 | 1.4.2.7.4.150 | 38.25d |
| 1.4.2.7.4.153 |  | Testing & commissioning of transformer SS5 | 3.75d | 2012-06-12 | 2012-06-16 | 1.4.2.7.4.152 | 37.75d |
|  | 7 | **Automatic Transfer Switches - ATS-Fire Alarm System** |  | 2012-07-09 | 2012-09-09 |  |  |
| 1.4.2.7.4.176 |  | Install ATS-Fire Alarm System LS9 | 15d | 2012-07-09 | 2012-07-23 | 1.4.2.7.4.126 SS+12.5d | 56d |
| 1.4.2.7.4.177 |  | Testing & commissioning of ATS-LS9 | 10d | 2012-07-18 | 2012-07-28 | 1.4.2.7.4.176 SS+10d | 121d |
| 1.4.2.7.4.174 |  | Install ATS-Fire Alarm System LS12 | 15d | 2012-07-30 | 2012-08-12 | 1.4.2.7.4.124 SS, 1.3.2.7.2.030 | 35d |
| 1.4.2.7.4.170 |  | Install ATS-Fire Alarm System -LS10 | 15d | 2012-08-05 | 2012-08-18 | 1.3.2.7.2.020, 1.4.2.7.4.120 SS+31.25d | 37.5d |
| 1.4.2.7.4.175 |  | Testing & commissioning of ATS-LS12 | 10d | 2012-08-08 | 2012-08-16 | 1.4.2.7.4.174 SS+10d | 98.75d |
| 1.4.2.7.4.171 |  | Testing & commissioning of ATS-LS10 | 10d | 2012-08-14 | 2012-08-22 | 1.4.2.7.4.170 SS+10d, 1.4.2.7.4.191 SS | 92.5d |
| 1.4.2.7.4.172 |  | Install ATS-Fire Alarm System LS11 | 15d | 2012-08-22 | 2012-09-04 | 1.4.2.7.4.122 SS+50d | 30d |
| 1.4.2.7.4.173 |  | Testing & commissioning of ATS-LS11 | 10d | 2012-09-01 | 2012-09-09 | 1.4.2.7.4.172 SS+10d | 73.75d |
|  | 8 | **Switchboards** |  | 2012-06-16 | 2012-06-26 |  |  |
| 1.4.2.7.4.190 |  | Install switchboards SS4 | 7.5d | 2012-06-16 | 2012-06-23 | 1.3.2.7.3.030, 1.4.2.7.4.151 | 38.25d |
| 1.4.2.7.4.192 |  | Install switchboards SS5 | 7.5d | 2012-06-16 | 2012-06-23 | 1.4.2.7.4.152 SS+10d, 1.3.2.7.3.030, 1.4.2.7.4.153 | 37.75d |
| 1.4.2.7.4.191 |  | Testing & commissioning of switchboards SS4 | 3.75d | 2012-06-23 | 2012-06-26 | 1.4.2.7.4.190 | 38.25d |
| 1.4.2.7.4.193 |  | Testing & commissioning of switchboards SS5 | 3.75d | 2012-06-23 | 2012-06-26 | 1.4.2.7.4.192 | 37.75d |
|  | 9 | **Main distribution Panel Boards** |  | 2012-06-26 | 2012-07-07 |  |  |
| 1.4.2.7.4.210 |  | Install main distribution panel board SS4 | 7.5d | 2012-06-26 | 2012-07-03 | 1.4.2.7.4.070 SS, 1.4.2.7.4.190 SS+6d, 1.4.2.7.4.192, 1.3.2.7.4.030, 1.4.2.7.4.191 | 38.25d |
| 1.4.2.7.4.212 |  | Install main distribution panel board SS5 | 7.5d | 2012-06-26 | 2012-07-03 | 1.4.2.7.4.192 SS+6.25d, 1.4.2.7.4.070, 1.4.2.7.4.210 SS, 1.4.2.7.4.193 | 37.75d |
| 1.4.2.7.4.211 |  | Testing & commissioning of panel board SS4 | 3.75d | 2012-07-03 | 2012-07-07 | 1.4.2.7.4.210, 1.4.2.7.4.071 SS, 1.4.2.7.4.151 SS | 38.25d |
| 1.4.2.7.4.213 |  | Testing & commissioning of panel board SS5 | 3.75d | 2012-07-03 | 2012-07-07 | 1.4.2.7.4.212 | 37.75d |
|  | 10 | **Circuit Breakers** |  | 2012-07-07 | 2012-07-17 |  |  |
| 1.4.2.7.4.230 |  | Install circuit breaker SS4 | 7.5d | 2012-07-07 | 2012-07-14 | 1.4.2.7.4.210 SS+6d, 1.3.2.7.1.030, 1.4.2.7.4.211 | 38.25d |
| 1.4.2.7.4.232 |  | Install circuit breaker SS5 | 7.5d | 2012-07-07 | 2012-07-14 | 1.4.2.7.4.212 SS+5d, 1.3.2.7.1.030, 1.4.2.7.4.230 SS, 1.4.2.7.4.213 | 37.75d |
| 1.4.2.7.4.231 |  | Testing & commissioning of circuit breaker SS4 | 3.75d | 2012-07-14 | 2012-07-17 | 1.4.2.7.4.230 | 38.25d |
| 1.4.2.7.4.233 |  | Testing & commissioning of circuit breaker SS5 | 3.75d | 2012-07-14 | 2012-07-17 | 1.4.2.7.4.232 | 37.75d |
|  | 11 | **Annunciator Panel** |  | 2012-07-17 | 2012-07-28 |  |  |
| 1.4.2.7.4.250 |  | Install annunciator panel SS4 | 7.5d | 2012-07-17 | 2012-07-24 | 1.4.2.7.4.190, 1.3.2.7.5.030, 1.4.2.7.4.230, 1.4.2.7.4.231 | 38.25d |
| 1.4.2.7.4.252 |  | Install annunciator panel SS5 | 7.5d | 2012-07-17 | 2012-07-24 | 1.4.2.7.4.232, 1.4.2.7.4.192, 1.4.2.7.4.030, 1.4.2.7.4.233 | 37.75d |
| 1.4.2.7.4.251 |  | Testing & commissioning of annunciator panel SS4 | 3.75d | 2012-07-24 | 2012-07-28 | 1.4.2.7.4.250 | 38.25d |
| 1.4.2.7.4.253 |  | Testing & commissioning of annunciator panel SS5 | 3.75d | 2012-07-24 | 2012-07-28 | 1.4.2.7.4.252 | 37.75d |
|  | 12 | **Battery Bank & Battery Charger with UPS** |  | 2012-07-28 | 2012-08-07 |  |  |
| 1.4.2.7.4.270 |  | Install battery bank & battery charger with system SS4 | 7.5d | 2012-07-28 | 2012-08-04 | 1.4.2.7.4.250 SS+6d, 1.3.2.7.6.030, 1.4.2.7.4.251 | 38.25d |
| 1.4.2.7.4.272 |  | Install battery bank & battery charger with system SS5 | 7.5d | 2012-07-28 | 2012-08-04 | 1.4.2.7.4.252 SS+6.25d, 1.4.2.7.4.253 | 37.75d |
| 1.4.2.7.4.271 |  | Testing & commissioning of battery system SS4 | 3.75d | 2012-08-04 | 2012-08-07 | 1.4.2.7.4.270, 1.4.2.7.4.251 SS | 38.25d |
| 1.4.2.7.4.273 |  | Testing & commissioning of battery system SS5 | 3.75d | 2012-08-04 | 2012-08-07 | 1.4.2.7.4.272, 1.4.2.7.4.253 | 37.75d |
|  | 06 | **Grounding Cables** |  | 2011-12-21 | 2012-05-30 |  |  |
| 1.4.2.7.5.010 |  | Excavation of trench for grounding cables | 75d | 2011-12-21 | 2012-02-28 | 1.4.2.7.4.140 SS | 122.5d |
| 1.4.2.7.5.030 |  | Install grounding cables | 56.25d | 2012-02-12 | 2012-04-03 | 1.3.2.7.7.030, 1.4.2.7.5.010 SS+56.25d | 122.5d |
| 1.4.2.7.5.040 |  | Testing & commissioning of grounding cables | 31.25d | 2012-03-29 | 2012-04-26 | 1.4.2.7.5.030 SS+50d | 122.5d |
| 1.4.2.7.5.020 |  | Supply/backfilling/compaction of grounding cable trench | 37.5d | 2012-04-26 | 2012-05-30 | 1.4.2.7.5.040 SS+30d | 122.5d |
|  | 9 | **Communication Works & Duct Banks** |  | 2012-01-15 | 2012-09-20 |  |  |
|  | 1 | **Communication works & Ductbanks** |  | 2012-01-15 | 2012-09-20 |  |  |
| 1.4.2.8.1.010 |  | Excavation of telecomm ductbanks & trench Zone3 -A3-1 | 18.75d | 2012-01-15 | 2012-02-01 | 1.3.3.2.1.030, 1.4.2.7.1.010 SS | 88d |
| 1.4.2.8.1.040 |  | Construction of comm concrete ductbanks | 75d | 2012-01-15 | 2012-03-25 | 1.4.2.8.1.010 SS | 188d |
| 1.4.2.8.1.050 |  | Install copper cable manholes | 75d | 2012-01-15 | 2012-03-25 | 1.4.2.8.1.040 SS | 188d |
| 1.4.2.8.1.100 |  | Install red tiles /cable markers | 62.5d | 2012-01-29 | 2012-03-27 | 1.4.2.8.1.050 SS+15d | 229.25d |
| 1.4.2.8.1.011 |  | Excavation of telecomm ductbanks & trench Zone3 -A3-2 | 25d | 2012-02-01 | 2012-02-25 | 1.4.2.8.1.010 | 88d |
| 1.4.2.8.1.070 |  | Install comm subduct materials | 50d | 2012-02-13 | 2012-03-31 | 1.4.2.8.1.050 SS+31.25d | 200.5d |
| 1.4.2.8.1.020 |  | Install comm conduits & fittings-Zone 3 - A3-1 | 22.5d | 2012-02-19 | 2012-03-11 | 1.4.2.8.1.010, 1.3.3.2.3.030, 1.3.3.2.4.030 | 95.5d |
| 1.4.2.8.1.012 |  | Excavation of telecomm ductbanks & trench Zone3 -A3-3 | 25d | 2012-02-25 | 2012-03-19 | 1.4.2.8.1.011 | 88d |
| 1.4.2.8.1.021 |  | Install comm conduits & fittings-Zone 3 - A3-2 | 27.5d | 2012-02-25 | 2012-03-21 | 1.4.2.8.1.011 | 93d |
| 1.4.2.8.1.030 |  | Install comm manholes-Zone 3 - A3-1(5) | 18.75d | 2012-03-01 | 2012-03-19 | 1.4.2.8.1.020 SS+12.5d, 1.3.3.2.7.030 | 95.5d |
| 1.4.2.8.1.013 |  | Excavation of telecomm ductbanks & trench Zone3 -A3-4 | 12.5d | 2012-03-19 | 2012-03-31 | 1.4.2.8.1.012 | 126.75d |
| 1.4.2.8.1.022 |  | Install comm conduits & fittings-Zone 3 - A3-3 | 27.5d | 2012-03-19 | 2012-04-14 | 1.4.2.8.1.012 | 88d |
| 1.4.2.8.1.031 |  | Install comm manholes-Zone 3 - A3-2 (5) | 18.75d | 2012-03-21 | 2012-04-08 | 1.4.2.8.1.021 | 93d |
| 1.4.2.8.1.060 |  | Supp/backfilling/compaction of comm trench | 43.75d | 2012-03-25 | 2012-05-05 | 1.4.2.8.1.050 | 188d |
| 1.4.2.8.1.014 |  | Excavation of telecomm ductbanks & trench Zone3 -A3-5 | 12.5d | 2012-03-31 | 2012-04-11 | 1.4.2.8.1.013 | 130.5d |
| 1.4.2.8.1.023 |  | Install comm conduits & fittings-Zone 3 - A3-4 | 15d | 2012-03-31 | 2012-04-14 | 1.4.2.8.1.013 | 126.75d |
| 1.4.2.8.1.015 |  | Excavation of telecomm ductbanks & trench Zone2 | 12.5d | 2012-04-11 | 2012-04-23 | 1.4.2.8.1.014 | 130.5d |
| 1.4.2.8.1.024 |  | Install comm conduits & fittings-Zone 3 - A3-5 | 15d | 2012-04-11 | 2012-04-25 | 1.4.2.8.1.014 | 138d |
| 1.4.2.8.1.032 |  | Install comm manholes-Zone 3 - A3-3 (7) | 26.25d | 2012-04-14 | 2012-05-08 | 1.4.2.8.1.022 | 88d |
| 1.4.2.8.1.033 |  | Install comm manholes-Zone 3 - A3-4 (5) | 18.75d | 2012-04-14 | 2012-05-01 | 1.4.2.8.1.023 | 126.75d |
| 1.4.2.8.1.082 |  | Install FOC [Fiber Optic Cable] Zone3 - A3-1 | 18.75d | 2012-04-22 | 2012-05-09 | 1.4.2.8.1.030, 1.3.3.1.1.030 | 59.25d |
| 1.4.2.8.1.016 |  | Excavation of telecomm ductbanks & trench Zone4 | 7.5d | 2012-04-23 | 2012-04-30 | 1.4.2.8.1.015 | 158d |

| ID | WBS | Task | Duration | Start | Finish | Predecessors | Total float |
| --- | --- | --- | --- | --- | --- | --- | --- |
| 1.4.2.8.1.025 |  | Install comm conduits & fittings-Zone 2 | 15d | 2012-04-23 | 2012-05-07 | 1.4.2.8.1.015 | 130.5d |
| 1.4.2.8.1.034 |  | Install comm manholes-Zone 3 - A3-5 (2) | 7.5d | 2012-04-25 | 2012-05-02 | 1.4.2.8.1.024 | 138d |
| 1.4.2.8.1.026 |  | Install comm conduits & fittings-Zone 4 | 15d | 2012-04-30 | 2012-05-14 | 1.4.2.8.1.016 | 158d |
| 1.4.2.8.1.035 |  | Install comm manholes-Zone 2 (4) | 15d | 2012-05-07 | 2012-05-21 | 1.4.2.8.1.025 | 130.5d |
| 1.4.2.8.1.083 |  | Install FOC [Fiber Optic Cable] Zone3 - A3-2 | 27.5d | 2012-05-09 | 2012-06-04 | 1.4.2.8.1.031, 1.4.2.8.1.082 | 59.25d |
| 1.4.2.8.1.036 |  | Install comm manholes-Zone 4 (2) | 7.5d | 2012-05-14 | 2012-05-21 | 1.4.2.8.1.026 | 158d |
| 1.4.2.8.1.084 |  | Install FOC [Fiber Optic Cable] Zone3 - A3-3 | 31.25d | 2012-06-04 | 2012-07-03 | 1.4.2.8.1.032, 1.4.2.8.1.083 | 59.25d |
| 1.4.2.8.1.090 |  | Install comm grounding system | 37.5d | 2012-06-25 | 2012-07-30 | 1.4.2.8.1.040 SS+90d, 1.3.3.2.6.030 | 150.5d |
| 1.4.2.8.1.085 |  | Install FOC [Fiber Optic Cable] Zone3 - A3-4 | 12.5d | 2012-07-03 | 2012-07-15 | 1.4.2.8.1.033, 1.4.2.8.1.084 | 59.25d |
| 1.4.2.8.1.086 |  | Install FOC [Fiber Optic Cable] Zone3 - A3-5 | 12.5d | 2012-07-15 | 2012-07-26 | 1.4.2.8.1.034, 1.4.2.8.1.085 | 59.25d |
| 1.4.2.8.1.055 |  | Install comm copper cables closure | 37.5d | 2012-07-19 | 2012-08-23 | 1.4.2.8.1.050 SS+45d, 1.3.3.2.5.030, 1.3.3.1.3.030 | 69.25d |
| 1.4.2.8.1.080 |  | Install comm copper cables | 50d | 2012-07-19 | 2012-09-04 | 1.4.2.8.1.070 SS+25d, 1.3.3.1.4.030 | 56.75d |
| 1.4.2.8.1.087 |  | Install FOC [Fiber Optic Cable] Zone2 | 27.5d | 2012-07-26 | 2012-08-21 | 1.4.2.8.1.035, 1.4.2.8.1.086 | 59.25d |
| 1.4.2.8.1.088 |  | Install FOC [Fiber Optic Cable] Zone4 | 12.5d | 2012-08-21 | 2012-09-02 | 1.4.2.8.1.036, 1.4.2.8.1.087 | 59.25d |
| 1.4.2.8.1.110 |  | Testing/commissioning of comm system | 17.5d | 2012-09-04 | 2012-09-20 | 1.4.2.8.1.082 SS+31.25d, 1.4.2.8.1.100, 1.4.2.8.1.088, 1.4.2.8.1.080, 1.4.2.8.1.060, 1.4.2.8.1.055 | 56.75d |
|  | 3 | **BUILDING WORKS** |  | 2011-07-26 | 2012-11-20 |  |  |
|  | 1 | **Substations** |  | 2011-08-08 | 2012-08-21 |  |  |
|  | 1 | **Substation # 4** |  | 2011-08-08 | 2012-08-21 |  |  |
|  | 1 | **Civil Works** |  | 2011-08-08 | 2012-01-08 |  |  |
| 1.4.3.1.1.010 |  | Excavation leveling & cpmpactionfor SS4 fdns | 30d | 2011-08-08 | 2011-09-04 | 1.2.6.200 | 40.25d |
| 1.4.3.1.1.060 |  | backfill/compaction | 25d | 2011-12-17 | 2012-01-08 | 1.4.3.1.1.050 | 263.75d |
|  | 2 | **Structural Works** |  | 2011-08-22 | 2012-02-15 |  |  |
| 1.4.3.1.1.020 |  | Install RSB/FW/concrete fdns | 50d | 2011-08-22 | 2011-10-06 | 1.4.3.1.1.010 SS+15d | 40.25d |
| 1.4.3.1.1.030 |  | Install RSB/FW/concrete for ground beams | 50d | 2011-09-14 | 2011-10-30 | 1.4.3.1.1.020 SS+25d | 40.25d |
| 1.4.3.1.1.040 |  | Install RSB/FW/concrete for equipment fdns | 50d | 2011-10-08 | 2011-11-22 | 1.4.3.1.1.030 SS+25d | 40.25d |
| 1.4.3.1.1.050 |  | Install RSB/FW/concrete for SS4 columns | 50d | 2011-10-31 | 2011-12-15 | 1.4.3.1.1.040 SS+25d | 40.25d |
| 1.4.3.1.1.070 |  | Install RSB/FW/concrete for roof beams | 50d | 2011-11-23 | 2012-01-08 | 1.4.3.1.1.050 SS+25d | 40.25d |
| 1.4.3.1.1.080 |  | Install RSB/FW/concrete for SS4 roof slab | 50d | 2011-11-23 | 2012-01-08 | 1.4.3.1.1.070 SS | 40.25d |
| 1.4.3.1.1.090 |  | Install CMU blocks | 40d | 2012-01-10 | 2012-02-15 | 1.4.3.1.1.080 SS+50d, 1.3.1.3.030, 1.2.5.030 | 39d |
|  | 3 | **Architectural Works** |  | 2012-01-24 | 2012-04-08 |  |  |
| 1.4.3.1.1.100 |  | Install Plastering work | 40d | 2012-01-24 | 2012-02-29 | 1.4.3.1.1.090 SS+15d | 39d |
| 1.4.3.1.1.110 |  | Install floor finishing works - [Tiling] | 30d | 2012-02-07 | 2012-03-05 | 1.4.3.1.1.100 SS+15d, 1.3.1.2.030 | 39d |
| 1.4.3.1.1.120 |  | Install wall finishing works | 30d | 2012-02-21 | 2012-03-19 | 1.4.3.1.1.110 SS+15d, 1.3.1.2.030, 1.3.1.6.220 | 39d |
| 1.4.3.1.1.130 |  | Install roof water proofing system | 25d | 2012-03-01 | 2012-03-24 | 1.4.3.1.1.120 SS+10d | 39d |
| 1.4.3.1.1.125 |  | Install Ceiling finishing work | 30d | 2012-03-03 | 2012-03-29 | 1.4.3.1.1.120 SS, 1.3.1.6.240 | 206.25d |
| 1.4.3.1.1.140 |  | Install painting works | 15d | 2012-03-15 | 2012-03-28 | 1.4.3.1.1.130 SS+15d | 39d |
| 1.4.3.1.1.150 |  | Install doors & windows with frames | 12.5d | 2012-03-28 | 2012-04-08 | 1.4.3.1.1.140 SS, 1.4.3.1.1.125 SS, 1.4.3.1.1.060, 1.3.1.4.030, 1.3.1.4.060, 1.3.1.6.260, 1.3.1.6.280 | 178.75d |
|  | 4 | **Plumbing Works** |  | 2012-01-31 | 2012-03-29 |  |  |
| 1.4.3.1.1.210 |  | Install plumbing works | 60d | 2012-01-31 | 2012-03-27 | 1.4.3.1.1.100 SS, 1.3.5.2.3.030 | 38d |
| 1.4.3.1.1.220 |  | Install eye wahs & shower | 18d | 2012-03-13 | 2012-03-29 | 1.4.3.1.1.210 SS+45d | 188.75d |
|  | 5 | **Mechanical / HVAC Works** |  | 2012-01-31 | 2012-04-26 |  |  |
| 1.4.3.1.1.330 |  | Install ducting works & DDC | 45d | 2012-01-31 | 2012-03-13 | 1.4.3.1.1.210 SS | 38d |
| 1.4.3.1.1.340 |  | Install air inlet & outlet accs | 30d | 2012-02-19 | 2012-03-18 | 1.4.3.1.1.330 SS+20d | 158.75d |
| 1.4.3.1.1.350 |  | Install fire & volume dampers | 20d | 2012-02-28 | 2012-03-18 | 1.4.3.1.1.340 SS+10d | 158.75d |
| 1.4.3.1.1.360 |  | Install sandtrap louvers | 20d | 2012-03-08 | 2012-03-27 | 1.4.3.1.1.350 SS+10d | 158.75d |
| 1.4.3.1.1.370 |  | Install exhaust fan | 10d | 2012-03-18 | 2012-03-27 | 1.4.3.1.1.360 SS+10d | 158.75d |
| 1.4.3.1.1.380 |  | Install fire extinguishers | 10d | 2012-03-18 | 2012-03-27 | 1.4.3.1.1.370 SS | 191.75d |
| 1.4.3.1.1.310 |  | Install ACCU [Air cooled condencing unit] equipments | 15d | 2012-03-26 | 2012-04-08 | 1.4.3.1.1.370 SS+8d | 158.75d |
| 1.4.3.1.1.320 |  | Install AHU [Air Handling Unit] equipments with DDC panel | 15d | 2012-04-04 | 2012-04-17 | 1.4.3.1.1.310 SS+10d | 158.75d |
| 1.4.3.1.1.390 |  | Testing & balancing of HVAC system | 15d | 2012-04-14 | 2012-04-26 | 1.4.3.1.1.320 SS+10d | 158.75d |
|  | 6 | **Electrical Works** |  | 2012-01-31 | 2012-08-21 |  |  |
| 1.4.3.1.1.410 |  | Install electrical conduits & fittings | 45d | 2012-01-31 | 2012-03-13 | 1.4.3.1.1.330 SS | 38d |
| 1.4.3.1.1.480 |  | Install cables trays | 60d | 2012-02-05 | 2012-04-01 | 1.4.3.1.1.410 SS+5d | 38d |
| 1.4.3.1.1.420 |  | Install cables & wires | 37.5d | 2012-02-19 | 2012-03-25 | 1.4.3.1.1.480 SS+15d | 38d |
| 1.4.3.1.1.430 |  | Install lighting fixtures | 37.5d | 2012-03-13 | 2012-04-17 | 1.4.3.1.1.420 SS+25d | 38d |
| 1.4.3.1.1.500 |  | Install grounding system | 25d | 2012-03-20 | 2012-04-12 | 1.4.3.1.1.480 SS+47.5d | 43d |
| 1.4.3.1.1.440 |  | Install Switchgear | 7.5d | 2012-04-17 | 2012-04-24 | 1.4.3.1.1.430, 1.4.3.1.1.500 | 38d |
| 1.4.3.1.1.450 |  | Install Package substation | 7.5d | 2012-04-28 | 2012-05-05 | 1.4.3.1.1.440 FS+3.75d | 38d |
| 1.4.3.1.1.460 |  | Install RMU | 18.75d | 2012-05-08 | 2012-05-26 | 1.4.3.1.1.450 FS+3.75d | 38d |
| 1.4.3.1.1.470 |  | Install Transformer | 12.5d | 2012-05-31 | 2012-06-12 | 1.4.3.1.1.460 FS+6.25d | 38d |
| 1.4.3.1.1.490 |  | Install FAS-Fire Alarm system & FACP | 18.75d | 2012-06-12 | 2012-06-30 | 1.4.3.1.1.470, 1.3.2.7.9.030 | 38d |
| 1.4.3.1.1.510 |  | Install switchboard | 7.5d | 2012-06-16 | 2012-06-23 | 1.4.3.1.1.470 FS+3.75d, 1.4.3.1.1.490 SS+3.75d | 38d |
| 1.4.3.1.1.520 |  | Install main distribution panel board | 7.5d | 2012-06-26 | 2012-07-03 | 1.4.3.1.1.510 FS+3.75d, 1.3.2.1.060 | 38d |
| 1.4.3.1.1.530 |  | Install circuit breaker | 7.5d | 2012-07-07 | 2012-07-14 | 1.4.3.1.1.520 FS+3.75d | 38d |
| 1.4.3.1.1.540 |  | Install annunciator panel | 7.5d | 2012-07-17 | 2012-07-24 | 1.4.3.1.1.530 FS+3.75d | 38d |
| 1.4.3.1.1.550 |  | Install batterybank | 7.5d | 2012-07-28 | 2012-08-04 | 1.4.3.1.1.540 FS+3.75d | 38d |
| 1.4.3.1.1.560 |  | Testing /commissioning of electrical system | 15d | 2012-08-04 | 2012-08-18 | 1.4.3.1.1.550, 1.4.2.7.4.271 SS, 1.2.8.020, 1.4.3.1.1.510 | 38d |
| 1.4.3.1.1.570 |  | Energize Substation 4 | 3.75d | 2012-08-18 | 2012-08-21 | 1.4.3.1.1.560, 1.4.3.1.1.380, 1.4.3.1.1.390, 1.4.3.1.1.220, 1.4.3.1.1.150, 1.4.3.1.1.640, 1.4.4.2.010, 1.4.3.1.1.510, 1.4.2.7.5.020 | 38d |
|  | 7 | **Communication Works** |  | 2012-02-09 | 2012-07-19 |  |  |
| 1.4.3.1.1.610 |  | Install comm conduits & fittings | 45d | 2012-02-09 | 2012-03-22 | 1.4.3.1.1.410 SS+10d | 181.75d |

| ID | WBS | Task | Duration | Start | Finish | Predecessors | Total float |
| --- | --- | --- | --- | --- | --- | --- | --- |
| 1.4.3.1.1.620 |  | Install comm cabinet & accs & Data interworks | 15d | 2012-03-08 | 2012-03-22 | 1.4.3.1.1.610 SS+30d | 181.75d |
| 1.4.3.1.1.630 |  | Install comm equipments & accs | 15d | 2012-07-01 | 2012-07-15 | 1.4.3.1.1.620 SS+10d, 1.3.3.1.2.030 | 69.25d |
| 1.4.3.1.1.640 |  | Install comm outlet & accs | 10d | 2012-07-10 | 2012-07-19 | 1.4.3.1.1.630 SS+10d | 69.25d |
|  | 8 | **Pavement / Parking / Signs / Markings** |  | 2012-01-24 | 2012-04-02 |  |  |
| 1.4.3.1.1.710 |  | Install gravel pavement | 40d | 2012-01-24 | 2012-02-29 | 1.4.3.1.1.100 SS | 277.5d |
| 1.4.3.1.1.720 |  | Install 150mm thick concrete pavement | 30d | 2012-02-02 | 2012-02-29 | 1.4.3.1.1.710 SS+10d | 277.5d |
| 1.4.3.1.1.730 |  | Install 500mm thick general fill | 30d | 2012-02-12 | 2012-03-10 | 1.4.3.1.1.720 SS+10d | 277.5d |
| 1.4.3.1.1.740 |  | Install 200mm thk aggregate base coarse | 30d | 2012-02-21 | 2012-03-19 | 1.4.3.1.1.730 SS+10d | 277.5d |
| 1.4.3.1.1.750 |  | Install 120mm thk asphalt cncrt pavement | 20d | 2012-03-01 | 2012-03-19 | 1.4.3.1.1.740 SS+10d | 277.5d |
| 1.4.3.1.1.760 |  | Install shaded parking space | 18d | 2012-03-11 | 2012-03-27 | 1.4.3.1.1.750 SS+10d | 277.5d |
| 1.4.3.1.1.770 |  | Install road / park markings | 10d | 2012-03-20 | 2012-03-28 | 1.4.3.1.1.760 SS+10d | 277.5d |
| 1.4.3.1.1.780 |  | Install road / parking signs | 10d | 2012-03-25 | 2012-04-02 | 1.4.3.1.1.770 SS+5d | 277.5d |
|  | 9 | **Perimeter Fence System** |  | 2012-03-01 | 2012-03-31 |  |  |
| 1.4.3.1.1.810 |  | Install perimeter fence type SSD-1 | 30d | 2012-03-01 | 2012-03-28 | 1.4.3.1.1.710 | 373d |
| 1.4.3.1.1.820 |  | Install perimeter gate SSD-1 10.5m wide 2 leaf | 10d | 2012-03-21 | 2012-03-31 | 1.4.3.1.1.810 SS+22d | 373d |
|  | 10 | **Substation # 5** |  | 2011-08-08 | 2012-08-21 |  |  |
|  | 1 | **Civil Works** |  | 2011-08-08 | 2012-01-08 |  |  |
| 1.4.3.1.2.010 |  | Excavation leveling & compactionfor SS5 fdns | 30d | 2011-08-08 | 2011-09-04 | 1.4.3.1.1.010 SS, 1.2.6.200 | 60d |
| 1.4.3.1.2.060 |  | backfill/compaction | 25d | 2011-12-17 | 2012-01-08 | 1.4.3.1.2.050 | 261.25d |
|  | 2 | **Structural Works** |  | 2011-08-22 | 2012-02-09 |  |  |
| 1.4.3.1.2.020 |  | Install RSB/FW/concrete fdns | 50d | 2011-08-22 | 2011-10-06 | 1.4.3.1.2.010 SS+15d | 60d |
| 1.4.3.1.2.030 |  | Install RSB/FW/concrete for ground beams | 50d | 2011-09-14 | 2011-10-30 | 1.4.3.1.2.020 SS+25d | 60d |
| 1.4.3.1.2.040 |  | Install RSB/FW/concrete for equipment fdns | 50d | 2011-10-08 | 2011-11-22 | 1.4.3.1.2.030 SS+25d | 60d |
| 1.4.3.1.2.050 |  | Install RSB/FW/concrete for SS5 columns | 50d | 2011-10-31 | 2011-12-15 | 1.4.3.1.2.040 SS+25d | 60d |
| 1.4.3.1.2.070 |  | Install RSB/FW/concrete for roof beams | 50d | 2011-10-31 | 2011-12-15 | 1.4.3.1.2.050 SS | 60d |
| 1.4.3.1.2.080 |  | Install RSB/FW/concrete for SS5 roof slab | 50d | 2011-11-23 | 2012-01-08 | 1.4.3.1.2.070 SS+25d | 60d |
| 1.4.3.1.2.090 |  | Install CMU blocks | 40d | 2012-01-04 | 2012-02-09 | 1.4.3.1.2.080 SS+45d | 60d |
|  | 3 | **Architectural Works** |  | 2012-01-18 | 2012-03-18 |  |  |
| 1.4.3.1.2.100 |  | Install Plastering work | 40d | 2012-01-18 | 2012-02-23 | 1.4.3.1.2.090 SS+15d | 60d |
| 1.4.3.1.2.110 |  | Install finishing finishing works - [Tiling] | 30d | 2012-02-01 | 2012-02-28 | 1.4.3.1.2.100 SS+15d | 201.25d |
| 1.4.3.1.2.120 |  | Install wall finishing works | 30d | 2012-02-11 | 2012-03-08 | 1.4.3.1.2.110 SS+10d | 201.25d |
| 1.4.3.1.2.125 |  | Install ceiling finishing works | 30d | 2012-02-11 | 2012-03-08 | 1.4.3.1.2.120 SS | 226.25d |
| 1.4.3.1.2.130 |  | Install roof water proofing system | 22.5d | 2012-02-20 | 2012-03-11 | 1.4.3.1.2.120 SS+10d | 201.25d |
| 1.4.3.1.2.140 |  | Install painting works | 15d | 2012-02-29 | 2012-03-13 | 1.4.3.1.2.130 SS+10d | 201.25d |
| 1.4.3.1.2.150 |  | Install doors & windows with frames | 15d | 2012-03-05 | 2012-03-18 | 1.4.3.1.2.140 SS+5d, 1.4.3.1.2.125 SS, 1.4.3.1.2.060 | 201.25d |
|  | 4 | **Plumbing Works** |  | 2012-01-31 | 2012-03-22 |  |  |
| 1.4.3.1.2.210 |  | Install plumbing works | 37.5d | 2012-01-31 | 2012-03-06 | 1.4.3.1.2.100 SS, 1.3.5.2.3.030 | 45.5d |
| 1.4.3.1.2.220 |  | Install eye wash & shower | 30d | 2012-02-23 | 2012-03-22 | 1.4.3.1.2.210 SS+25d | 196.75d |
|  | 5 | **Mechanical / HVAC Works** |  | 2012-01-31 | 2012-05-06 |  |  |
| 1.4.3.1.2.330 |  | Install ducting works | 45d | 2012-01-31 | 2012-03-13 | 1.4.3.1.2.210 SS | 45.5d |
| 1.4.3.1.2.340 |  | Install air inlet & outlet accs | 20d | 2012-02-23 | 2012-03-13 | 1.4.3.1.2.330 SS+25d | 148.75d |
| 1.4.3.1.2.350 |  | Install fire & volume dampers | 20d | 2012-03-04 | 2012-03-22 | 1.4.3.1.2.340 SS+10d | 148.75d |
| 1.4.3.1.2.360 |  | Install sandtrap louvers | 17.5d | 2012-03-13 | 2012-03-29 | 1.4.3.1.2.350 SS+10d | 148.75d |
| 1.4.3.1.2.370 |  | Install exhaust fan | 10d | 2012-03-22 | 2012-04-01 | 1.4.3.1.2.360 SS+10d | 148.75d |
| 1.4.3.1.2.380 |  | Install fire extinguishers | 15d | 2012-03-22 | 2012-04-05 | 1.4.3.1.2.370 SS | 181.75d |
| 1.4.3.1.2.310 |  | Install ACCU equipments | 15d | 2012-03-31 | 2012-04-12 | 1.4.3.1.2.370 SS+8d | 148.75d |
| 1.4.3.1.2.320 |  | Install AHU equipments with DDC Panel | 15d | 2012-04-14 | 2012-04-26 | 1.4.3.1.2.310 SS+15d | 148.75d |
| 1.4.3.1.2.390 |  | Testing & balancing of HVAC system | 15d | 2012-04-23 | 2012-05-06 | 1.4.3.1.2.320 SS+10d | 148.75d |
|  | 6 | **Electrical Works** |  | 2012-01-31 | 2012-08-21 |  |  |
| 1.4.3.1.2.410 |  | Install electrical conduits & fititings | 45d | 2012-01-31 | 2012-03-13 | 1.4.3.1.2.330 SS | 45.5d |
| 1.4.3.1.2.480 |  | Install cables trays | 60d | 2012-02-05 | 2012-04-01 | 1.4.3.1.2.410 SS+5d | 45.5d |
| 1.4.3.1.2.420 |  | Install cables & wires | 37.5d | 2012-02-19 | 2012-03-25 | 1.4.3.1.2.480 SS+15d | 45.5d |
| 1.4.3.1.2.430 |  | Install lighting fixtures | 37.5d | 2012-03-13 | 2012-04-17 | 1.4.3.1.2.420 SS+25d | 45.5d |
| 1.4.3.1.2.500 |  | Install grounding system | 25d | 2012-03-20 | 2012-04-12 | 1.4.3.1.2.480 SS+47.5d | 69.5d |
| 1.4.3.1.2.440 |  | Install switchgear | 7.5d | 2012-04-17 | 2012-04-24 | 1.4.3.1.2.430, 1.4.3.1.2.500 SS+6d | 45.5d |
| 1.4.3.1.2.450 |  | Install package substation | 7.5d | 2012-04-28 | 2012-05-05 | 1.4.3.1.2.440 FS+3.75d | 45.5d |
| 1.4.3.1.2.460 |  | Install RMU | 18.75d | 2012-05-08 | 2012-05-26 | 1.4.3.1.2.450 FS+3.75d | 45.5d |
| 1.4.3.1.2.470 |  | Install Transformer | 12.5d | 2012-05-31 | 2012-06-12 | 1.4.3.1.2.460 FS+6.25d | 45.5d |
| 1.4.3.1.2.490 |  | Install FAS-Fire Alarm System & FACP | 18.75d | 2012-06-12 | 2012-06-30 | 1.4.3.1.2.470 | 45.5d |
| 1.4.3.1.2.510 |  | Install switchboard | 7.5d | 2012-06-16 | 2012-06-23 | 1.4.3.1.2.470 FS+3.75d, 1.4.3.1.2.490 SS+3.75d | 45.5d |
| 1.4.3.1.2.520 |  | Install Main distribution panel board | 7.5d | 2012-06-26 | 2012-07-03 | 1.4.3.1.2.510 FS+3.75d | 45.5d |
| 1.4.3.1.2.530 |  | Install circuit breaker | 7.5d | 2012-07-07 | 2012-07-14 | 1.4.3.1.2.520 FS+3.75d | 45.5d |
| 1.4.3.1.2.540 |  | Install annunciator panel | 7.5d | 2012-07-17 | 2012-07-24 | 1.4.3.1.2.530 FS+3.75d | 45.5d |
| 1.4.3.1.2.550 |  | Install batterybank | 7.5d | 2012-07-28 | 2012-08-04 | 1.4.3.1.2.540 FS+3.75d | 45.5d |
| 1.4.3.1.2.560 |  | Testing /commissioning of electrical system | 15d | 2012-08-04 | 2012-08-18 | 1.4.3.1.2.550 SS, 1.4.2.7.4.273 SS, 1.4.3.1.2.540 SS | 37.75d |
| 1.4.3.1.2.570 |  | Energize Substation 5 | 3.75d | 2012-08-18 | 2012-08-21 | 1.4.3.1.2.560, 1.4.3.1.2.380, 1.4.3.1.2.390, 1.4.3.1.2.640, 1.4.3.1.2.780, 1.4.3.1.2.150, 1.4.3.1.2.220 | 37.75d |
|  | 7 | **Communication Works** |  | 2012-01-31 | 2012-04-15 |  |  |
| 1.4.3.1.2.610 |  | Install comm conduits & fittings | 50d | 2012-01-31 | 2012-03-18 | 1.4.3.1.2.410 SS | 171.75d |
| 1.4.3.1.2.620 |  | Install comm cabinet & accs & data interworks | 20d | 2012-03-08 | 2012-03-27 | 1.4.3.1.2.610 SS+40d | 171.75d |
| 1.4.3.1.2.630 |  | Install comm equipments & accs | 20d | 2012-03-22 | 2012-04-10 | 1.4.3.1.2.620 SS+15d | 171.75d |

| ID | WBS | Task | Duration | Start | Finish | Predecessors | Total float |
| --- | --- | --- | --- | --- | --- | --- | --- |
| 1.4.3.1.2.640 |  | Install comm outlet & accs | 10d | 2012-04-05 | 2012-04-15 | 1.4.3.1.2.630 SS+15d, 1.4.3.1.2.820 | 171.75d |
|  | 8 | **Pavement / Parking / Signs / Markings** |  | 2012-01-18 | 2012-03-22 |  |  |
| 1.4.3.1.2.710 |  | Install gravel pavement | 40d | 2012-01-18 | 2012-02-23 | 1.4.3.1.2.100 SS | 181.25d |
| 1.4.3.1.2.720 |  | Install 150mm thick concrete pavement | 30d | 2012-01-28 | 2012-02-23 | 1.4.3.1.2.710 SS+10d | 197.25d |
| 1.4.3.1.2.730 |  | Install 500mm thick general fill | 30d | 2012-02-06 | 2012-03-04 | 1.4.3.1.2.720 SS+10d | 197.25d |
| 1.4.3.1.2.740 |  | Install 200mm thk aggregate base coarse | 25d | 2012-02-15 | 2012-03-08 | 1.4.3.1.2.730 SS+10d | 197.25d |
| 1.4.3.1.2.750 |  | Install 120mm thk asphalt cncrt pavement | 20d | 2012-02-25 | 2012-03-13 | 1.4.3.1.2.740 SS+10d | 197.25d |
| 1.4.3.1.2.760 |  | Install shaded parking space | 18.75d | 2012-02-29 | 2012-03-17 | 1.4.3.1.2.750 SS+5d | 197.25d |
| 1.4.3.1.2.770 |  | Install road / park markings | 15d | 2012-03-05 | 2012-03-19 | 1.4.3.1.2.760 SS+6d | 197.25d |
| 1.4.3.1.2.780 |  | Install road / parking signs | 15d | 2012-03-08 | 2012-03-22 | 1.4.3.1.2.770 SS+3d | 197.25d |
|  | 9 | **Perimeter Fence System** |  | 2012-02-11 | 2012-03-27 |  |  |
| 1.4.3.1.2.810 |  | Install perimeter fence type SSD-1 | 45d | 2012-02-11 | 2012-03-22 | 1.4.3.1.2.710 SS+25d | 181.25d |
| 1.4.3.1.2.820 |  | Install periemter gate SSD-1 10.5m wide 2 leaf | 20d | 2012-03-10 | 2012-03-27 | 1.4.3.1.2.810 SS+30d | 181.25d |
|  | 2 | **Exchange Building** |  | 2011-07-26 | 2012-10-04 |  |  |
|  | 1 | **Exchange Building # 1** |  | 2011-07-26 | 2012-10-04 |  |  |
|  | 1 | **Civil Works** |  | 2011-07-26 | 2012-01-02 |  |  |
| 1.4.3.2.1.010 |  | Site clearing / grubbing | 15d | 2011-07-26 | 2011-08-08 | 1.2.6.200 SS+18.75d | 51.5d |
| 1.4.3.2.1.020 |  | Excavation leveling & compactionfor exchange bldg 1 fdns | 15d | 2011-07-31 | 2011-08-14 | 1.4.3.2.1.010 SS+6d | 51.5d |
| 1.4.3.2.1.030 |  | Backfill/compaction of exchange bldg fdns | 18.75d | 2011-12-15 | 2012-01-02 | 1.4.3.2.1.150 | 229.25d |
|  | 2 | **Structural Works** |  | 2011-08-14 | 2012-05-02 |  |  |
| 1.4.3.2.1.110 |  | Install RSB/FW/concrete for fdns | 37.5d | 2011-08-14 | 2011-09-18 | 1.4.3.2.1.020 | 51.5d |
| 1.4.3.2.1.120 |  | Install RSB/FW/concrete for ground beams | 60d | 2011-08-14 | 2011-10-09 | 1.4.3.2.1.110 SS | 51.5d |
| 1.4.3.2.1.130 |  | Install RSB/FW/concrete for equipment fdns | 60d | 2011-09-11 | 2011-11-06 | 1.4.3.2.1.120 SS+30d | 51.5d |
| 1.4.3.2.1.140 |  | Install RSB/FW/concrete for columns | 60d | 2011-10-09 | 2011-12-04 | 1.4.3.2.1.130 SS+30d | 51.5d |
| 1.4.3.2.1.230 |  | Install embedded structural steel, anchor bolts,plates,angles | 120d | 2011-10-09 | 2012-01-29 | 1.4.3.2.1.130 SS+30d | 167d |
| 1.4.3.2.1.150 |  | Install RSB/FW/concrete for side walls | 60d | 2011-10-20 | 2011-12-15 | 1.4.3.2.1.140 SS+12.5d | 51.5d |
| 1.4.3.2.1.155 |  | Install structural steel structures | 60d | 2011-10-20 | 2011-12-15 | 1.4.3.2.1.150 SS | 81.5d |
| 1.4.3.2.1.160 |  | Install RSB/FW/cncrt for suspended slab | 60d | 2011-11-17 | 2012-01-12 | 1.4.3.2.1.150 SS+30d, 1.4.3.2.1.155 SS | 51.5d |
| 1.4.3.2.1.170 |  | Install RSB/FW/cncrt for cable vault, SOG | 60d | 2011-12-05 | 2012-01-30 | 1.4.3.2.1.160 SS+18.75d | 51.5d |
| 1.4.3.2.1.180 |  | Install RSB/FW/cncrt for grade slab | 45d | 2012-01-02 | 2012-02-13 | 1.4.3.2.1.170 SS+30d | 150.75d |
| 1.4.3.2.1.190 |  | Install 150mm thk prefabricated wall panel | 30d | 2012-01-30 | 2012-02-27 | 1.4.3.2.1.170 | 51.5d |
| 1.4.3.2.1.200 |  | Install 250mm thk prefabricated wall panel | 30d | 2012-02-22 | 2012-03-21 | 1.4.3.2.1.190 SS+25d | 95.75d |
| 1.4.3.2.1.210 |  | Install 250mm thk prefabricated wall panel, 150mm thkx650mm | 30d | 2012-03-17 | 2012-04-14 | 1.4.3.2.1.200 SS+25d | 95.75d |
| 1.4.3.2.1.220 |  | Install expanded wire mesh on frame as per SSD/20 | 30d | 2012-04-04 | 2012-05-02 | 1.4.3.2.1.210 SS+20d, 1.4.3.2.1.230 | 95.75d |
|  | 3 | **Architectural Works** |  | 2012-01-30 | 2012-08-14 |  |  |
|  | 1 | **Masonry work** |  | 2012-01-30 | 2012-04-02 |  |  |
| 1.4.3.2.1.310 |  | Install 200mm thk CMU blocks | 37.5d | 2012-01-30 | 2012-03-05 | 1.4.3.2.1.190 SS | 51.5d |
| 1.4.3.2.1.320 |  | Install 50mm thk morter plastering work | 37.5d | 2012-02-27 | 2012-04-02 | 1.4.3.2.1.310 SS+30d | 169.25d |
|  | 2 | **Floor Finishing work** |  | 2012-05-02 | 2012-06-19 |  |  |
| 1.4.3.2.1.330 |  | Install ceramic tiling works | 20d | 2012-05-02 | 2012-05-20 | 1.4.3.2.1.380 SS | 66.75d |
| 1.4.3.2.1.340 |  | Install cement toping works | 20d | 2012-05-12 | 2012-05-29 | 1.4.3.2.1.330 SS+10d | 66.75d |
| 1.4.3.2.1.350 |  | Install vinyl tiling works | 20d | 2012-05-21 | 2012-06-07 | 1.4.3.2.1.340 SS+10d | 66.75d |
| 1.4.3.2.1.360 |  | Install APCS-12 painting works | 20d | 2012-05-30 | 2012-06-17 | 1.4.3.2.1.350 SS+10d | 66.75d |
| 1.4.3.2.1.370 |  | Install accs floor system | 12d | 2012-06-09 | 2012-06-19 | 1.4.3.2.1.360 SS+10d | 66.75d |
|  | 3 | **Wall Finishing work** |  | 2012-05-02 | 2012-06-12 |  |  |
| 1.4.3.2.1.380 |  | Install dry wall partition works | 25d | 2012-05-02 | 2012-05-24 | 1.4.3.2.1.180, 1.4.3.2.1.220 SS, 1.3.1.5.430, 1.3.1.5.330 | 66.75d |
| 1.4.3.2.1.390 |  | Install ceramic wall tiling works | 25d | 2012-05-12 | 2012-06-03 | 1.4.3.2.1.380 SS+10d | 98.75d |
| 1.4.3.2.1.400 |  | Install wall painting works | 25d | 2012-05-21 | 2012-06-12 | 1.4.3.2.1.390 SS+10d | 98.75d |
|  | 4 | **Ceiling Finishing work** |  | 2012-06-19 | 2012-07-31 |  |  |
| 1.4.3.2.1.410 |  | Install acoustical celing works | 25d | 2012-06-19 | 2012-07-12 | 1.4.3.2.1.400 SS, 1.4.3.2.1.370, 1.3.1.5.230 | 66.75d |
| 1.4.3.2.1.420 |  | Install gypsum board celing works | 25d | 2012-06-28 | 2012-07-22 | 1.4.3.2.1.410 SS+10d | 81.75d |
| 1.4.3.2.1.430 |  | Install ceiling painting works | 25d | 2012-07-08 | 2012-07-31 | 1.4.3.2.1.420 SS+10d, 1.4.3.2.1.400 | 81.75d |
|  | 5 | **Roof Finishing work** |  | 2012-07-03 | 2012-08-09 |  |  |
| 1.4.3.2.1.440 |  | Install roof water proofing system | 25d | 2012-07-03 | 2012-07-26 | 1.4.3.2.1.410 SS+15d | 66.75d |
| 1.4.3.2.1.450 |  | Install roof painting works | 20d | 2012-07-22 | 2012-08-09 | 1.4.3.2.1.440 SS+20d | 66.75d |
|  | 6 | **Doors & Windows** |  | 2012-07-22 | 2012-08-14 |  |  |
| 1.4.3.2.1.460 |  | Install doors & windows with frames | 25d | 2012-07-22 | 2012-08-14 | 1.4.3.2.1.450 SS, 1.4.3.2.1.430 SS, 1.4.3.2.1.030 | 66.75d |
|  | 4 | **Plumbing Works** |  | 2012-04-14 | 2012-06-09 |  |  |
| 1.4.3.2.1.510 |  | Install plumbing conduits & fittings | 35d | 2012-04-14 | 2012-05-16 | 1.4.3.2.1.210 | 144d |
| 1.4.3.2.1.520 |  | Install plumbing fixtures | 30d | 2012-05-02 | 2012-05-30 | 1.4.3.2.1.510 SS+20d | 144d |
| 1.4.3.2.1.530 |  | Install countertop w/built in lavatory | 20d | 2012-05-21 | 2012-06-09 | 1.4.3.2.1.520 SS+20d | 144d |
|  | 5 | **Mechanical / HVAC Works** |  | 2012-04-23 | 2012-08-28 |  |  |
| 1.4.3.2.1.630 |  | Install ducting system | 45d | 2012-04-23 | 2012-06-03 | 1.4.3.2.1.310, 1.3.5.4.9.030, 1.3.5.4.10.030, 1.3.5.4.7.030 | 77.25d |
| 1.4.3.2.1.640 |  | Install air & outlets accs | 25d | 2012-05-21 | 2012-06-12 | 1.4.3.2.1.630 SS+30d | 77.25d |
| 1.4.3.2.1.650 |  | Install fire / volume dampers | 25d | 2012-05-30 | 2012-06-21 | 1.4.3.2.1.640 SS+10d | 77.25d |
| 1.4.3.2.1.660 |  | Install sandtrap louvers | 15d | 2012-06-10 | 2012-06-24 | 1.4.3.2.1.650 SS+12d | 77.25d |
| 1.4.3.2.1.670 |  | Install exhaust fan | 10d | 2012-06-19 | 2012-06-28 | 1.4.3.2.1.660 SS+10d, 1.3.5.4.10.060 | 77.25d |
| 1.4.3.2.1.680 |  | Install fire protection system | 10d | 2012-06-25 | 2012-07-04 | 1.4.3.2.1.670 SS+6d | 77.25d |
| 1.4.3.2.1.610 |  | Install ACCU equipments | 25d | 2012-07-01 | 2012-07-24 | 1.4.3.2.1.680 SS+6d | 77.25d |
| 1.4.3.2.1.685 |  | Install fire extinguishers | 10d | 2012-07-02 | 2012-07-11 | 1.4.3.2.1.680 SS+8d | 109d |

| ID | WBS | Task | Duration | Start | Finish | Predecessors | Total float |
| --- | --- | --- | --- | --- | --- | --- | --- |
| 1.4.3.2.1.620 |  | Install AHU equipments | 25d | 2012-07-18 | 2012-08-11 | 1.4.3.2.1.610 SS+18.75d | 77.25d |
| 1.4.3.2.1.690 |  | Testing & balancing of HVAC system | 18.75d | 2012-08-11 | 2012-08-28 | 1.4.3.2.1.620, 1.4.3.2.1.685 SS+10d, 1.4.3.2.1.530 | 77.25d |
|  | 6 | **Electrical Works** |  | 2012-03-17 | 2012-07-26 |  |  |
| 1.4.3.2.1.710 |  | Install electrical conduits / fittings | 30d | 2012-03-17 | 2012-04-14 | 1.4.3.2.1.310 FS+12.5d, 1.3.3.2.2.030 | 51.5d |
| 1.4.3.2.1.720 |  | Install cables / wires | 25d | 2012-03-26 | 2012-04-18 | 1.4.3.2.1.710 SS+10d | 121.75d |
| 1.4.3.2.1.730 |  | Install lighting fixtures | 25d | 2012-04-09 | 2012-05-02 | 1.4.3.2.1.720 SS+15d | 121.75d |
| 1.4.3.2.1.740 |  | Install panelboards | 10d | 2012-04-23 | 2012-05-02 | 1.4.3.2.1.730 SS+15d | 121.75d |
| 1.4.3.2.1.750 |  | Install lighting control panel | 10d | 2012-04-28 | 2012-05-07 | 1.4.3.2.1.740 SS+5d | 121.75d |
| 1.4.3.2.1.760 |  | Install annunciator DC distribution panel | 15d | 2012-05-02 | 2012-05-16 | 1.4.3.2.1.750 SS+5d | 121.75d |
| 1.4.3.2.1.770 |  | Install battery bank / battery charger/UPS | 15d | 2012-05-07 | 2012-05-21 | 1.4.3.2.1.760 SS+5d, 1.3.2.7.6.130 | 121.75d |
| 1.4.3.2.1.780 |  | Install inventor | 10d | 2012-05-12 | 2012-05-21 | 1.4.3.2.1.770 SS+5d | 121.75d |
| 1.4.3.2.1.790 |  | Install inventor distribution panel | 10d | 2012-05-16 | 2012-05-26 | 1.4.3.2.1.780 SS+5d | 121.75d |
| 1.4.3.2.1.800 |  | Install disconnect switches | 15d | 2012-05-21 | 2012-06-04 | 1.4.3.2.1.790 SS+5d | 121.75d |
| 1.4.3.2.1.810 |  | Install FAS-Fire alarm system & FACP with detection sytem | 15d | 2012-05-26 | 2012-06-09 | 1.4.3.2.1.800 SS+5d | 121.75d |
| 1.4.3.2.1.820 |  | Install grounding system | 15d | 2012-05-30 | 2012-06-13 | 1.4.3.2.1.810 SS+5d | 121.75d |
| 1.4.3.2.1.830 |  | Install circuit breaker | 15d | 2012-06-04 | 2012-06-18 | 1.4.3.2.1.820 SS+5d | 121.75d |
| 1.4.3.2.1.840 |  | Install ATS | 15d | 2012-06-09 | 2012-06-23 | 1.4.3.2.1.830 SS+5d | 121.75d |
| 1.4.3.2.1.850 |  | Install rectifier | 15d | 2012-06-13 | 2012-06-27 | 1.4.3.2.1.840 SS+5d | 121.75d |
| 1.4.3.2.1.860 |  | Install 500kva generator | 15d | 2012-06-18 | 2012-07-02 | 1.4.3.2.1.850 SS+5d | 121.75d |
| 1.4.3.2.1.870 |  | Install 300kva, 13.8kv XFR | 15d | 2012-06-23 | 2012-07-07 | 1.4.3.2.1.860 SS+5d | 121.75d |
| 1.4.3.2.1.880 |  | Install switchboards | 15d | 2012-06-27 | 2012-07-11 | 1.4.3.2.1.870 SS+5d | 121.75d |
| 1.4.3.2.1.890 |  | Testing/commissioning electrical system | 25d | 2012-07-03 | 2012-07-26 | 1.4.3.2.1.880 SS+6d | 121.75d |
|  | 7 | **Communication Works at Exch Bldg #1** |  | 2012-04-14 | 2012-06-27 |  |  |
| 1.4.3.2.1.910 |  | Install comm conduits / fittings | 45d | 2012-04-14 | 2012-05-26 | 1.4.3.2.1.710, 1.3.3.2.1.130 | 51.5d |
| 1.4.3.2.1.920 |  | Install comm vault / accs | 25d | 2012-05-12 | 2012-06-04 | 1.4.3.2.1.910 SS+30d | 51.5d |
| 1.4.3.2.1.930 |  | Install comm equipments / accs | 25d | 2012-05-26 | 2012-06-18 | 1.4.3.2.1.920 SS+15d, 1.3.3.2.2.130 | 51.5d |
| 1.4.3.2.1.940 |  | Install comm outlets / accs | 25d | 2012-06-04 | 2012-06-27 | 1.4.3.2.1.930 SS+10d | 51.5d |
|  | 8 | **Communication Works at Exch Bldg #1 with existing network** |  | 2012-06-27 | 2012-09-05 |  |  |
| 1.4.3.2.1.1010 |  | Install comm equip to connect with existing exch bldg | 75d | 2012-06-27 | 2012-09-05 | 1.4.3.2.1.940, 1.3.3.3.030 | 51.5d |
|  | 9 | **Communication Works at Exch Bldg #1 with security HQ bldg** |  | 2012-07-09 | 2012-09-20 |  |  |
| 1.4.3.2.1.1110 |  | Install comm equip to connect with security HQ | 78.75d | 2012-07-09 | 2012-09-20 | 1.4.3.2.1.1010 SS+12.5d | 51.5d |
|  | 10 | **Communication Works at Exch Bldg #1 with exst bsns data center** |  | 2012-08-14 | 2012-09-06 |  |  |
| 1.4.3.2.1.1210 |  | Install comm equip to connect with exst business center | 25d | 2012-08-14 | 2012-09-06 | 1.4.3.2.1.1110 SS+10d, 1.4.3.2.1.460 | 66.75d |
|  | 11 | **SACS System** |  | 2012-08-14 | 2012-10-04 |  |  |
| 1.4.3.2.1.1310 |  | Install access switches | 45d | 2012-08-14 | 2012-09-25 | 1.4.3.2.1.1010 SS, 1.3.3.3.130 | 69d |
| 1.4.3.2.1.1320 |  | Install miscellaneous items | 45d | 2012-08-23 | 2012-10-04 | 1.4.3.2.1.1310 SS+10d, 1.4.3.2.1.1480, 1.4.3.2.1.1520 | 69d |
| 1.4.3.2.1.1330 |  | Testing / commissioning & Energize SACS system | 10d | 2012-09-20 | 2012-09-30 | 1.4.3.2.1.1320 SS+12.5d, 1.4.2.8.1.110 SS+12.5d, 1.4.3.2.1.1010, 1.4.3.2.1.1110 | 51.5d |
| 1.4.3.2.1.1340 |  | Energize SACS System & Communication Bldg | 10d | 2012-09-20 | 2012-09-30 | 1.4.3.2.1.1330 SS, 1.4.3.2.1.1010, 1.4.3.2.1.1110, 1.4.3.2.1.1210, 1.4.3.2.1.690, 1.4.3.1.1.570, M2.10 | 51.5d |
|  | 12 | **Pavement / Parking / Signs / Markings** |  | 2012-02-27 | 2012-04-30 |  |  |
| 1.4.3.2.1.1410 |  | Install gravel pavement | 30d | 2012-02-27 | 2012-03-26 | 1.4.3.2.1.320 SS, 1.4.3.2.1.030 | 169.25d |
| 1.4.3.2.1.1420 |  | Install 150mm thk concrete pavement | 30d | 2012-03-06 | 2012-04-03 | 1.4.3.2.1.1410 SS+8d | 169.25d |
| 1.4.3.2.1.1430 |  | Install 500mm thk general fill | 30d | 2012-03-13 | 2012-04-10 | 1.4.3.2.1.1420 SS+8d | 169.25d |
| 1.4.3.2.1.1440 |  | Install 200mm thk aggregate base coarse | 30d | 2012-03-21 | 2012-04-17 | 1.4.3.2.1.1430 SS+8d | 169.25d |
| 1.4.3.2.1.1450 |  | Install 120mm thk asphalt concrete pavement | 25d | 2012-03-28 | 2012-04-21 | 1.4.3.2.1.1440 SS+8d | 169.25d |
| 1.4.3.2.1.1460 |  | Install shaded parking space | 25d | 2012-04-04 | 2012-04-28 | 1.4.3.2.1.1450 SS+8d | 193.5d |
| 1.4.3.2.1.1470 |  | Install road / park markings | 20d | 2012-04-04 | 2012-04-23 | 1.4.3.2.1.1460 SS | 193.5d |
| 1.4.3.2.1.1480 |  | Install road / park signs | 18.75d | 2012-04-12 | 2012-04-30 | 1.4.3.2.1.1470 SS+8d | 193.5d |
|  | 13 | **Perimeter Fence System** |  | 2012-04-01 | 2012-05-22 |  |  |
| 1.4.3.2.1.1510 |  | Install perimeter fence type SSD-1 | 45d | 2012-04-01 | 2012-05-13 | 1.4.3.2.1.1450 SS+4d | 169.25d |
| 1.4.3.2.1.1520 |  | Install perimeter gate SSD-1, 10.5m widex2 leaf | 25d | 2012-04-29 | 2012-05-22 | 1.4.3.2.1.1510 SS+30d | 169.25d |
|  | 3 | **Toilet Facilities (3 nos)** |  | 2012-03-17 | 2012-11-20 |  |  |
|  | 1 | **Toilet # 1** |  | 2012-03-17 | 2012-11-04 |  |  |
|  | 1 | **Civil works** |  | 2012-03-17 | 2012-08-14 |  |  |
| 1.4.3.3.1.1.010 |  | Excavation leveling & compaction for toilet # 1 bldg fdns | 10d | 2012-03-17 | 2012-03-25 | 1.2.6.200 FS+237.5d, 1.4.3.1.1.140 SS | 37.75d |
| 1.4.3.3.1.1.020 |  | Backfilling/compation | 12.5d | 2012-08-02 | 2012-08-14 | 1.4.3.3.1.1.070 | 207.75d |
|  | 2 | **Structural works** |  | 2012-03-21 | 2012-08-13 |  |  |
| 1.4.3.3.1.1.030 |  | Install lean concrete for reinforced fdns for toilet bldg | 18.75d | 2012-03-21 | 2012-04-08 | 1.4.3.3.1.1.010 SS+6d | 122d |
| 1.4.3.3.1.1.040 |  | Install reinforced fdns for toilet bldg | 31.25d | 2012-04-19 | 2012-05-19 | 1.4.3.3.1.1.030 SS+31.25d | 139.75d |
| 1.4.3.3.1.1.050 |  | Install reinforced columns | 45d | 2012-05-19 | 2012-06-30 | 1.4.3.3.1.1.040 SS+31.25d | 139.75d |
| 1.4.3.3.1.1.060 |  | Install reinforced roof beams | 45d | 2012-06-17 | 2012-07-29 | 1.4.3.3.1.1.050 SS+31.25d | 139.75d |
| 1.4.3.3.1.1.070 |  | Install reinforced roof slab /paraphet | 35d | 2012-07-01 | 2012-08-02 | 1.4.3.3.1.1.060 SS+15d | 139.75d |
| 1.4.3.3.1.1.080 |  | Install reinforced slab on grade | 31.25d | 2012-07-15 | 2012-08-13 | 1.4.3.3.1.1.070 SS+15d | 172.5d |
|  | 3 | **Architectural works** |  | 2012-08-02 | 2012-11-04 |  |  |
|  | 1 | **Masonry** |  | 2012-08-02 | 2012-09-10 |  |  |
| 1.4.3.3.1.1.090 |  | Install 200mm thk CMU blocks | 31.25d | 2012-08-02 | 2012-09-01 | 1.4.3.3.1.1.070 | 139.75d |
| 1.4.3.3.1.1.100 |  | Install 50 mm thk mortar plastering work | 31.25d | 2012-08-12 | 2012-09-10 | 1.4.3.3.1.1.090 SS+10d | 142.5d |
|  | 2 | **Floor Finishing** |  | 2012-09-24 | 2012-10-31 |  |  |
| 1.4.3.3.1.1.110 |  | Install cement toping work | 31.25d | 2012-09-24 | 2012-10-22 | 1.4.3.3.1.1.140 SS | 142.5d |
| 1.4.3.3.1.1.120 |  | Install cermaic tiling work | 31.25d | 2012-10-03 | 2012-10-31 | 1.4.3.3.1.1.110 SS+10d, 1.4.3.3.1.1.150 SS, 1.4.3.3.1.1.020 SS | 142.5d |
|  | 3 | **Wall Finishing** |  | 2012-09-17 | 2012-10-29 |  |  |

| ID | WBS | Task | Duration | Start | Finish | Predecessors | Total float |
| --- | --- | --- | --- | --- | --- | --- | --- |
| 1.4.3.3.1.1.130 |  | Install phenolic toilet partition | 31.25d | 2012-09-17 | 2012-10-16 | 1.4.3.3.1.1.170 SS | 142.5d |
| 1.4.3.3.1.1.140 |  | Install ceramic tiling work | 31.25d | 2012-09-24 | 2012-10-22 | 1.4.3.3.1.1.130 SS+7d | 142.5d |
| 1.4.3.3.1.1.150 |  | Install textured painted work on CMU wall | 31.25d | 2012-09-30 | 2012-10-29 | 1.4.3.3.1.1.140 SS+7d | 145.5d |
|  | 4 | **Ceiling Finihsing** |  | 2012-09-10 | 2012-10-16 |  |  |
| 1.4.3.3.1.1.160 |  | Install gypsum board ceiling system | 25d | 2012-09-10 | 2012-10-03 | 1.4.3.3.1.1.100, 1.4.3.3.1.1.080 | 142.5d |
| 1.4.3.3.1.1.170 |  | Install painting work | 25d | 2012-09-17 | 2012-10-10 | 1.4.3.3.1.1.160 SS+7d | 142.5d |
| 1.4.3.3.1.1.180 |  | Install roof water proofing system & scrupper | 25d | 2012-09-24 | 2012-10-16 | 1.4.3.3.1.1.170 SS+7d | 158.75d |
|  | 5 | **Doors / Windows / Toilet Accs** |  | 2012-10-02 | 2012-11-04 |  |  |
| 1.4.3.3.1.1.190 |  | Install doors & windows | 25d | 2012-10-02 | 2012-10-25 | 1.4.3.3.1.1.290 | 139.75d |
| 1.4.3.3.1.1.200 |  | Install toilet fixtures & accs | 25d | 2012-10-07 | 2012-10-30 | 1.4.3.3.1.1.190 SS+5d | 139.75d |
| 1.4.3.3.1.1.210 |  | Install cabinet & counter top | 25d | 2012-10-11 | 2012-11-04 | 1.4.3.3.1.1.200 SS+5d, 1.4.3.3.1.1.180 SS | 139.75d |
|  | 4 | **Electrical works** |  | 2012-08-02 | 2012-09-09 |  |  |
| 1.4.3.3.1.1.220 |  | Install electric conduits / fittings | 25d | 2012-08-02 | 2012-08-26 | 1.4.3.3.1.1.090 SS | 174d |
| 1.4.3.3.1.1.230 |  | Install cables / wires | 25d | 2012-08-06 | 2012-08-29 | 1.4.3.3.1.1.220 SS+3d | 174d |
| 1.4.3.3.1.1.240 |  | Install lighting fixtures | 25d | 2012-08-08 | 2012-09-01 | 1.4.3.3.1.1.230 SS+3d | 174d |
| 1.4.3.3.1.1.250 |  | Install panelboards | 25d | 2012-08-12 | 2012-09-03 | 1.4.3.3.1.1.240 SS+3d | 174d |
| 1.4.3.3.1.1.255 |  | Install Lighting control panel | 25d | 2012-08-13 | 2012-09-05 | 1.4.3.3.1.1.250 SS+2d | 174d |
| 1.4.3.3.1.1.260 |  | Install disconnect switches | 25d | 2012-08-15 | 2012-09-08 | 1.4.3.3.1.1.250 SS+2d, 1.4.3.3.1.1.255 SS+2d | 174d |
| 1.4.3.3.1.1.270 |  | Install grounding system | 25d | 2012-08-16 | 2012-09-09 | 1.4.3.3.1.1.260 SS+2d | 174d |
|  | 5 | **Water Supply System** |  | 2012-09-01 | 2012-09-24 |  |  |
| 1.4.3.3.1.1.280 |  | Install water supply system | 25d | 2012-09-01 | 2012-09-24 | 1.4.3.3.1.1.090 | 139.75d |
|  | 6 | **Sewer System** |  | 2012-09-09 | 2012-10-02 |  |  |
| 1.4.3.3.1.1.290 |  | Install sewer system | 25d | 2012-09-09 | 2012-10-02 | 1.4.3.3.1.1.280 SS+8d | 139.75d |
|  | 7 | **HVAC System** |  | 2012-10-02 | 2012-10-25 |  |  |
| 1.4.3.3.1.1.300 |  | Install HVAC system | 25d | 2012-10-02 | 2012-10-25 | 1.4.3.3.1.1.290, 1.4.3.3.1.1.270 | 149.75d |
|  | 8 | **Toilet # 2** |  | 2012-04-04 | 2012-11-04 |  |  |
|  | 1 | **Civil works** |  | 2012-04-04 | 2012-08-06 |  |  |
| 1.4.3.3.1.2.010 |  | Excavation leveling & compaction for toilet # 2 bldg fdns | 10d | 2012-04-04 | 2012-04-14 | 1.4.3.3.1.1.030 SS+15d | 122d |
| 1.4.3.3.1.2.020 |  | Backfilling/compation | 12.5d | 2012-07-25 | 2012-08-06 | 1.4.3.3.1.2.070 | 210.5d |
|  | 2 | **Structural works** |  | 2012-04-10 | 2012-08-23 |  |  |
| 1.4.3.3.1.2.030 |  | Install lean concrete for reinforced fdns for toilet bldg | 18.75d | 2012-04-10 | 2012-04-28 | 1.4.3.3.1.2.010 SS+6d | 122d |
| 1.4.3.3.1.2.040 |  | Install reinforced fdns for toilet bldg | 31.25d | 2012-04-24 | 2012-05-23 | 1.4.3.3.1.2.030 SS+15d | 139d |
| 1.4.3.3.1.2.050 |  | Install reinforced columns | 45d | 2012-05-08 | 2012-06-19 | 1.4.3.3.1.2.040 SS+15d | 139d |
| 1.4.3.3.1.2.060 |  | Install reinforced roof beams | 50d | 2012-05-22 | 2012-07-08 | 1.4.3.3.1.2.050 SS+15d | 139d |
| 1.4.3.3.1.2.070 |  | Install reinforced roof slab /paraphet | 37.5d | 2012-06-20 | 2012-07-25 | 1.4.3.3.1.2.060 SS+31.25d | 139d |
| 1.4.3.3.1.2.080 |  | Install reinforced slab on grade | 37.5d | 2012-07-19 | 2012-08-23 | 1.4.3.3.1.2.070 SS+31.25d | 181.75d |
|  | 3 | **Architectural works** |  | 2012-07-25 | 2012-11-04 |  |  |
|  | 1 | **Masonry** |  | 2012-07-25 | 2012-08-27 |  |  |
| 1.4.3.3.1.2.090 |  | Install 200mm thk CMU blocks | 25d | 2012-07-25 | 2012-08-18 | 1.4.3.3.1.2.070 | 139d |
| 1.4.3.3.1.2.100 |  | Install 50 mm thk mortar plastering work | 25d | 2012-08-04 | 2012-08-27 | 1.4.3.3.1.2.090 SS+10d | 139d |
|  | 2 | **Floor Finishing** |  | 2012-10-02 | 2012-11-04 |  |  |
| 1.4.3.3.1.2.110 |  | Install cement toping work | 25d | 2012-10-02 | 2012-10-25 | 1.4.3.3.1.2.140 SS, 1.4.3.3.1.2.080 | 139d |
| 1.4.3.3.1.2.120 |  | Install cermaic tiling work | 25d | 2012-10-11 | 2012-11-04 | 1.4.3.3.1.2.110 SS+10d, 1.4.3.3.1.2.020, 1.4.3.3.1.2.150 SS | 139d |
|  | 3 | **Wall Finishing** |  | 2012-09-26 | 2012-11-01 |  |  |
| 1.4.3.3.1.2.130 |  | Install phenolic toilet partition | 25d | 2012-09-26 | 2012-10-20 | 1.4.3.3.1.2.170 | 139d |
| 1.4.3.3.1.2.140 |  | Install ceramic tiling work | 25d | 2012-10-02 | 2012-10-25 | 1.4.3.3.1.2.130 SS+7d | 139d |
| 1.4.3.3.1.2.150 |  | Install textured painted work on CMU wall | 25d | 2012-10-09 | 2012-11-01 | 1.4.3.3.1.2.140 SS+7d | 142d |
|  | 4 | **Ceiling Finihsing** |  | 2012-08-27 | 2012-10-02 |  |  |
| 1.4.3.3.1.2.160 |  | Install gypsum board ceiling system | 25d | 2012-08-27 | 2012-09-19 | 1.4.3.3.1.2.100 | 139d |
| 1.4.3.3.1.2.170 |  | Install painting work | 25d | 2012-09-03 | 2012-09-26 | 1.4.3.3.1.2.160 SS+7d | 139d |
| 1.4.3.3.1.2.180 |  | Install roof water proofing system & scrupper | 25d | 2012-09-09 | 2012-10-02 | 1.4.3.3.1.2.170 SS+7d | 174d |
|  | 5 | **Doors / Windows / Toilet Accs** |  | 2012-09-18 | 2012-10-20 |  |  |
| 1.4.3.3.1.2.190 |  | Install doors & windows | 25d | 2012-09-18 | 2012-10-10 | 1.4.3.3.1.2.290 | 155d |
| 1.4.3.3.1.2.200 |  | Install toilet fixtures & accs | 25d | 2012-09-23 | 2012-10-15 | 1.4.3.3.1.2.190 SS+5d | 155d |
| 1.4.3.3.1.2.210 |  | Install cabinet & counter top | 25d | 2012-09-27 | 2012-10-20 | 1.4.3.3.1.2.200 SS+5d | 155d |
|  | 4 | **Electrical works** |  | 2012-07-25 | 2012-09-01 |  |  |
| 1.4.3.3.1.2.220 |  | Install electric conduits / fittings | 25d | 2012-07-25 | 2012-08-18 | 1.4.3.3.1.2.090 SS | 183d |
| 1.4.3.3.1.2.230 |  | Install cables / wires | 25d | 2012-07-29 | 2012-08-20 | 1.4.3.3.1.2.220 SS+3d | 183d |
| 1.4.3.3.1.2.240 |  | Install lighting fixtures | 25d | 2012-07-31 | 2012-08-23 | 1.4.3.3.1.2.230 SS+3d | 183d |
| 1.4.3.3.1.2.250 |  | Install panelboards | 25d | 2012-08-02 | 2012-08-26 | 1.4.3.3.1.2.240 SS+3d | 183d |
| 1.4.3.3.1.2.255 |  | Install lighting control panel | 25d | 2012-08-05 | 2012-08-28 | 1.4.3.3.1.2.250 SS+2d | 183d |
| 1.4.3.3.1.2.260 |  | Install disconnect switches | 25d | 2012-08-07 | 2012-08-29 | 1.4.3.3.1.2.250 SS+2d, 1.4.3.3.1.2.255 SS+2d | 183d |
| 1.4.3.3.1.2.270 |  | Install grounding system | 25d | 2012-08-08 | 2012-09-01 | 1.4.3.3.1.2.260 SS+2d | 183d |
|  | 5 | **Water Supply System** |  | 2012-08-18 | 2012-09-10 |  |  |
| 1.4.3.3.1.2.280 |  | Install water supply system | 25d | 2012-08-18 | 2012-09-10 | 1.4.3.3.1.2.090 | 155d |
|  | 6 | **Sewer System** |  | 2012-08-26 | 2012-09-17 |  |  |
| 1.4.3.3.1.2.290 |  | Install sewer system | 25d | 2012-08-26 | 2012-09-17 | 1.4.3.3.1.2.280 SS+8d | 155d |
|  | 7 | **HVAC System** |  | 2012-09-18 | 2012-10-10 |  |  |
| 1.4.3.3.1.2.300 |  | Install HVAC system | 25d | 2012-09-18 | 2012-10-10 | 1.4.3.3.1.2.290, 1.4.3.3.1.2.270 | 165d |
|  | 2 | **Toilet # 3** |  | 2012-04-28 | 2012-11-20 |  |  |

| ID | WBS | Task | Duration | Start | Finish | Predecessors | Total float |
| --- | --- | --- | --- | --- | --- | --- | --- |
|  | 1 | **Civil works** |  | 2012-04-28 | 2012-08-26 |  |  |
| 1.4.3.3.1.3.010 |  | Excavation leveling & compaction for toilet # 3 bldg fdns | 10d | 2012-04-28 | 2012-05-07 | 1.4.3.3.1.2.030 | 122d |
| 1.4.3.3.1.3.020 |  | Backfilling/compation | 12.5d | 2012-08-14 | 2012-08-26 | 1.4.3.3.1.3.070 | 189.5d |
|  | 2 | **Structural works** |  | 2012-05-03 | 2012-08-28 |  |  |
| 1.4.3.3.1.3.030 |  | Install lean concrete for reinforced fdns for toilet bldg | 18.75d | 2012-05-03 | 2012-05-21 | 1.4.3.3.1.3.010 SS+6d | 122d |
| 1.4.3.3.1.3.040 |  | Install reinforced fdns for toilet bldg | 31.25d | 2012-05-17 | 2012-06-16 | 1.4.3.3.1.3.030 SS+15d | 122d |
| 1.4.3.3.1.3.050 |  | Install reinforced columns | 37.5d | 2012-05-31 | 2012-07-05 | 1.4.3.3.1.3.040 SS+15d | 122d |
| 1.4.3.3.1.3.060 |  | Install reinforced roof beams | 37.5d | 2012-06-14 | 2012-07-19 | 1.4.3.3.1.3.050 SS+15d | 122d |
| 1.4.3.3.1.3.070 |  | Install reinforced roof slab /paraphet | 50d | 2012-06-28 | 2012-08-14 | 1.4.3.3.1.3.060 SS+15d | 122d |
| 1.4.3.3.1.3.080 |  | Install reinforced slab on grade | 50d | 2012-07-12 | 2012-08-28 | 1.4.3.3.1.3.070 SS+15d | 187d |
|  | 3 | **Architectural works** |  | 2012-08-14 | 2012-11-20 |  |  |
|  | 1 | **Masonry** |  | 2012-08-14 | 2012-09-16 |  |  |
| 1.4.3.3.1.3.090 |  | Install 200mm thk CMU blocks | 25d | 2012-08-14 | 2012-09-06 | 1.4.3.3.1.3.070 | 122d |
| 1.4.3.3.1.3.100 |  | Install 50 mm thk mortar plastering work | 25d | 2012-08-23 | 2012-09-16 | 1.4.3.3.1.3.090 SS+10d | 122d |
|  | 2 | **Floor Finishing** |  | 2012-10-25 | 2012-11-20 |  |  |
| 1.4.3.3.1.3.110 |  | Install cement toping work | 25d | 2012-10-25 | 2012-11-17 | 1.4.3.3.1.3.140 SS+3d | 122d |
| 1.4.3.3.1.3.120 |  | Install ceramic tiling work | 25d | 2012-10-28 | 2012-11-20 | 1.4.3.3.1.3.110 SS+3d, 1.4.3.3.1.3.020, 1.4.3.3.1.3.080 | 122d |
|  | 3 | **Wall Finishing** |  | 2012-10-16 | 2012-11-20 |  |  |
| 1.4.3.3.1.3.130 |  | Install phenolic toilet partition | 25d | 2012-10-16 | 2012-11-07 | 1.4.3.3.1.3.170 | 122d |
| 1.4.3.3.1.3.140 |  | Install ceramic tiling work | 25d | 2012-10-22 | 2012-11-14 | 1.4.3.3.1.3.130 SS+7d | 122d |
| 1.4.3.3.1.3.150 |  | Install textured painted work on CMU wall | 23.75d | 2012-10-29 | 2012-11-20 | 1.4.3.3.1.3.140 SS+7d | 122.25d |
|  | 4 | **Ceiling Finihsing** |  | 2012-09-16 | 2012-10-22 |  |  |
| 1.4.3.3.1.3.160 |  | Install gypsum board ceiling system | 25d | 2012-09-16 | 2012-10-09 | 1.4.3.3.1.3.100 | 122d |
| 1.4.3.3.1.3.170 |  | Install painting work | 25d | 2012-09-23 | 2012-10-15 | 1.4.3.3.1.3.160 SS+7d | 122d |
| 1.4.3.3.1.3.180 |  | Install roof water proofing system & scrupper | 25d | 2012-09-29 | 2012-10-22 | 1.4.3.3.1.3.170 SS+7d | 153d |
|  | 5 | **Doors / Windows / Toilet Accs** |  | 2012-09-27 | 2012-10-31 |  |  |
| 1.4.3.3.1.3.190 |  | Install doors & windows | 25d | 2012-09-27 | 2012-10-21 | 1.4.3.3.1.3.290, 1.4.3.3.1.3.270 | 143.5d |
| 1.4.3.3.1.3.200 |  | Install toilet fixtures & accs | 25d | 2012-10-04 | 2012-10-28 | 1.4.3.3.1.3.190 SS+7.5d | 143.5d |
| 1.4.3.3.1.3.210 |  | Install cabinet & counter top | 25d | 2012-10-08 | 2012-10-31 | 1.4.3.3.1.3.200 SS+3d | 143.5d |
|  | 4 | **Electrical works** |  | 2012-08-14 | 2012-09-11 |  |  |
| 1.4.3.3.1.3.220 |  | Install electric conduits / fittings | 15d | 2012-08-14 | 2012-08-28 | 1.4.3.3.1.3.090 SS | 161.5d |
| 1.4.3.3.1.3.230 |  | Install cables / wires | 15d | 2012-08-16 | 2012-08-30 | 1.4.3.3.1.3.220 SS+3d | 161.5d |
| 1.4.3.3.1.3.240 |  | Install lighting fixtures | 15d | 2012-08-20 | 2012-09-03 | 1.4.3.3.1.3.230 SS+3d | 161.5d |
| 1.4.3.3.1.3.250 |  | Install panelboards | 15d | 2012-08-22 | 2012-09-05 | 1.4.3.3.1.3.240 SS+3d | 161.5d |
| 1.4.3.3.1.3.255 |  | Install lighting control panel | 15d | 2012-08-25 | 2012-09-08 | 1.4.3.3.1.3.250 SS+2d | 161.5d |
| 1.4.3.3.1.3.260 |  | Install disconnect switches | 15d | 2012-08-26 | 2012-09-09 | 1.4.3.3.1.3.250 SS+2d, 1.4.3.3.1.3.255 SS+2d | 161.5d |
| 1.4.3.3.1.3.270 |  | Install grounding system | 15d | 2012-08-28 | 2012-09-11 | 1.4.3.3.1.3.260 SS+2d | 161.5d |
|  | 5 | **Water Supply System** |  | 2012-09-06 | 2012-09-20 |  |  |
| 1.4.3.3.1.3.280 |  | Install water supply system | 15d | 2012-09-06 | 2012-09-20 | 1.4.3.3.1.3.090 | 143.5d |
|  | 6 | **Sewer System** |  | 2012-09-13 | 2012-09-27 |  |  |
| 1.4.3.3.1.3.290 |  | Install sewer system | 15d | 2012-09-13 | 2012-09-27 | 1.4.3.3.1.3.280 SS+8d | 143.5d |
|  | 7 | **HVAC System** |  | 2012-09-27 | 2012-10-11 |  |  |
| 1.4.3.3.1.3.300 |  | Install HVAC system | 15d | 2012-09-27 | 2012-10-11 | 1.4.3.3.1.3.290 | 164d |
|  | 4 | **Snack Booths (4 nos)** |  | 2012-03-17 | 2012-11-13 |  |  |
|  | 1 | **Snack Booth # 1** |  | 2012-03-17 | 2012-08-11 |  |  |
|  | 1 | **Civil work** |  | 2012-03-17 | 2012-06-07 |  |  |
| 1.4.3.4.1.010 |  | Excavation leveling & compaction for snack booth #1 | 10d | 2012-03-17 | 2012-03-25 | 1.4.3.3.1.1.010 SS | 37.75d |
| 1.4.3.4.1.015 |  | Backfill/comp for snack booth #1 | 12.5d | 2012-05-27 | 2012-06-07 | 1.4.3.4.1.050 | 182.25d |
|  | 2 | **Structural work** |  | 2012-03-21 | 2012-05-27 |  |  |
| 1.4.3.4.1.020 |  | Install lean concrete for reinforced fdns for snack both 1 | 18.75d | 2012-03-21 | 2012-04-08 | 1.4.3.4.1.010 SS+6d | 157d |
| 1.4.3.4.1.030 |  | Install reinforced fdns for snack booth1 | 31.25d | 2012-03-31 | 2012-04-29 | 1.4.3.4.1.020 SS+10d | 157d |
| 1.4.3.4.1.040 |  | Install reinforced roof slab/paraphet snack booth1 | 31.25d | 2012-04-14 | 2012-05-13 | 1.4.3.4.1.030 SS+15d | 157d |
| 1.4.3.4.1.050 |  | Install reinforced slab on grade | 31.25d | 2012-04-28 | 2012-05-27 | 1.4.3.4.1.040 SS+15d | 157d |
|  | 3 | **Architectural work** |  | 2012-05-12 | 2012-08-11 |  |  |
| 1.4.3.4.1.060 |  | Install masonry work for snack booth1 | 18.75d | 2012-05-12 | 2012-05-29 | 1.4.3.4.1.050 SS+15d | 157d |
| 1.4.3.4.1.070 |  | Install plastering work | 18.75d | 2012-05-17 | 2012-06-04 | 1.4.3.4.1.060 SS+6d | 157d |
| 1.4.3.4.1.080 |  | Install roof proofing system | 18.75d | 2012-05-22 | 2012-06-09 | 1.4.3.4.1.070 SS+5d | 157d |
| 1.4.3.4.1.090 |  | Install ceiling system | 18.75d | 2012-05-27 | 2012-06-13 | 1.4.3.4.1.080 SS+5d | 175d |
| 1.4.3.4.1.100 |  | Install concret toping, ceramic floor finishes | 18.75d | 2012-05-31 | 2012-06-18 | 1.4.3.4.1.090 SS+5d | 175d |
| 1.4.3.4.1.110 |  | Install painting work | 18.75d | 2012-06-05 | 2012-06-23 | 1.4.3.4.1.100 SS+5d | 175d |
| 1.4.3.4.1.120 |  | Install plumbing fixture | 18.75d | 2012-06-10 | 2012-06-27 | 1.4.3.4.1.110 SS+5d | 175d |
| 1.4.3.4.1.130 |  | Install doors | 18.75d | 2012-06-14 | 2012-07-02 | 1.4.3.4.1.120 SS+5d, 1.4.3.4.1.015 | 175d |
| 1.4.3.4.1.140 |  | Install windows | 18.75d | 2012-06-20 | 2012-07-08 | 1.4.3.4.1.130 SS+6.25d | 175d |
| 1.4.3.4.1.150 |  | Install furniture & kitchen counter top | 18.75d | 2012-06-26 | 2012-07-14 | 1.4.3.4.1.140 SS+6.25d | 175d |
| 1.4.3.4.1.160 |  | Install kitchen & dinnning equipments | 18.75d | 2012-07-02 | 2012-07-19 | 1.4.3.4.1.150 SS+6.25d | 175d |
| 1.4.3.4.1.170 |  | Install wooden trellis | 18.75d | 2012-07-25 | 2012-08-11 | 1.4.3.4.1.160 SS+6.25d, 1.4.3.4.1.330 | 157d |
|  | 4 | **Electrical work** |  | 2012-06-09 | 2012-07-12 |  |  |
| 1.4.3.4.1.180 |  | Install electric conduits | 18.75d | 2012-06-09 | 2012-06-26 | 1.4.3.4.1.080 | 157d |
| 1.4.3.4.1.190 |  | Install cables & wires | 18.75d | 2012-06-14 | 2012-07-02 | 1.4.3.4.1.180 SS+6d | 157d |
| 1.4.3.4.1.200 |  | Install lighting fixtures | 18.75d | 2012-06-18 | 2012-07-05 | 1.4.3.4.1.190 SS+4d | 157d |

| ID | WBS | Task | Duration | Start | Finish | Predecessors | Total float |
| --- | --- | --- | --- | --- | --- | --- | --- |
| 1.4.3.4.1.210 |  | Install panelboards | 18.75d | 2012-06-21 | 2012-07-08 | 1.4.3.4.1.200 SS+3d | 157d |
| 1.4.3.4.1.220 |  | Install grounding system | 18.75d | 2012-06-23 | 2012-07-10 | 1.4.3.4.1.210 SS+2d | 157d |
| 1.4.3.4.1.230 |  | Testing & commissioing of electric system | 18.75d | 2012-06-26 | 2012-07-12 | 1.4.3.4.1.220 SS+3d | 157d |
|  | 5 | **Communciation work** |  | 2012-06-09 | 2012-07-24 |  |  |
| 1.4.3.4.1.240 |  | Install comm condutis & fittings | 12.5d | 2012-06-09 | 2012-06-20 | 1.4.3.4.1.180 SS | 164.75d |
| 1.4.3.4.1.250 |  | Install UTP cable | 12.5d | 2012-06-12 | 2012-06-24 | 1.4.3.4.1.240 SS+4d | 167.75d |
| 1.4.3.4.1.260 |  | Install equipment cabinet | 12.5d | 2012-06-17 | 2012-06-27 | 1.4.3.4.1.250 SS+4d | 167.75d |
| 1.4.3.4.1.270 |  | Install data network switch | 12.5d | 2012-06-18 | 2012-06-30 | 1.4.3.4.1.260 SS+2d | 167.75d |
| 1.4.3.4.1.280 |  | Install copper splice closure | 12.5d | 2012-06-20 | 2012-07-02 | 1.4.3.4.1.270 SS+2d | 167.75d |
| 1.4.3.4.1.290 |  | Install patch panel | 12.5d | 2012-06-21 | 2012-07-03 | 1.4.3.4.1.280 SS+2d | 167.75d |
| 1.4.3.4.1.300 |  | Install fiber patch panel | 12.5d | 2012-06-25 | 2012-07-07 | 1.4.3.4.1.290 SS+3d | 167.75d |
| 1.4.3.4.1.310 |  | Install patch cord | 12.5d | 2012-06-27 | 2012-07-09 | 1.4.3.4.1.300 SS+3d | 167.75d |
| 1.4.3.4.1.320 |  | Install rack manager | 12.5d | 2012-07-01 | 2012-07-11 | 1.4.3.4.1.310 SS+3d | 167.75d |
| 1.4.3.4.1.330 |  | Testing & commissioning of comm system | 12.5d | 2012-07-14 | 2012-07-24 | 1.4.3.4.1.320 SS+3d, 1.4.3.4.1.230, 1.4.3.4.1.360 | 157d |
|  | 6 | **Mechanical work** |  | 2012-06-09 | 2012-07-05 |  |  |
| 1.4.3.4.1.340 |  | Install water supply system | 15d | 2012-06-09 | 2012-06-23 | 1.4.3.4.1.240 SS | 164.75d |
| 1.4.3.4.1.350 |  | Install sewer system | 15d | 2012-06-16 | 2012-06-30 | 1.4.3.4.1.340 SS+7d | 164.75d |
| 1.4.3.4.1.360 |  | Install HVAC system | 15d | 2012-06-21 | 2012-07-05 | 1.4.3.4.1.350 SS+7d | 164.75d |
|  | 2 | **Snack Booth # 2** |  | 2012-04-18 | 2012-09-20 |  |  |
|  | 1 | **Civil work** |  | 2012-04-18 | 2012-08-02 |  |  |
| 1.4.3.4.2.010 |  | Excavation leveling & compaction for snack booth #2 | 37.5d | 2012-04-18 | 2012-05-22 | 1.4.3.4.1.010 SS+35d | 128.75d |
| 1.4.3.4.2.015 |  | Backfill/comp for snack booth #2 | 37.5d | 2012-06-28 | 2012-08-02 | 1.4.3.4.2.050 | 174d |
|  | 2 | **Structural work** |  | 2012-04-23 | 2012-06-28 |  |  |
| 1.4.3.4.2.020 |  | Install lean concrete for reinforced fdns for snack both | 18.75d | 2012-04-23 | 2012-05-10 | 1.4.3.4.2.010 SS+6d | 174d |
| 1.4.3.4.2.030 |  | Install reinforced fdns for snack booth | 31.25d | 2012-05-02 | 2012-05-31 | 1.4.3.4.2.020 SS+10d | 174d |
| 1.4.3.4.2.040 |  | Install reinforced roof slab/paraphet snack booth | 31.25d | 2012-05-16 | 2012-06-14 | 1.4.3.4.2.030 SS+15d | 174d |
| 1.4.3.4.2.050 |  | Install reinforced slab on grade | 31.25d | 2012-05-30 | 2012-06-28 | 1.4.3.4.2.040 SS+15d | 174d |
|  | 3 | **Architectural work** |  | 2012-06-13 | 2012-09-20 |  |  |
| 1.4.3.4.2.060 |  | Install masonry work for snack booth | 18.75d | 2012-06-13 | 2012-07-01 | 1.4.3.4.2.050 SS+15d | 174d |
| 1.4.3.4.2.070 |  | Install plastering work | 18.75d | 2012-06-19 | 2012-07-07 | 1.4.3.4.2.060 SS+6d | 174d |
| 1.4.3.4.2.080 |  | Install roof proofing system | 18.75d | 2012-06-24 | 2012-07-11 | 1.4.3.4.2.070 SS+5d | 174d |
| 1.4.3.4.2.090 |  | Install ceiling system | 18.75d | 2012-06-28 | 2012-07-16 | 1.4.3.4.2.080 SS+5d | 194.75d |
| 1.4.3.4.2.100 |  | Install concrete toping, ceramic floor finishes | 18.75d | 2012-07-03 | 2012-07-21 | 1.4.3.4.2.090 SS+5d | 194.75d |
| 1.4.3.4.2.110 |  | Install painting work | 18.75d | 2012-08-12 | 2012-08-28 | 1.4.3.4.2.100 SS+4d, 1.4.3.4.1.170 | 157d |
| 1.4.3.4.2.120 |  | Install plumbing fixture | 18.75d | 2012-08-15 | 2012-09-02 | 1.4.3.4.2.110 SS+4d | 157d |
| 1.4.3.4.2.130 |  | Install doors | 18.75d | 2012-08-19 | 2012-09-05 | 1.4.3.4.2.120 SS+4d, 1.4.3.4.2.015 | 157d |
| 1.4.3.4.2.140 |  | Install windows | 18.75d | 2012-08-21 | 2012-09-06 | 1.4.3.4.2.130 SS+2d | 157d |
| 1.4.3.4.2.150 |  | Install furniture & kitchen counter top | 18.75d | 2012-08-22 | 2012-09-09 | 1.4.3.4.2.140 SS+2d | 157d |
| 1.4.3.4.2.160 |  | Install kitchen & dinnning equipments | 18.75d | 2012-08-28 | 2012-09-15 | 1.4.3.4.2.150 SS+6d | 157d |
| 1.4.3.4.2.170 |  | Install wooden trellis | 18.75d | 2012-09-03 | 2012-09-20 | 1.4.3.4.2.160 SS+6d, 1.4.3.4.2.230 | 157d |
|  | 4 | **Electrical work** |  | 2012-07-11 | 2012-08-11 |  |  |
| 1.4.3.4.2.180 |  | Install electric conduits | 15d | 2012-07-11 | 2012-07-25 | 1.4.3.4.2.080 | 174d |
| 1.4.3.4.2.190 |  | Install cables & wires | 15d | 2012-07-17 | 2012-07-31 | 1.4.3.4.2.180 SS+6d | 174d |
| 1.4.3.4.2.200 |  | Install lighting fixtures | 15d | 2012-07-21 | 2012-08-04 | 1.4.3.4.2.190 SS+4d | 174d |
| 1.4.3.4.2.210 |  | Install panelboards | 15d | 2012-07-24 | 2012-08-06 | 1.4.3.4.2.200 SS+3d | 174d |
| 1.4.3.4.2.220 |  | Install grounding system | 15d | 2012-07-25 | 2012-08-08 | 1.4.3.4.2.210 SS+2d | 174d |
| 1.4.3.4.2.230 |  | Testing & commissioing of electric system | 15d | 2012-07-29 | 2012-08-11 | 1.4.3.4.2.220 SS+3d | 174d |
|  | 5 | **Communciation work** |  | 2012-07-11 | 2012-08-25 |  |  |
| 1.4.3.4.2.240 |  | Install comm condutis & fittings | 15d | 2012-07-11 | 2012-07-25 | 1.4.3.4.2.180 SS | 178d |
| 1.4.3.4.2.250 |  | Install UTP cable | 15d | 2012-07-15 | 2012-07-29 | 1.4.3.4.2.240 SS+4d | 181d |
| 1.4.3.4.2.260 |  | Install equipment cabinet | 15d | 2012-07-19 | 2012-08-01 | 1.4.3.4.2.250 SS+4d | 181d |
| 1.4.3.4.2.270 |  | Install data network switch | 15d | 2012-07-21 | 2012-08-04 | 1.4.3.4.2.260 SS+2d | 181d |
| 1.4.3.4.2.280 |  | Install copper splice closure | 15d | 2012-07-23 | 2012-08-06 | 1.4.3.4.2.270 SS+2d | 181d |
| 1.4.3.4.2.290 |  | Install patch panel | 15d | 2012-07-24 | 2012-08-07 | 1.4.3.4.2.280 SS+2d | 181d |
| 1.4.3.4.2.300 |  | Install fiber patch panel | 15d | 2012-07-28 | 2012-08-11 | 1.4.3.4.2.290 SS+3d | 181d |
| 1.4.3.4.2.310 |  | Install patch cord | 15d | 2012-07-30 | 2012-08-13 | 1.4.3.4.2.300 SS+3d | 181d |
| 1.4.3.4.2.320 |  | Install rack manager | 15d | 2012-08-02 | 2012-08-15 | 1.4.3.4.2.310 SS+3d | 181d |
| 1.4.3.4.2.330 |  | Testing & commissioning of comm system | 15d | 2012-08-12 | 2012-08-25 | 1.4.3.4.2.320 SS+3d, 1.4.3.4.2.230, 1.4.3.4.2.360 | 174d |
|  | 6 | **Mechanical work** |  | 2012-07-11 | 2012-08-07 |  |  |
| 1.4.3.4.2.340 |  | Install water supply system | 15d | 2012-07-11 | 2012-07-25 | 1.4.3.4.2.240 SS | 178d |
| 1.4.3.4.2.350 |  | Install sewer system | 15d | 2012-07-18 | 2012-08-01 | 1.4.3.4.2.340 SS+7d | 178d |
| 1.4.3.4.2.360 |  | Install HVAC system | 15d | 2012-07-24 | 2012-08-07 | 1.4.3.4.2.350 SS+7d | 178d |
|  | 3 | **Snack Booth # 3** |  | 2012-05-21 | 2012-11-13 |  |  |
|  | 1 | **Civil work** |  | 2012-05-21 | 2012-08-12 |  |  |
| 1.4.3.4.3.010 |  | Excavation leveling & compaction for snack booth 3 | 10d | 2012-05-21 | 2012-05-29 | 1.4.3.4.2.010 SS+35d | 128.75d |
| 1.4.3.4.3.015 |  | Backfill/comp for snack booth 3 | 12.5d | 2012-07-31 | 2012-08-12 | 1.4.3.4.3.050 | 188d |
|  | 2 | **Structural work** |  | 2012-05-26 | 2012-07-31 |  |  |
| 1.4.3.4.3.020 |  | Install lean concrete for reinforced fdns for snack both | 18.75d | 2012-05-26 | 2012-06-12 | 1.4.3.4.3.010 SS+6d | 128.75d |
| 1.4.3.4.3.030 |  | Install reinforced fdns for snack booth | 31.25d | 2012-06-04 | 2012-07-03 | 1.4.3.4.3.020 SS+10d | 128.75d |
| 1.4.3.4.3.040 |  | Install reinforced roof slab/paraphet snack booth | 31.25d | 2012-06-18 | 2012-07-17 | 1.4.3.4.3.030 SS+15d | 128.75d |

| ID | WBS | Task | Duration | Start | Finish | Predecessors | Total float |
| --- | --- | --- | --- | --- | --- | --- | --- |
| 1.4.3.4.3.050 |  | Install reinforced slab on grade | 31.25d | 2012-07-02 | 2012-07-31 | 1.4.3.4.3.040 SS+15d | 128.75d |
|  | 3 | **Architectural work** |  | 2012-07-16 | 2012-11-13 |  |  |
| 1.4.3.4.3.060 |  | Install masonry work for snack booth | 25d | 2012-07-16 | 2012-08-08 | 1.4.3.4.3.050 SS+15d | 128.75d |
| 1.4.3.4.3.070 |  | Install plastering work | 25d | 2012-07-22 | 2012-08-14 | 1.4.3.4.3.060 SS+6d | 128.75d |
| 1.4.3.4.3.080 |  | Install roof proofing system | 25d | 2012-07-26 | 2012-08-19 | 1.4.3.4.3.070 SS+5d | 128.75d |
| 1.4.3.4.3.090 |  | Install ceiling system | 25d | 2012-07-31 | 2012-08-23 | 1.4.3.4.3.080 SS+5d | 183.75d |
| 1.4.3.4.3.100 |  | Install concrete toping, ceramic floor finishes | 25d | 2012-08-05 | 2012-08-28 | 1.4.3.4.3.090 SS+5d | 183.75d |
| 1.4.3.4.3.110 |  | Install painting work | 25d | 2012-09-03 | 2012-09-26 | 1.4.3.4.3.100 SS+4d, 1.4.3.4.2.170 SS | 157d |
| 1.4.3.4.3.120 |  | Install plumbing fixture | 25d | 2012-09-06 | 2012-09-30 | 1.4.3.4.3.110 SS+4d | 157d |
| 1.4.3.4.3.130 |  | Install doors | 25d | 2012-09-10 | 2012-10-03 | 1.4.3.4.3.120 SS+4d, 1.4.3.4.2.330, 1.4.3.4.3.015 | 157d |
| 1.4.3.4.3.140 |  | Install windows | 25d | 2012-09-12 | 2012-10-06 | 1.4.3.4.3.130 SS+2d | 157d |
| 1.4.3.4.3.150 |  | Install furniture & kitchen counter top | 25d | 2012-09-13 | 2012-10-07 | 1.4.3.4.3.140 SS+2d | 157d |
| 1.4.3.4.3.160 |  | Install kitchen & dinnning equipments | 25d | 2012-09-19 | 2012-10-13 | 1.4.3.4.3.150 SS+6d | 157d |
| 1.4.3.4.3.170 |  | Install wooden trellis | 25d | 2012-10-22 | 2012-11-13 | 1.4.3.4.3.160 SS+6d, 1.4.3.4.3.330 | 128.75d |
|  | 4 | **Electrical work** |  | 2012-08-19 | 2012-09-27 |  |  |
| 1.4.3.4.3.180 |  | Install electric conduits | 25d | 2012-08-19 | 2012-09-11 | 1.4.3.4.3.080 | 128.75d |
| 1.4.3.4.3.190 |  | Install cables & wires | 25d | 2012-08-25 | 2012-09-17 | 1.4.3.4.3.180 SS+6d | 128.75d |
| 1.4.3.4.3.200 |  | Install lighting fixtures | 25d | 2012-08-28 | 2012-09-20 | 1.4.3.4.3.190 SS+4d | 128.75d |
| 1.4.3.4.3.210 |  | Install panelboards | 25d | 2012-09-01 | 2012-09-23 | 1.4.3.4.3.200 SS+3d | 128.75d |
| 1.4.3.4.3.220 |  | Install grounding system | 25d | 2012-09-02 | 2012-09-25 | 1.4.3.4.3.210 SS+2d | 128.75d |
| 1.4.3.4.3.230 |  | Testing & commissioing of electric system | 25d | 2012-09-05 | 2012-09-27 | 1.4.3.4.3.220 SS+3d | 128.75d |
|  | 5 | **Communciation work** |  | 2012-08-19 | 2012-10-21 |  |  |
| 1.4.3.4.3.240 |  | Install comm condutis & fittings | 25d | 2012-08-19 | 2012-09-11 | 1.4.3.4.3.180 SS | 145.25d |
| 1.4.3.4.3.250 |  | Install UTP cable | 25d | 2012-08-22 | 2012-09-15 | 1.4.3.4.3.240 SS+4d | 145.75d |
| 1.4.3.4.3.260 |  | Install equipment cabinet | 25d | 2012-08-27 | 2012-09-18 | 1.4.3.4.3.250 SS+4d | 145.75d |
| 1.4.3.4.3.270 |  | Install data network switch | 25d | 2012-08-28 | 2012-09-20 | 1.4.3.4.3.260 SS+2d | 145.75d |
| 1.4.3.4.3.280 |  | Install copper splice closure | 25d | 2012-08-30 | 2012-09-23 | 1.4.3.4.3.270 SS+2d | 145.75d |
| 1.4.3.4.3.290 |  | Install patch panel | 25d | 2012-09-01 | 2012-09-24 | 1.4.3.4.3.280 SS+2d | 145.75d |
| 1.4.3.4.3.300 |  | Install fiber patch panel | 25d | 2012-09-04 | 2012-09-27 | 1.4.3.4.3.290 SS+3d | 145.75d |
| 1.4.3.4.3.310 |  | Install patch cord | 25d | 2012-09-06 | 2012-09-30 | 1.4.3.4.3.300 SS+3d | 145.75d |
| 1.4.3.4.3.320 |  | Install rack manager | 25d | 2012-09-10 | 2012-10-02 | 1.4.3.4.3.310 SS+3d | 145.75d |
| 1.4.3.4.3.330 |  | Testing & commissioning of comm system | 25d | 2012-09-29 | 2012-10-21 | 1.4.3.4.3.320 SS+3d, 1.4.3.4.3.230, 1.4.3.4.3.360 | 128.75d |
|  | 6 | **Mechanical work** |  | 2012-08-19 | 2012-09-12 |  |  |
| 1.4.3.4.3.340 |  | Install water supply system | 12.5d | 2012-08-19 | 2012-08-30 | 1.4.3.4.3.240 SS | 145.25d |
| 1.4.3.4.3.350 |  | Install sewer system | 12.5d | 2012-08-26 | 2012-09-06 | 1.4.3.4.3.340 SS+7d | 145.25d |
| 1.4.3.4.3.360 |  | Install HVAC system | 12.5d | 2012-09-01 | 2012-09-12 | 1.4.3.4.3.350 SS+7d | 145.25d |
|  | 4 | **Snack Booth # 4** |  | 2012-06-23 | 2012-11-04 |  |  |
|  | 1 | **Civil work** |  | 2012-06-23 | 2012-09-13 |  |  |
| 1.4.3.4.4.010 |  | Excavation leveling & compaction for snack booth 4 | 10d | 2012-06-23 | 2012-07-01 | 1.4.3.4.3.010 SS+35d | 139.5d |
| 1.4.3.4.4.015 |  | Backfill/comp for snack booth 4 | 12.5d | 2012-09-02 | 2012-09-13 | 1.4.3.4.4.050 | 165.5d |
|  | 2 | **Structural work** |  | 2012-06-27 | 2012-09-02 |  |  |
| 1.4.3.4.4.020 |  | Install lean concrete for reinforced fdns for snack both | 18.75d | 2012-06-27 | 2012-07-15 | 1.4.3.4.4.010 SS+6d | 139.5d |
| 1.4.3.4.4.030 |  | Install reinforced fdns for snack booth | 31.25d | 2012-07-07 | 2012-08-05 | 1.4.3.4.4.020 SS+10d | 139.5d |
| 1.4.3.4.4.040 |  | Install reinforced roof slab/paraphet snack booth | 31.25d | 2012-07-21 | 2012-08-19 | 1.4.3.4.4.030 SS+15d | 139.5d |
| 1.4.3.4.4.050 |  | Install reinforced slab on grade | 31.25d | 2012-08-04 | 2012-09-02 | 1.4.3.4.4.040 SS+15d | 139.5d |
|  | 3 | **Architectural work** |  | 2012-08-18 | 2012-11-04 |  |  |
| 1.4.3.4.4.060 |  | Install masonry work for snack booth | 12.5d | 2012-08-18 | 2012-08-29 | 1.4.3.4.4.050 SS+15d | 139.5d |
| 1.4.3.4.4.070 |  | Install plastering work | 12.5d | 2012-08-22 | 2012-09-03 | 1.4.3.4.4.060 SS+5d | 139.5d |
| 1.4.3.4.4.080 |  | Install roof proofing system | 12.5d | 2012-08-27 | 2012-09-08 | 1.4.3.4.4.070 SS+5d | 139.5d |
| 1.4.3.4.4.090 |  | Install ceiling system | 12.5d | 2012-09-01 | 2012-09-12 | 1.4.3.4.4.080 SS+5d | 153.75d |
| 1.4.3.4.4.100 |  | Install concrete toping, ceramic floor finishes | 12.5d | 2012-09-05 | 2012-09-17 | 1.4.3.4.4.090 SS+5d | 153.75d |
| 1.4.3.4.4.110 |  | Install painting work | 12.5d | 2012-09-17 | 2012-09-29 | 1.4.3.4.4.100 SS+12.5d | 153.75d |
| 1.4.3.4.4.120 |  | Install plumbing fixture | 12.5d | 2012-09-22 | 2012-10-02 | 1.4.3.4.4.110 SS+4d | 153.75d |
| 1.4.3.4.4.130 |  | Install doors | 12.5d | 2012-09-25 | 2012-10-07 | 1.4.3.4.4.120 SS+4d, 1.4.3.4.4.015 | 153.75d |
| 1.4.3.4.4.140 |  | Install windows | 12.5d | 2012-09-26 | 2012-10-08 | 1.4.3.4.4.130 SS+2d | 153.75d |
| 1.4.3.4.4.150 |  | Install furniture & kitchen counter top | 12.5d | 2012-09-29 | 2012-10-10 | 1.4.3.4.4.140 SS+2d | 153.75d |
| 1.4.3.4.4.160 |  | Install kitchen & dinnning equipments | 12.5d | 2012-10-04 | 2012-10-16 | 1.4.3.4.4.150 SS+6d | 153.75d |
| 1.4.3.4.4.170 |  | Install wooden trellis | 12.5d | 2012-10-23 | 2012-11-04 | 1.4.3.4.4.160 SS+6d, 1.4.3.4.4.330 | 139.5d |
|  | 4 | **Electrical work** |  | 2012-09-08 | 2012-10-07 |  |  |
| 1.4.3.4.4.180 |  | Install electric conduits | 12.5d | 2012-09-08 | 2012-09-19 | 1.4.3.4.4.080 | 139.5d |
| 1.4.3.4.4.190 |  | Install cables & wires | 12.5d | 2012-09-13 | 2012-09-25 | 1.4.3.4.4.180 SS+6d | 149d |
| 1.4.3.4.4.200 |  | Install lighting fixtures | 12.5d | 2012-09-17 | 2012-09-29 | 1.4.3.4.4.190 SS+4d | 149d |
| 1.4.3.4.4.210 |  | Install panelboards | 12.5d | 2012-09-20 | 2012-10-02 | 1.4.3.4.4.200 SS+3.75d | 149d |
| 1.4.3.4.4.220 |  | Install grounding system | 12.5d | 2012-09-23 | 2012-10-04 | 1.4.3.4.4.210 SS+2d | 149d |
| 1.4.3.4.4.230 |  | Testing & commissioing of electric system | 12.5d | 2012-09-25 | 2012-10-07 | 1.4.3.4.4.220 SS+3d | 149d |
|  | 5 | **Communciation work** |  | 2012-09-19 | 2012-10-23 |  |  |
| 1.4.3.4.4.240 |  | Install comm condutis & fittings | 7.5d | 2012-09-19 | 2012-09-26 | 1.4.3.4.4.180 | 139.5d |
| 1.4.3.4.4.250 |  | Install UTP cable | 7.5d | 2012-09-24 | 2012-09-30 | 1.4.3.4.4.240 SS+4d | 139.5d |
| 1.4.3.4.4.260 |  | Install equipment cabinet | 7.5d | 2012-09-27 | 2012-10-04 | 1.4.3.4.4.250 SS+4d | 139.5d |
| 1.4.3.4.4.270 |  | Install data network switch | 7.5d | 2012-10-01 | 2012-10-08 | 1.4.3.4.4.260 SS+3.75d | 139.5d |

| ID | WBS | Task | Duration | Start | Finish | Predecessors | Total float |
| --- | --- | --- | --- | --- | --- | --- | --- |
| 1.4.3.4.4.280 |  | Install copper splice closure | 7.5d | 2012-10-03 | 2012-10-10 | 1.4.3.4.4.270 SS+2.5d | 139.5d |
| 1.4.3.4.4.290 |  | Install patch panel | 7.5d | 2012-10-04 | 2012-10-11 | 1.4.3.4.4.280 SS+2d | 139.5d |
| 1.4.3.4.4.300 |  | Install fiber patch panel | 7.5d | 2012-10-08 | 2012-10-15 | 1.4.3.4.4.290 SS+3d | 139.5d |
| 1.4.3.4.4.310 |  | Install patch cord | 7.5d | 2012-10-10 | 2012-10-17 | 1.4.3.4.4.300 SS+3d | 139.5d |
| 1.4.3.4.4.320 |  | Install rack manager | 7.5d | 2012-10-14 | 2012-10-20 | 1.4.3.4.4.310 SS+3d | 139.5d |
| 1.4.3.4.4.330 |  | Testing & commissioning of comm system | 7.5d | 2012-10-16 | 2012-10-23 | 1.4.3.4.4.320 SS+3d, 1.4.3.4.4.230, 1.4.3.4.4.360 | 139.5d |
|  | 6 | **Mechanical work** |  | 2012-09-26 | 2012-10-15 |  |  |
| 1.4.3.4.4.340 |  | Install water supply system | 8d | 2012-09-26 | 2012-10-04 | 1.4.3.4.4.240 | 140.25d |
| 1.4.3.4.4.350 |  | Install sewer system | 8d | 2012-10-03 | 2012-10-10 | 1.4.3.4.4.340 SS+7d | 140.25d |
| 1.4.3.4.4.360 |  | Install HVAC system | 6d | 2012-10-10 | 2012-10-15 | 1.4.3.4.4.350 SS+7d | 140.25d |
|  | 5 | **Picnic Shelters (30 nos)** |  | 2012-03-17 | 2012-11-06 |  |  |
|  | 1 | **Picnic Shelters** |  | 2012-03-17 | 2012-11-06 |  |  |
|  | 1 | **Civil work** |  | 2012-03-17 | 2012-07-30 |  |  |
| 1.4.3.5.1.010 |  | Excavation for picnic shelters | 60d | 2012-03-17 | 2012-05-10 | 1.4.3.4.1.010 SS | 37.75d |
| 1.4.3.5.1.015 |  | Backfill/comp for picnic shelters | 60d | 2012-06-04 | 2012-07-30 | 1.4.3.5.1.040 SS+45d | 137.75d |
|  | 2 | **Structural work** |  | 2012-03-21 | 2012-07-14 |  |  |
| 1.4.3.5.1.020 |  | Install lean concrete for reinforced fdns | 75d | 2012-03-21 | 2012-05-30 | 1.4.3.5.1.010 SS+6d | 44d |
| 1.4.3.5.1.030 |  | Install reinforced fdns | 87.5d | 2012-04-04 | 2012-06-25 | 1.4.3.5.1.020 SS+15d | 44d |
| 1.4.3.5.1.040 |  | Install reinforced roof slab on grade | 87.5d | 2012-04-23 | 2012-07-14 | 1.4.3.5.1.030 SS+20d | 44d |
|  | 3 | **Architectural work** |  | 2012-05-12 | 2012-09-19 |  |  |
| 1.4.3.5.1.050 |  | Install cement based plaster/textured paintn finish | 90d | 2012-05-12 | 2012-08-04 | 1.4.3.5.1.040 SS+20d | 44d |
| 1.4.3.5.1.060 |  | Install roofing trellis system | 90d | 2012-05-23 | 2012-08-15 | 1.4.3.5.1.050 SS+12.5d | 44d |
| 1.4.3.5.1.070 |  | Install concrete topping, ceramic floor finish | 90d | 2012-06-04 | 2012-08-27 | 1.4.3.5.1.060 SS+12.5d | 44d |
| 1.4.3.5.1.080 |  | Install picnic furniture | 90d | 2012-06-16 | 2012-09-08 | 1.4.3.5.1.070 SS+12.5d | 172.75d |
| 1.4.3.5.1.090 |  | Install faucet & drain fixtures/plumbing works | 90d | 2012-06-27 | 2012-09-19 | 1.4.3.5.1.080 SS+12.5d | 172.75d |
|  | 4 | **Electrical work** |  | 2012-07-07 | 2012-11-06 |  |  |
| 1.4.3.5.1.100 |  | Install electric conduits & fittings | 90d | 2012-07-07 | 2012-09-29 | 1.4.3.5.1.070 SS+35d | 44d |
| 1.4.3.5.1.110 |  | Install cables & wires | 90d | 2012-07-18 | 2012-10-10 | 1.4.3.5.1.100 SS+12.5d | 44d |
| 1.4.3.5.1.120 |  | Install lighting fixtures | 75d | 2012-08-05 | 2012-10-14 | 1.4.3.5.1.110 SS+18.75d | 44d |
| 1.4.3.5.1.130 |  | Install grounding system | 75d | 2012-08-16 | 2012-10-25 | 1.4.3.5.1.120 SS+12.5d | 44d |
| 1.4.3.5.1.140 |  | Testing & commissioing of electric system | 12.5d | 2012-10-25 | 2012-11-06 | 1.4.3.5.1.130, 1.4.3.5.1.015, 1.4.3.5.1.090 SS | 44d |
|  | 6 | **Fitness Shelters (7 nos)** |  | 2012-03-17 | 2012-11-12 |  |  |
|  | 1 | **Fitness Shelters** |  | 2012-03-17 | 2012-11-12 |  |  |
|  | 1 | **Civil work** |  | 2012-03-17 | 2012-07-21 |  |  |
| 1.4.3.6.1.010 |  | Excavation for picnic shelters | 60d | 2012-03-17 | 2012-05-10 | 1.4.3.5.1.010 SS | 37.75d |
| 1.4.3.6.1.015 |  | Backfill/comp for picnic shelters | 50d | 2012-06-04 | 2012-07-21 | 1.4.3.6.1.040 SS+45d | 95.25d |
|  | 2 | **Structural work** |  | 2012-03-21 | 2012-07-14 |  |  |
| 1.4.3.6.1.020 |  | Install lean concrete for reinforced fdns | 75d | 2012-03-21 | 2012-05-30 | 1.4.3.6.1.010 SS+6d | 37.75d |
| 1.4.3.6.1.030 |  | Install reinforced fdns | 87.5d | 2012-04-04 | 2012-06-25 | 1.4.3.6.1.020 SS+15d | 37.75d |
| 1.4.3.6.1.040 |  | Install reinforced roof slab on grade | 87.5d | 2012-04-23 | 2012-07-14 | 1.4.3.6.1.030 SS+20d | 37.75d |
|  | 3 | **Architectural work** |  | 2012-05-12 | 2012-10-23 |  |  |
| 1.4.3.6.1.050 |  | Install cement based plaster/textured paintn finish | 75d | 2012-05-12 | 2012-07-21 | 1.4.3.6.1.040 SS+20d | 37.75d |
| 1.4.3.6.1.060 |  | Install roofing trellis system | 75d | 2012-05-29 | 2012-08-07 | 1.4.3.6.1.050 SS+18.75d | 37.75d |
| 1.4.3.6.1.070 |  | Install concrete topping, ceramic floor finish | 75d | 2012-06-16 | 2012-08-25 | 1.4.3.6.1.060 SS+18.75d | 37.75d |
| 1.4.3.6.1.080 |  | Install fitness furniture | 75d | 2012-07-19 | 2012-09-27 | 1.4.3.6.1.070 SS+18.75d, 1.3.5.5.030 | 59d |
| 1.4.3.6.1.090 |  | Install aluminium cladding | 75d | 2012-08-06 | 2012-10-15 | 1.4.3.6.1.080 SS+18.75d | 59d |
| 1.4.3.6.1.100 |  | Install faucet & drain fixtures/plumbing works | 65d | 2012-08-23 | 2012-10-23 | 1.4.3.6.1.090 SS+18.75d, 1.4.3.6.1.015 | 59d |
|  | 4 | **Electrical work** |  | 2012-07-18 | 2012-11-12 |  |  |
| 1.4.3.6.1.110 |  | Install electric conduits & fittings | 75d | 2012-07-18 | 2012-09-26 | 1.4.3.6.1.070 SS+35d | 37.75d |
| 1.4.3.6.1.120 |  | Install cables & wires | 75d | 2012-08-01 | 2012-10-10 | 1.4.3.6.1.110 SS+15d | 37.75d |
| 1.4.3.6.1.130 |  | Install lighting fixtures | 75d | 2012-08-15 | 2012-10-24 | 1.4.3.6.1.120 SS+15d | 37.75d |
| 1.4.3.6.1.140 |  | Install grounding system | 75d | 2012-08-29 | 2012-11-07 | 1.4.3.6.1.130 SS+15d | 37.75d |
| 1.4.3.6.1.150 |  | Testing & commissioing of electric system | 65d | 2012-09-12 | 2012-11-12 | 1.4.3.6.1.140 SS+15d, 1.4.3.6.1.100 SS | 37.75d |
|  | 7 | **Art Work Shelters (8 nos)** |  | 2012-03-17 | 2012-11-07 |  |  |
|  | 1 | **Art Work Shelters** |  | 2012-03-17 | 2012-11-07 |  |  |
|  | 1 | **Civil work** |  | 2012-03-17 | 2012-07-30 |  |  |
| 1.4.3.7.1.010 |  | Excavation for picnic shelters | 60d | 2012-03-17 | 2012-05-10 | 1.4.3.6.1.010 SS | 42.75d |
| 1.4.3.7.1.015 |  | Backfill/comp for picnic shelters | 60d | 2012-06-04 | 2012-07-30 | 1.4.3.7.1.040 SS+45d | 75.25d |
|  | 2 | **Structural work** |  | 2012-03-21 | 2012-07-14 |  |  |
| 1.4.3.7.1.020 |  | Install lean concrete for reinforced fdns | 62.5d | 2012-03-21 | 2012-05-19 | 1.4.3.7.1.010 SS+6d | 42.75d |
| 1.4.3.7.1.030 |  | Install reinforced fdns | 87.5d | 2012-04-04 | 2012-06-25 | 1.4.3.7.1.020 SS+15d | 42.75d |
| 1.4.3.7.1.040 |  | Install reinforced roof slab on grade | 87.5d | 2012-04-23 | 2012-07-14 | 1.4.3.7.1.030 SS+20d | 42.75d |
|  | 3 | **Architectural work** |  | 2012-05-12 | 2012-10-16 |  |  |
| 1.4.3.7.1.050 |  | Install cement based plaster/textured paintn finish | 75d | 2012-05-12 | 2012-07-21 | 1.4.3.7.1.040 SS+20d | 42.75d |
| 1.4.3.7.1.060 |  | Install roofing trellis system | 75d | 2012-05-29 | 2012-08-07 | 1.4.3.7.1.050 SS+18.75d | 42.75d |
| 1.4.3.7.1.070 |  | Install concrete topping, ceramic floor finish | 75d | 2012-06-16 | 2012-08-25 | 1.4.3.7.1.060 SS+18.75d | 42.75d |
| 1.4.3.7.1.080 |  | Install furniture for art works | 75d | 2012-07-03 | 2012-09-11 | 1.4.3.7.1.070 SS+18.75d | 66.5d |
| 1.4.3.7.1.090 |  | Install aluminium cladding | 75d | 2012-07-21 | 2012-09-29 | 1.4.3.7.1.080 SS+18.75d | 66.5d |
| 1.4.3.7.1.100 |  | Install faucet & drain fixtures/plumbing works | 75d | 2012-08-07 | 2012-10-16 | 1.4.3.7.1.090 SS+18.75d, 1.4.3.7.1.015 | 66.5d |
|  | 4 | **Electrical work** |  | 2012-07-18 | 2012-11-07 |  |  |

| ID | WBS | Task | Duration | Start | Finish | Predecessors | Total float |
| --- | --- | --- | --- | --- | --- | --- | --- |
| 1.4.3.7.1.110 |  | Install electric conduits & fittings | 75d | 2012-07-18 | 2012-09-26 | 1.4.3.7.1.070 SS+35d | 42.75d |
| 1.4.3.7.1.120 |  | Install cables & wires | 75d | 2012-08-01 | 2012-10-10 | 1.4.3.7.1.110 SS+15d | 42.75d |
| 1.4.3.7.1.130 |  | Install lighting fixtures | 75d | 2012-08-15 | 2012-10-24 | 1.4.3.7.1.120 SS+15d | 42.75d |
| 1.4.3.7.1.140 |  | Install grounding system | 75d | 2012-08-29 | 2012-11-07 | 1.4.3.7.1.130 SS+15d | 42.75d |
|  | 4 | **PRE-COMMISSIONING WORKS** |  | 2012-01-24 | 2012-12-29 |  |  |
|  | 1 | **Submit OSPDP (Operating Spare Parts Data Package** |  | 2012-04-07 | 2012-10-20 |  |  |
|  | 1 | **Submit OSPDP** |  | 2012-04-07 | 2012-10-20 |  |  |
| 1.4.4.1.010 |  | Complete Submit OSPDP for elect materials | 93.75d | 2012-04-07 | 2012-07-03 | 1.3.2.1.020, 1.4.3.1.1.090, 1.4.3.1.2.090 | 62.75d |
| 1.4.4.1.020 |  | Complete Submit OSPDP for mech materials | 81.25d | 2012-06-04 | 2012-08-19 | 1.4.4.1.010 SS+62.5d | 62.75d |
| 1.4.4.1.030 |  | Complete Submit OSPDP Telecomm materials | 72.5d | 2012-08-13 | 2012-10-20 | 1.4.4.1.020 SS+75d | 62.75d |
|  | 2 | **Submit O & M (Operating & Maintenance)** |  | 2012-04-07 | 2012-07-21 |  |  |
|  | 1 | **Submit O & M** |  | 2012-04-07 | 2012-07-21 |  |  |
| 1.4.4.2.010 |  | Submit O&M Documents | 112.5d | 2012-04-07 | 2012-07-21 | 1.4.4.1.010 SS | 67.75d |
|  | 3 | **Submit Approved Project Record Books** |  | 2012-07-21 | 2012-09-29 |  |  |
|  | 1 | **Submit Project Records Books** |  | 2012-07-21 | 2012-09-29 |  |  |
| 1.4.4.3.010 |  | Submit approved project record books | 75d | 2012-07-21 | 2012-09-29 | 1.4.4.2.010 | 85.25d |
|  | 4 | **Submit Pre-Commissioning Activities** |  | 2012-01-24 | 2012-04-02 |  |  |
|  | 1 | **Submit Pre-commissioning Activites** |  | 2012-01-24 | 2012-04-02 |  |  |
| 1.4.4.4.010 |  | Submit pre-commissioing activities for all facilities | 75d | 2012-01-24 | 2012-04-02 | 1.2.6.200, 1.2.8.010 SS | 99.25d |
|  | 5 | **Submit Red Lined Drawings** |  | 2012-10-21 | 2012-11-19 |  |  |
|  | 1 | **Submit red lined drawings** |  | 2012-10-21 | 2012-11-19 |  |  |
| 1.4.4.5.010 |  | Submit complete red lined as built drawings-civil | 31.25d | 2012-10-21 | 2012-11-18 | 1.4.4.2.010 SS+37.5d, 1.4.3.1.1.570, 1.4.3.1.2.560, 1.4.3.2.1.1340, M2.10, 1.4.3.1.2.570, M2.17, M2.14 | 30d |
| 1.4.4.5.020 |  | Submit complete red lined as built drawings-mech | 31.25d | 2012-10-21 | 2012-11-18 | 1.4.4.5.010 SS, 1.4.3.1.2.560, 1.4.3.1.1.570, 1.4.3.2.1.1340, 1.4.3.1.2.570, M2.10, M2.17, M2.14 | 30d |
| 1.4.4.5.030 |  | Submit complete red lined as built drawings-elect | 31.25d | 2012-10-21 | 2012-11-18 | 1.4.4.5.020 SS, 1.4.2.7.4.010, 1.4.2.7.4.020, 1.4.2.7.4.040, 1.4.2.7.4.050, 1.4.2.7.4.070, 1.4.2.7.4.072, 1.4.2.7.4.150, 1.4.2.7.4.152, 1.4.2.7.4.190, 1.4.2.7.4.192, 1.4.2.7.4.210, 1.4.2.7.4.212, 1.4.2.7.4.230 SS, 1.4.2.7.4.232 SS, 1.4.2.7.4.250 SS, 1.4.2.7.4.252 SS, 1.4.2.7.4.270 SS, 1.4.2.7.4.272 SS, 1.4.3.1.2.560, 1.4.3.1.1.570, 1.4.3.2.1.1340, 1.4.3.1.2.570, M2.10, M2.17, M2.14 | 30d |
| 1.4.4.5.040 |  | Submit complete red lined as built drawings-telecomm | 32.5d | 2012-10-21 | 2012-11-19 | 1.4.4.5.030 SS, 1.4.3.1.2.560, 1.4.3.1.1.570, 1.4.3.2.1.1340, 1.4.3.1.2.570, M2.10, M2.17, M2.14 | 30d |
|  | 7 | **MCC - Mechanical Completion Certificate** |  | 2012-12-18 | 2012-12-29 |  |  |
|  | 1 | **MCC** |  | 2012-12-18 | 2012-12-29 |  |  |
| 1.4.4.6.010 |  | Mechanical Completion of all works -MCC | 12.5d | 2012-12-18 | 2012-12-29 | 1.4.4.5.040, 1.4.4.3.010, 1.4.4.4.010, M2.20, M2.19, M2.17, M2.16, M2.15, M2.18, M2.09, M2.14, 1.4.3.1.1.780, M2.10, M2.11, M2.12, M2.13, Z1.1060, 1.4.2.5.3.110, 1.4.2.5.4.050, 1.4.3.1.1.570, 1.4.2.5.6.020D, 1.4.2.6.170, 1.4.2.6.120, 1.4.3.6.1.150, 1.4.3.7.1.140, 1.4.3.7.1.100, 1.4.3.5.1.140, 1.4.2.5.6.010D, 1.4.3.1.2.570 | 0d |
|  | 5 | **DEMOBILIZATION** |  | 2012-12-30 | 2013-06-29 |  |  |
|  | 1 | **Demobilization** |  | 2012-12-30 | 2013-06-29 |  |  |
|  | 1 | **Demobilization** |  | 2012-12-30 | 2013-06-29 |  |  |
| 1.4.5.1.010 |  | Remove Temporary gates & Jersey Barriers | 112.5d | 2012-12-30 | 2013-04-13 | 1.4.4.6.010 | 0d |
| 1.4.5.1.020 |  | Touch up of roads according to the existing roads | 37.5d | 2013-04-14 | 2013-05-18 | 1.4.5.1.010, M2.22 | 0d |
| 1.4.5.1.030 |  | Removal of temporary offices | 25d | 2013-05-19 | 2013-06-10 | 1.4.5.1.020 | 0d |
| 1.4.5.1.040 |  | Demobilization of equipments & manpower | 20d | 2013-06-11 | 2013-06-29 | 1.4.5.1.030 | 0d |

## Version 2 (data date 2012-10-04, saved 2012-10-06, file KAUST-Public Realm Area-04Oct2012.xer)

Last finish 2013-06-29 → 2014-01-04 (+189d). Complete tasks 0 → 424.

Added:

| ID | Task | Duration | Start | Finish | Predecessors | Resources |
| --- | --- | --- | --- | --- | --- | --- |
| 1 | **CIVIL / STRUCTURAL / ARCHITECTURAL / ROAD WORKS** |  | 2011-01-12 | 2012-11-03 |  |  |
| 2 | **ELECTRICAL / INSTRUMENTATION WORKS** |  | 2011-03-12 | 2012-07-23 |  |  |
| 2 | **MCP -Motor Control Panel** |  | 2011-09-28 | 2012-06-02 |  |  |
| 1.3.2.2.010 | Place PO for Motor Control Panel | 37.5d | 2011-09-28 A | 2011-11-01 A | 1.3.2.1.010 SS+33.75d | SSH-Procurement Manhours |
| 1.3.2.2.020 | Delivery of MCP | 7.5d | 2012-05-21 A | 2012-05-27 A | 1.3.2.2.010 FS+215d | SSH-Procurement Manhours |
| 3 | **SECURITY / COMMUNICATION WORKS** |  | 2011-09-28 | 2012-07-29 |  |  |
| 16 | **Code Blue System Materials** |  | 2011-12-11 | 2012-04-18 |  |  |
| 1.3.3.16.010 | Place PO for Code Blue System Materials | 38d | 2011-12-11 A | 2012-01-15 A | 1.3.3.13.010 SS |  |
| 1.3.3.16.020 | Delivery of Code Blue System Materials | 6d | 2012-04-08 A | 2012-04-14 A | 1.3.3.16.010 FS+90d |  |
| 17 | **UTP Cables & Patch Panels with Accs** |  | 2012-02-18 | 2012-07-05 |  |  |
| 1.3.3.17.010 | Place PO UTP Cables & Patch Panels with accessories | 38d | 2012-02-18 A | 2012-03-24 A | 1.3.3.16.010 |  |
| 1.3.3.17.020 | Delivery of UTP Cables & Patch Panels with accessories | 6d | 2012-06-25 A | 2012-07-01 A | 1.3.3.17.010 FS+100d |  |
| 18 | **Cable Vault & MDF Materials** |  | 2012-03-03 | 2012-07-05 |  |  |
| 1.3.3.18.010 | Place PO for Comm Cable Vault & MDF Materials | 38d | 2012-03-03 A | 2012-04-07 A | 1.3.3.17.010 SS+15d |  |
| 1.3.3.18.020 | Delivery of Comm Cable Vault & MDF Materials | 6d | 2012-06-30 A | 2012-07-05 A | 1.3.3.18.010 FS+90d |  |
| 4 | **MECHANICAL / PLUMBING / HVAC WORKS** |  | 2011-06-19 | 2012-09-20 |  |  |
| 1 | **Potable / Fire water /Sewer Pipes (RTR)/(GRE) & Fittings** |  | 2011-08-13 | 2012-02-28 |  |  |
| 1.3.4.14.030 | Provision of startup spare parts & Non-material-req'ts | 6d | 2012-08-20 A | 2012-08-26 A | 1.3.4.14.020 | SSH-Procurement Manhours |
| 1.3.4.15.030 | Provision of startup spare parts & Non-material-req'ts | 10d | 2012-04-16 A | 2012-04-24 A | 1.3.4.15.020 | SSH-Procurement Manhours |
| 1.3.4.16.030 | Provision of startup spare parts & Non-material-req'ts | 10d | 2012-05-23 A | 2012-05-31 A | 1.3.4.16.020 | SSH-Procurement Manhours |
| 1.4.2.3.5.151 | Install Instruments & Local control panel & accs | 30d | 2013-02-19 | 2013-03-18 | 1.4.2.3.5.150 FF | SSH-Construction Manhours [1115.97 h] |
| 1.4.2.3.5.152 | Install odour control system cabling and instruments | 30d | 2013-02-19 | 2013-03-18 | 1.4.2.3.5.151 FF | SSH-Construction Manhours [1115.97 h] |
| 1.4.2.3.6.151 | Install Instruments & local control panel & accs | 30d | 2012-12-29 | 2013-01-26 | 1.4.2.3.6.150 FF | SSH-Construction Manhours [976.48 h] |
| 1.4.2.3.6.152 | Install odour control system cabling & instruments | 30d | 2012-12-29 | 2013-01-26 | 1.4.2.3.6.151 FF | SSH-Construction Manhours [976.48 h] |
| 1.4.2.3.7.151 | Install instruments & local control panel & accs | 30d | 2013-02-26 | 2013-03-25 | 1.4.2.3.7.150 FF | SSH-Construction Manhours [948.58 h] |
| 1.4.2.3.7.152 | Install odour control system cabling & instruments | 30d | 2013-02-26 | 2013-03-25 | 1.4.2.3.7.151 FF | SSH-Construction Manhours [948.58 h] |
| 1.4.2.3.8.151 | Install instruments & local control panel & accs | 30d | 2013-03-13 | 2013-04-09 | 1.4.2.3.8.150 FF | SSH-Construction Manhours [1171.77 h] |
| 1.4.2.3.8.152 | Install odour control system cabling & instruments | 30d | 2013-03-13 | 2013-04-09 | 1.4.2.3.8.151 FF | SSH-Construction Manhours [1171.77 h] |
| 3 | **Storm Water Drainage System** |  | 2012-03-04 | 2013-05-23 |  |  |
| 1.4.1.3.1.005 | Fabrication/Casting of Jersey Barriers | 1d | 2011-01-28 A | 2011-10-13 A | 1.4.1.1.110 SS | SSH-Construction Manhours [66624.3 h] |
| 4 | **Curbs & gutters** |  | 2012-11-14 | 2013-04-17 |  |  |
| 5 | **Landscaping & Hardscaping in Public Realm Area - Zone 3** |  | 2011-12-05 | 2013-07-03 |  |  |
| 1 | **Segment 1** |  | 2011-12-05 | 2013-04-20 |  |  |
| 1.4.2.6.1.020 | Leveling / Compaction upto desired level | 20d | 2011-12-15 A | 2012-01-25 A | 1.4.2.6.1.010 SS | SSH-Construction Manhours [1851.56 h] |
| 1.4.2.6.1.080 | Excavation of electric cable trench | 15d | 2012-03-08 A | 2012-11-07 | 1.4.2.6.1.070 FF+2d | SSH-Construction Manhours [1110.93 h] |
| 1.4.2.6.1.090 | Casting of electrical ductbanks | 15d | 2012-03-13 A | 2012-11-12 | 1.4.2.6.1.080 FF+5d | SSH-Construction Manhours [1851.56 h] |
| 1.4.2.6.1.130 | Excavation for Telecomm Trench | 15d | 2012-03-26 A | 2012-11-25 | 1.4.2.6.1.110 FF+5d | SSH-Construction Manhours [1110.93 h] |
| 1.4.2.6.1.140 | Casting of telecomm ductbanks | 20d | 2012-03-31 A | 2012-12-04 | 1.4.2.6.1.130 FF+10d | SSH-Construction Manhours [1851.56 h] |
| 1.4.2.6.1.030 | Excavation of water line / irrigation line trench | 15d | 2012-10-04 | 2012-10-17 | 1.4.2.6.1.020 FF | SSH-Construction Manhours [1110.93 h] |
| 1.4.2.6.1.040 | Installation of pipes & fittings | 15d | 2012-10-09 | 2012-10-22 | 1.4.2.6.1.030 FF+5d | SSH-Construction Manhours [5554.67 h] |
| 1.4.2.6.1.050 | Hydrotesting of pipes | 10d | 2012-10-23 | 2012-10-31 | 1.4.2.6.1.040 | SSH-Construction Manhours [740.62 h] |
| 1.4.2.6.1.070 | Backfilling | 10d | 2012-10-28 | 2012-11-05 | 1.4.2.6.1.050 FF+5d | SSH-Construction Manhours [370.31 h] |
| 1.4.2.6.1.100 | Install cables (LV, MV, Grounding, Irrigation) | 20d | 2012-10-29 | 2012-11-17 | 1.4.2.6.1.090 FF+5d | SSH-Construction Manhours [4443.74 h] |
| 1.4.2.6.1.110 | Backfilling | 10d | 2012-11-11 | 2012-11-20 | 1.4.2.6.1.100 FF+4d | SSH-Construction Manhours [370.31 h] |
| 1.4.2.6.1.160 | Backfilling | 10d | 2012-11-29 | 2012-12-09 | 1.4.2.6.1.140 FF+5d | SSH-Construction Manhours [370.31 h] |
| 1.4.2.6.1.180 | Laying of basecourse for bicycle segway & electric cart lane | 15d | 2013-03-04 | 2013-03-18 | 1.4.2.6.1.160, 1.4.2.6.5.160 | SSH-Construction Manhours [740.62 h] |
| 1.4.2.6.1.190 | Casting of curbs & gutters | 15d | 2013-03-09 | 2013-03-23 | 1.4.2.6.1.180 FF+5d | SSH-Construction Manhours [1110.93 h] |
| 1.4.2.6.1.060 | Install control valves sprinklers & accs | 15d | 2013-03-18 | 2013-04-01 | 1.4.2.6.1.050, 1.4.2.6.1.180 | SSH-Construction Manhours [1481.25 h] |
| 1.4.2.6.1.120 | Install solar globe lighting & package Substaion | 20d | 2013-03-18 | 2013-04-06 | 1.4.2.6.1.180 | SSH-Construction Manhours [740.62 h] |
| 1.4.2.6.1.150 | Pulling of subduct, copper cable & Fiber optic cable | 20d | 2013-03-18 | 2013-04-06 | 1.4.2.6.1.180 | SSH-Construction Manhours [4443.74 h] |
| 1.4.2.6.1.200 | Casting of concrete pavement | 10d | 2013-03-18 | 2013-03-27 | 1.4.2.6.1.190 FF+5d | SSH-Construction Manhours [1110.93 h] |
| 1.4.2.6.1.210 | Installation of walkways | 15d | 2013-03-18 | 2013-04-01 | 1.4.2.6.1.200 FF+5d | SSH-Construction Manhours [1481.25 h] |
| 1.4.2.6.1.220 | Install benches, signage & accs | 15d | 2013-03-23 | 2013-04-06 | 1.4.2.6.1.210 FF+5d, 1.3.1.22.020, 1.3.1.24.030 | SSH-Construction Manhours [370.31 h] |
| 1.4.2.6.1.230 | Install natural boulders | 15d | 2013-03-27 | 2013-04-10 | 1.4.2.6.1.220 FF+5d | SSH-Construction Manhours [1110.93 h] |
| 1.4.2.6.1.240 | Laying of gravel mulch | 15d | 2013-04-01 | 2013-04-15 | 1.4.2.6.1.230 FF+5d, 1.3.1.23.030 | SSH-Construction Manhours [740.62 h] |
| 1.4.2.6.1.170 | Installation of IPCCTV camera (Footings, poles & etc) | 15d | 2013-04-06 | 2013-04-20 | 1.4.2.6.1.150 | SSH-Construction Manhours [1481.25 h] |
| 1.4.2.6.1.250 | Planting of shrubs & trees | 15d | 2013-04-06 | 2013-04-20 | 1.4.2.6.1.240 FF+5d, 1.4.2.6.1.170 FF | SSH-Construction Manhours [603.11 h] |
| 2 | **Segment 2** |  | 2011-12-05 | 2013-05-04 |  |  |
| 1.4.2.6.2.010 | Site grading/clearing/grubbing | 20d | 2011-12-05 A | 2011-12-28 A | 1.4.2.6.1.010 SS | SSH-Construction Manhours [740.62 h]; Grader [600 h]; Dump Truck [600 h] |
| 1.4.2.6.2.020 | Leveling / Compaction upto desired level | 20d | 2011-12-15 A | 2012-01-25 A | 1.4.2.6.2.010 SS | SSH-Construction Manhours [1851.56 h] |
| 1.4.2.6.2.030 | Excavation of water line / irrigation line trench | 15d | 2012-03-21 A | 2012-11-15 | 1.4.2.6.2.020 FF, 1.4.2.6.1.070 | SSH-Construction Manhours [1110.93 h] |
| 1.4.2.6.2.080 | Excavation of electric cable trench | 15d | 2012-04-10 A | 2012-04-24 A | 1.4.2.6.2.070 FF+2d | SSH-Construction Manhours [1110.93 h] |
| 1.4.2.6.2.130 | Excavation for Telecomm Trench | 15d | 2012-04-28 A | 2012-05-12 A | 1.4.2.6.2.110 FF+5d | SSH-Construction Manhours [1110.93 h] |
| 1.4.2.6.2.140 | Casting of telecomm ductbanks | 20d | 2012-05-02 A | 2012-05-21 A | 1.4.2.6.2.130 FF+10d | SSH-Construction Manhours [1851.56 h] |
| 1.4.2.6.2.160 | Backfilling | 10d | 2012-05-16 A | 2012-12-19 | 1.4.2.6.2.140 FF+5d | SSH-Construction Manhours [370.31 h] |
| 1.4.2.6.2.040 | Installation of pipes & fittings | 15d | 2012-11-07 | 2012-11-20 | 1.4.2.6.2.030 FF+5d | SSH-Construction Manhours [5554.67 h] |
| 1.4.2.6.2.050 | Hydrotesting of pipes | 10d | 2012-11-21 | 2012-11-29 | 1.4.2.6.2.040 | SSH-Construction Manhours [740.62 h] |
| 1.4.2.6.2.090 | Casting of electrical ductbanks | 15d | 2012-11-22 | 2012-12-06 | 1.4.2.6.2.080 FF+5d | SSH-Construction Manhours [1851.56 h] |
| 1.4.2.6.2.100 | Install cables (LV, MV, Grounding, Irrigation) | 20d | 2012-11-22 | 2012-12-11 | 1.4.2.6.2.090 FF+5d | SSH-Construction Manhours [4443.74 h] |
| 1.4.2.6.2.070 | Backfilling | 10d | 2012-11-26 | 2012-12-04 | 1.4.2.6.2.050 FF+5d | SSH-Construction Manhours [370.31 h] |
| 1.4.2.6.2.110 | Backfilling | 10d | 2012-12-05 | 2012-12-15 | 1.4.2.6.2.100 FF+4d | SSH-Construction Manhours [370.31 h] |
| 1.4.2.6.2.180 | Laying of basecourse for bicycle segway & electric cart lane | 15d | 2013-03-18 | 2013-04-01 | 1.4.2.6.2.160, 1.4.2.6.1.180 | SSH-Construction Manhours [740.62 h] |
| 1.4.2.6.2.190 | Casting of curbs & gutters | 15d | 2013-03-23 | 2013-04-06 | 1.4.2.6.2.180 FF+5d | SSH-Construction Manhours [1110.93 h] |
| 1.4.2.6.2.060 | Install control valves sprinklers & accs | 15d | 2013-04-01 | 2013-04-15 | 1.4.2.6.2.180, 1.4.2.6.2.050 | SSH-Construction Manhours [1481.25 h] |
| 1.4.2.6.2.120 | Install solar globe lighting & package Substaion | 20d | 2013-04-01 | 2013-04-20 | 1.4.2.6.2.180 | SSH-Construction Manhours [740.62 h] |
| 1.4.2.6.2.150 | Pulling of subduct, copper cable & Fiber optic cable | 20d | 2013-04-01 | 2013-04-20 | 1.4.2.6.2.180 | SSH-Construction Manhours [4443.74 h] |
| 1.4.2.6.2.170 | Installation of IPCCTV camera (Footings, poles & etc) | 15d | 2013-04-01 | 2013-04-15 | 1.4.2.6.2.180 | SSH-Construction Manhours [1481.25 h] |
| 1.4.2.6.2.200 | Casting of concrete pavement | 10d | 2013-04-01 | 2013-04-10 | 1.4.2.6.2.190 FF+5d | SSH-Construction Manhours [1110.93 h] |
| 1.4.2.6.2.210 | Installation of walkways | 15d | 2013-04-01 | 2013-04-15 | 1.4.2.6.2.200 FF+5d | SSH-Construction Manhours [1481.25 h] |
| 1.4.2.6.2.220 | Install benches, signage & accs | 15d | 2013-04-06 | 2013-04-20 | 1.4.2.6.2.210 FF+5d | SSH-Construction Manhours [370.31 h] |
| 1.4.2.6.2.230 | Install natural boulders | 15d | 2013-04-10 | 2013-04-24 | 1.4.2.6.2.220 FF+5d | SSH-Construction Manhours [1110.93 h] |
| 1.4.2.6.2.240 | Laying of gravel mulch | 15d | 2013-04-15 | 2013-04-29 | 1.4.2.6.2.230 FF+5d | SSH-Construction Manhours [740.62 h] |
| 1.4.2.6.2.250 | Planting of shrubs & trees | 15d | 2013-04-20 | 2013-05-04 | 1.4.2.6.2.240 FF+5d, 1.4.2.6.2.170 FF | SSH-Construction Manhours [603.11 h] |
| 3 | **Segment 3** |  | 2012-04-18 | 2013-05-18 |  |  |
| 1.4.2.6.3.010 | Site grading/clearing/grubbing | 20d | 2012-04-18 A | 2012-05-06 A | 1.4.2.6.2.050 | SSH-Construction Manhours [740.62 h]; Grader [600 h]; Dump Truck [600 h] |
| 1.4.2.6.3.020 | Leveling / Compaction upto desired level | 20d | 2012-04-28 A | 2012-05-15 A | 1.4.2.6.3.010 FF+10d | SSH-Construction Manhours [1851.56 h] |
| 1.4.2.6.3.030 | Excavation of water line / irrigation line trench | 15d | 2012-05-02 A | 2012-05-15 A | 1.4.2.6.3.020 FF | SSH-Construction Manhours [1110.93 h] |
| 1.4.2.6.3.040 | Installation of pipes & fittings | 15d | 2012-05-07 A | 2012-11-29 | 1.4.2.6.3.030 FF+5d | SSH-Construction Manhours [5554.67 h] |
| 1.4.2.6.3.080 | Excavation of electric cable trench | 15d | 2012-05-22 A | 2012-06-05 A | 1.4.2.6.3.070 FF+2d | SSH-Construction Manhours [1110.93 h] |
| 1.4.2.6.3.070 | Backfilling | 10d | 2012-05-26 A | 2012-12-13 | 1.4.2.6.3.050 FF+5d | SSH-Construction Manhours [370.31 h] |
| 1.4.2.6.3.130 | Excavation for Telecomm Trench | 15d | 2012-06-09 A | 2012-06-23 A | 1.4.2.6.3.110 FF+5d | SSH-Construction Manhours [1110.93 h] |
| 1.4.2.6.3.140 | Casting of telecomm ductbanks | 20d | 2012-06-13 A | 2012-07-02 A | 1.4.2.6.3.130 FF+10d | SSH-Construction Manhours [1851.56 h] |
| 1.4.2.6.3.050 | Hydrotesting of pipes | 10d | 2012-12-01 | 2012-12-09 | 1.4.2.6.3.040 | SSH-Construction Manhours [740.62 h] |
| 1.4.2.6.3.090 | Casting of electrical ductbanks | 15d | 2012-12-02 | 2012-12-16 | 1.4.2.6.3.080 FF+5d | SSH-Construction Manhours [1851.56 h] |
| 1.4.2.6.3.100 | Install cables (LV, MV, Grounding, Irrigation) | 20d | 2012-12-02 | 2012-12-20 | 1.4.2.6.3.090 FF+5d | SSH-Construction Manhours [4443.74 h] |
| 1.4.2.6.3.110 | Backfilling | 10d | 2012-12-15 | 2012-12-24 | 1.4.2.6.3.100 FF+4d | SSH-Construction Manhours [370.31 h] |
| 1.4.2.6.3.160 | Backfilling | 10d | 2012-12-19 | 2012-12-29 | 1.4.2.6.3.140 FF+5d | SSH-Construction Manhours [370.31 h] |
| 1.4.2.6.3.180 | Laying of basecourse for bicycle segway & electric cart lane | 15d | 2013-04-01 | 2013-04-15 | 1.4.2.6.3.160, 1.4.2.6.2.180 | SSH-Construction Manhours [740.62 h] |
| 1.4.2.6.3.190 | Casting of curbs & gutters | 15d | 2013-04-06 | 2013-04-20 | 1.4.2.6.3.180 FF+5d | SSH-Construction Manhours [1110.93 h] |
| 1.4.2.6.3.060 | Install control valves sprinklers & accs | 15d | 2013-04-15 | 2013-04-29 | 1.4.2.6.3.180, 1.4.2.6.3.050 | SSH-Construction Manhours [1481.25 h] |
| 1.4.2.6.3.120 | Install solar globe lighting & package Substaion | 20d | 2013-04-15 | 2013-05-04 | 1.4.2.6.3.180 | SSH-Construction Manhours [740.62 h] |
| 1.4.2.6.3.150 | Pulling of subduct, copper cable & Fiber optic cable | 20d | 2013-04-15 | 2013-05-04 | 1.4.2.6.3.180 | SSH-Construction Manhours [4443.74 h] |
| 1.4.2.6.3.170 | Installation of IPCCTV camera (Footings, poles & etc) | 15d | 2013-04-15 | 2013-04-29 | 1.4.2.6.3.180 | SSH-Construction Manhours [1481.25 h] |
| 1.4.2.6.3.200 | Casting of concrete pavement | 10d | 2013-04-15 | 2013-04-24 | 1.4.2.6.3.190 FF+5d | SSH-Construction Manhours [1110.93 h] |
| 1.4.2.6.3.210 | Installation of walkways | 15d | 2013-04-15 | 2013-04-29 | 1.4.2.6.3.200 FF+5d | SSH-Construction Manhours [1481.25 h] |
| 1.4.2.6.3.220 | Install benches, signage & accs | 15d | 2013-04-20 | 2013-05-04 | 1.4.2.6.3.210 FF+5d | SSH-Construction Manhours [370.31 h] |
| 1.4.2.6.3.230 | Install natural boulders | 15d | 2013-04-24 | 2013-05-08 | 1.4.2.6.3.220 FF+5d | SSH-Construction Manhours [1110.93 h] |
| 1.4.2.6.3.240 | Laying of gravel mulch | 15d | 2013-04-29 | 2013-05-13 | 1.4.2.6.3.230 FF+5d | SSH-Construction Manhours [740.62 h] |
| 1.4.2.6.3.250 | Planting of shrubs & trees | 15d | 2013-05-04 | 2013-05-18 | 1.4.2.6.3.240 FF+5d, 1.4.2.6.3.170 FF | SSH-Construction Manhours [603.11 h] |
| 4 | **Segment 4** |  | 2012-05-21 | 2013-06-01 |  |  |
| 1.4.2.6.4.010 | Site grading/clearing/grubbing | 20d | 2012-05-21 A | 2012-06-07 A | 1.4.2.6.3.050 FF+10d | SSH-Construction Manhours [740.62 h]; Grader [600 h]; Dump Truck [600 h] |
| 1.4.2.6.4.020 | Leveling / Compaction upto desired level | 20d | 2012-05-30 A | 2012-06-17 A | 1.4.2.6.4.010 FF+10d | SSH-Construction Manhours [1851.56 h] |
| 1.4.2.6.4.030 | Excavation of water line / irrigation line trench | 15d | 2012-06-04 A | 2012-12-18 | 1.4.2.6.4.020 FF | SSH-Construction Manhours [1110.93 h] |
| 1.4.2.6.4.040 | Installation of pipes & fittings | 15d | 2012-06-09 A | 2012-12-23 | 1.4.2.6.4.030 FF+5d | SSH-Construction Manhours [5554.67 h] |
| 1.4.2.6.4.080 | Excavation of electric cable trench | 15d | 2012-06-24 A | 2013-01-08 | 1.4.2.6.4.070 FF+2d | SSH-Construction Manhours [1110.93 h] |
| 1.4.2.6.4.070 | Backfilling | 10d | 2012-06-27 A | 2013-01-06 | 1.4.2.6.4.050 FF+5d | SSH-Construction Manhours [370.31 h] |
| 1.4.2.6.4.090 | Casting of electrical ductbanks | 15d | 2012-06-28 A | 2013-01-13 | 1.4.2.6.4.080 FF+5d | SSH-Construction Manhours [1851.56 h] |
| 1.4.2.6.4.110 | Backfilling | 10d | 2012-07-11 A | 2013-01-21 | 1.4.2.6.4.100 FF+4d | SSH-Construction Manhours [370.31 h] |
| 1.4.2.6.4.130 | Excavation for Telecomm Trench | 15d | 2012-07-11 A | 2013-01-26 | 1.4.2.6.4.110 FF+5d | SSH-Construction Manhours [1110.93 h] |
| 1.4.2.6.4.140 | Casting of telecomm ductbanks | 20d | 2012-07-16 A | 2013-02-04 | 1.4.2.6.4.130 FF+10d | SSH-Construction Manhours [1851.56 h] |
| 1.4.2.6.4.050 | Hydrotesting of pipes | 10d | 2012-12-24 | 2013-01-01 | 1.4.2.6.4.040 | SSH-Construction Manhours [740.62 h] |
| 1.4.2.6.4.100 | Install cables (LV, MV, Grounding, Irrigation) | 20d | 2012-12-30 | 2013-01-17 | 1.4.2.6.4.090 FF+5d | SSH-Construction Manhours [4443.74 h] |
| 1.4.2.6.4.160 | Backfilling | 10d | 2013-01-30 | 2013-02-09 | 1.4.2.6.4.140 FF+5d | SSH-Construction Manhours [370.31 h] |
| 1.4.2.6.4.180 | Laying of basecourse for bicycle segway & electric cart lane | 15d | 2013-04-15 | 2013-04-29 | 1.4.2.6.4.160, 1.4.2.6.3.180 | SSH-Construction Manhours [740.62 h] |
| 1.4.2.6.4.190 | Casting of curbs & gutters | 15d | 2013-04-20 | 2013-05-04 | 1.4.2.6.4.180 FF+5d | SSH-Construction Manhours [1110.93 h] |
| 1.4.2.6.4.060 | Install control valves sprinklers & accs | 15d | 2013-04-29 | 2013-05-13 | 1.4.2.6.4.180, 1.4.2.6.4.050 | SSH-Construction Manhours [1481.25 h] |
| 1.4.2.6.4.120 | Install solar globe lighting & package Substaion | 20d | 2013-04-29 | 2013-05-18 | 1.4.2.6.4.180 | SSH-Construction Manhours [740.62 h] |
| 1.4.2.6.4.150 | Pulling of subduct, copper cable & Fiber optic cable | 20d | 2013-04-29 | 2013-05-18 | 1.4.2.6.4.180 | SSH-Construction Manhours [4443.74 h] |
| 1.4.2.6.4.170 | Installation of IPCCTV camera (Footings, poles & etc) | 15d | 2013-04-29 | 2013-05-13 | 1.4.2.6.4.180 | SSH-Construction Manhours [1481.25 h] |
| 1.4.2.6.4.200 | Casting of concrete pavement | 10d | 2013-04-29 | 2013-05-08 | 1.4.2.6.4.190 FF+5d | SSH-Construction Manhours [1110.93 h] |
| 1.4.2.6.4.210 | Installation of walkways | 15d | 2013-04-29 | 2013-05-13 | 1.4.2.6.4.200 FF+5d | SSH-Construction Manhours [1481.25 h] |
| 1.4.2.6.4.220 | Install benches, signage & accs | 15d | 2013-05-04 | 2013-05-18 | 1.4.2.6.4.210 FF+5d | SSH-Construction Manhours [370.31 h] |
| 1.4.2.6.4.230 | Install natural boulders | 15d | 2013-05-08 | 2013-05-22 | 1.4.2.6.4.220 FF+5d | SSH-Construction Manhours [1110.93 h] |
| 1.4.2.6.4.240 | Laying of gravel mulch | 15d | 2013-05-13 | 2013-05-27 | 1.4.2.6.4.230 FF+5d | SSH-Construction Manhours [740.62 h] |
| 1.4.2.6.4.250 | Planting of shrubs & trees | 15d | 2013-05-18 | 2013-06-01 | 1.4.2.6.4.240 FF+5d, 1.4.2.6.4.170 FF | SSH-Construction Manhours [603.11 h] |
| 5 | **Segment 5** |  | 2012-06-23 | 2013-07-03 |  |  |
| 1.4.2.6.5.010 | Site grading/clearing/grubbing | 20d | 2012-06-23 A | 2012-07-10 A | 1.4.2.6.4.050 FF+10d | SSH-Construction Manhours [740.62 h]; Grader [600 h]; Dump Truck [600 h] |
| 1.4.2.6.5.020 | Leveling / Compaction upto desired level | 20d | 2012-07-02 A | 2013-01-10 | 1.4.2.6.5.010 FF+10d | SSH-Construction Manhours [1851.56 h] |
| 1.4.2.6.5.050 | Hydrotesting of pipes | 10d | 2012-07-25 A | 2013-01-24 | 1.4.2.6.5.040 | SSH-Construction Manhours [740.62 h] |
| 1.4.2.6.5.160 | Backfilling | 10d | 2012-09-01 A | 2013-03-04 | 1.4.2.6.5.140 FF+5d | SSH-Construction Manhours [370.31 h] |
| 1.4.2.6.5.030 | Excavation of water line / irrigation line trench | 15d | 2012-12-29 | 2013-01-10 | 1.4.2.6.5.020 FF | SSH-Construction Manhours [1110.93 h] |
| 1.4.2.6.5.040 | Installation of pipes & fittings | 15d | 2013-01-02 | 2013-01-15 | 1.4.2.6.5.030 FF+5d | SSH-Construction Manhours [5554.67 h] |
| 1.4.2.6.5.080 | Excavation of electric cable trench | 15d | 2013-01-17 | 2013-01-31 | 1.4.2.6.5.070 FF+2d | SSH-Construction Manhours [1110.93 h] |
| 1.4.2.6.5.070 | Backfilling | 10d | 2013-01-21 | 2013-01-29 | 1.4.2.6.5.050 FF+5d | SSH-Construction Manhours [370.31 h] |
| 1.4.2.6.5.090 | Casting of electrical ductbanks | 15d | 2013-01-22 | 2013-02-05 | 1.4.2.6.5.080 FF+5d | SSH-Construction Manhours [1851.56 h] |
| 1.4.2.6.5.100 | Install cables (LV, MV, Grounding, Irrigation) | 20d | 2013-01-22 | 2013-02-10 | 1.4.2.6.5.090 FF+5d | SSH-Construction Manhours [4443.74 h] |
| 1.4.2.6.5.110 | Backfilling | 10d | 2013-02-04 | 2013-02-13 | 1.4.2.6.5.100 FF+4d | SSH-Construction Manhours [370.31 h] |
| 1.4.2.6.5.130 | Excavation for Telecomm Trench | 15d | 2013-02-04 | 2013-02-18 | 1.4.2.6.5.110 FF+5d | SSH-Construction Manhours [1110.93 h] |
| 1.4.2.6.5.140 | Casting of telecomm ductbanks | 20d | 2013-02-09 | 2013-02-27 | 1.4.2.6.5.130 FF+10d | SSH-Construction Manhours [1851.56 h] |
| 1.4.2.6.5.180 | Laying of basecourse for bicycle segway & electric cart lane | 15d | 2013-04-29 | 2013-05-13 | 1.4.2.6.5.160, 1.4.2.6.4.180 | SSH-Construction Manhours [740.62 h] |
| 1.4.2.6.5.190 | Casting of curbs & gutters | 15d | 2013-05-04 | 2013-05-18 | 1.4.2.6.5.180 FF+5d | SSH-Construction Manhours [1110.93 h] |
| 1.4.2.6.5.060 | Install control valves sprinklers & accs | 15d | 2013-05-13 | 2013-05-27 | 1.4.2.6.5.180 | SSH-Construction Manhours [1481.25 h] |
| 1.4.2.6.5.120 | Install solar globe lighting & package Substaion | 20d | 2013-05-13 | 2013-06-01 | 1.4.2.6.5.180 | SSH-Construction Manhours [740.62 h] |
| 1.4.2.6.5.150 | Pulling of subduct, copper cable & Fiber optic cable | 20d | 2013-05-13 | 2013-06-01 | 1.4.2.6.5.180 | SSH-Construction Manhours [4443.74 h] |
| 1.4.2.6.5.170 | Installation of IPCCTV camera (Footings, poles & etc) | 15d | 2013-05-13 | 2013-05-27 | 1.4.2.6.5.180 | SSH-Construction Manhours [1481.25 h] |
| 1.4.2.6.5.200 | Casting of concrete pavement | 10d | 2013-05-13 | 2013-05-22 | 1.4.2.6.5.190 FF+5d | SSH-Construction Manhours [1110.93 h] |
| 1.4.2.6.5.210 | Installation of walkways | 15d | 2013-05-13 | 2013-05-27 | 1.4.2.6.5.200 FF+5d | SSH-Construction Manhours [1481.25 h] |
| 1.4.2.6.5.220 | Install benches, signage & accs | 15d | 2013-05-18 | 2013-06-01 | 1.4.2.6.5.210 FF+5d | SSH-Construction Manhours [370.31 h] |
| 1.4.2.6.5.230 | Install natural boulders | 15d | 2013-05-22 | 2013-06-05 | 1.4.2.6.5.220 FF+5d | SSH-Construction Manhours [1110.93 h] |
| 1.4.2.6.5.240 | Laying of gravel mulch | 15d | 2013-05-27 | 2013-06-10 | 1.4.2.6.5.230 FF+5d | SSH-Construction Manhours [740.62 h] |
| 1.4.2.6.5.250 | Planting of shrubs & trees | 15d | 2013-06-01 | 2013-06-15 | 1.4.2.6.5.240 FF+5d, 1.4.2.6.5.170 FF | SSH-Construction Manhours [603.11 h] |
| 1.4.2.6.5.260 | Testing & Commissioning all works - Public Realm Area | 20d | 2013-06-15 | 2013-07-03 | 1.4.2.6.5.250 FF+7d, 1.4.2.6.1.060, 1.4.2.6.1.120, 1.4.2.6.1.170, 1.4.2.6.2.060, 1.4.2.6.2.120, 1.4.2.6.2.150, 1.4.2.6.3.060, 1.4.2.6.3.120, 1.4.2.6.3.150, 1.4.2.6.4.060, 1.4.2.6.4.120, 1.4.2.6.4.150, 1.4.2.6.5.060, 1.4.2.6.5.120, 1.4.2.6.5.150, 1.4.2.7.3.050 | SSH-Construction Manhours [1887.74 h] |
| 1 | **DuctBanks** |  | 2011-12-28 | 2013-01-30 |  |  |
| 1.4.2.7.700 | Excavation of MV cable trench zone2 | 45d | 2011-12-03 A | 2012-10-08 | 1.4.2.7.200 SS | SSH-Construction Manhours [1271.53 h] |
| 1.4.2.7.710 | Install MV cable zone 2 | 45d | 2011-12-20 A | 2012-10-08 | 1.4.2.7.700 SS | SSH-Construction Manhours [12784.2 h] |
| 1.4.2.7.720 | Excavation of MV cable for SEC Substation | 90d | 2012-03-13 A | 2012-11-19 | 1.4.2.7.710 | SSH-Construction Manhours [1274.48 h] |
| 1.4.2.7.730 | Install MV cable zone 2 towards SEC SS | 90d | 2012-04-24 A | 2012-12-31 | 1.4.2.7.720 FF+45d | SSH-Construction Manhours [13442.5 h] |
| 02 | **LV Cables -(For Permanent Roads & CCTV Camera network)** |  | 2012-05-23 | 2013-05-11 |  |  |
| 1.4.2.7.2.091 | Install CCTV camera poles & CCTV Cameras | 120d | 2013-01-09 | 2013-05-01 | 1.4.2.7.2.080 FF+15d | SSH-Construction Manhours [1476.23 h] |
| 1.4.2.7.2.092 | Testing & Commissioning of CCTV System | 60d | 2013-03-16 | 2013-05-11 | 1.4.2.7.2.090 FF+10d, 1.4.2.7.2.091 FF+10d | SSH-Construction Manhours [492.08 h] |
| 05 | **Electrcial Equipments & Power Cables** |  | 2012-05-23 | 2013-05-08 |  |  |
| 2 | **Package Substations (For all zones)** |  | 2012-05-23 | 2013-05-08 |  |  |
| 1.4.2.7.4.065 | Install package substation zone4 | 38d | 2013-04-03 | 2013-05-08 | 1.4.2.7.4.055 FF, 1.4.2.7.4.050 FF, 1.3.2.3.020 | SSH-Construction Manhours [602.3 h] |
| 1.4.2.7.4.085 | Testing & commissioning of package substation | 31d | 2013-04-10 | 2013-05-08 | 1.4.2.7.4.065 FF | SSH-Construction Manhours [246.04 h] |
| 3 | **RMU (For all zones)** |  | 2012-05-23 | 2013-04-13 |  |  |
| 1.4.2.8.1.051 | Install CCTV System & accs | 60d | 2012-10-14 | 2012-12-08 | 1.4.2.8.1.050 FF+10d, 1.3.3.14.020 | SSH-Construction Manhours [3636.05 h] |
| 1.4.2.8.1.130 | Testing & Commissioning of Code Blue System | 20d | 2012-11-29 | 2012-12-17 | 1.4.2.8.1.050 | SSH-Construction Manhours [1990.66 h] |
| 1.4.2.8.1.150 | Testing & Commissioning of CCTV System | 12d | 2012-12-09 | 2012-12-19 | 1.4.2.8.1.055 FF+10d, 1.4.2.8.1.051 | SSH-Construction Manhours [1990.66 h] |
| 1 | **Exchange Building** |  | 2011-10-02 | 2013-03-05 |  |  |
| 7 | **MDF & Cable Vault** |  | 2012-12-09 | 2013-02-20 |  |  |
| 1.4.4.6.020 | Complete AS built CAD work & Intergraph CADD | 32d | 2013-07-06 | 2013-08-05 | 1.4.4.6.010 FF+2d | SSH-Construction Manhours [12725.6 h] |

Removed: Categories 1; Categories 2; Categories 3; Categories 4; Categories 5; Categories 6; Categories 7; Categories 8; Categories 9; CIVIL WORKS; Civil Works & Road Related Materials; ELECTRICAL WORKS; Switchgears; MCC -Motor Control Center; 1.3.2.1.040 Place PO for MCC; 1.3.2.1.050 Delivery of MCC; Package Substations; Medium Voltage Cables; Submersible Pumps (Lift Station Pumps); Diesel Generators; Transformers; Miscellaneous Items; COMMUNICATION WORKS; Fiber Optic Cables; Communication Duct bank systems; Miscellaneous Communication Items; LANDSCAPING WORKS; Landscaping & Playground Materials; UTILITIES & SERVICE WORKS; Potable & Fire Water Pipelines & Fittings; Potable / Fire water /Sewer Pipes (RTR) & Fittings; Sanitary Sewer Pipeline & Related Equipments; Irrigation Pipeline & related equipments; Street Lighting Network & Related Equipments; Fitness Shelter equipemnts & Furnitures; Site Preparations; Site Preparation; Z2.1010 Site clearing/grubbing/disposal; Z2.1020 Backfill/Compaction of soil upto desired level; Z2.2010 Site clearing/grubbing/disposal; Z2.2020 Backfill/Compaction of soil upto desired level; Z2.2330 Temoraru access road for zone 2; Site Preparation; Z4.1010 Site clearing/grubbing/disposal zone4; Z4.1020 Supp/backfill/compact gen soil upto des level zone4; A1; A3-4; A2-1; A2-2; Lift Station # 9 Zone 4; Lift Station # 10 Zone 3; Lift Station # 11 Zone 3; Lift Station #12 Zone 2; Storm water drainage system; Zone 1; Zone 2; Zone 4; Curbs & Walkways; Segway / Bicycle lane; 1.4.2.5.5.010A Site grading/sub-grade course compaction Zone3 -A3-1; 1.4.2.5.5.010B Install agregate grade course type A Zone3 - A3-1; 1.4.2.5.5.010C Install RC pavement for bicycle lane Zone3 - A3-1; 1.4.2.5.5.020A Site grading/sub-grade course compaction Zone3 -A3-2; 1.4.2.5.5.020B Install agregate grade course type A Zone3 - A3-2; 1.4.2.5.5.020C Install RC pavement for bicycle lane Zone3 - A3-2; 1.4.2.5.5.030A Site grading/sub-grade course compaction Zone3 -A3-3; 1.4.2.5.5.030B Install agregate grade course type A Zone3 - A3-3; 1.4.2.5.5.030C Install RC pavement for bicycle lane Zone3 - A3-3; 1.4.2.5.5.040A Site grading/sub-grade course compaction Zone2 -A2-1; 1.4.2.5.5.040B Install agregate grade course type A Zone2 - A2-1; 1.4.2.5.5.040C Install RC pavement for bicycle lane Zone2 - A2-1; 1.4.2.5.5.050A Site grading/sub-grade course compaction Zone2 -A2-2; 1.4.2.5.5.050B Install agregate grade course type A Zone2 - A2-2; 1.4.2.5.5.050C Install RC pavement for bicycle lane Zone2 - A2-2; Landscaping & Hardscaping; Landscaping & Hardscaping; Zone 3; 1.4.2.6.020 Cut/fill upto exisitng grade; 1.4.2.6.130 constrcution (structural/archt'l) of water fountain; 1.4.2.6.030 Fill/compaction upto lower level; 1.4.2.6.040 Aggregarte basecoarse for sidewalk & walkways; 1.4.2.6.140 constrcution (structural/archt'l) of fitness park; 1.4.2.6.050 Sweet sand basecoarse for sidewalk & walkways; 1.4.2.6.060 RC pavement for walkways; 1.4.2.6.070 Interlocking tiles for walkways; 1.4.2.6.080 Decorative interlocking tiles for wlaslkways; 1.4.2.6.090 concrete edging for walkways; 1.4.2.6.100 sweet sand for playground area; 1.4.2.6.150 constrcution (structural/archt'l) of play park fountain & fitting; 1.4.2.6.110 gravel mulch for trees well; 1.4.2.6.120 natural stone boulder/sculptured(1each large & 2 small); 1.4.2.6.160 Install Maze & Labyrinth; 1.4.2.6.170 Install Turfin & ground cover; LV Cables - Lighting Power Cables (For Permanent Roads); Electrcial Equipments; Switchgears; 1.4.2.7.4.010 Install switchgear SS4; 1.4.2.7.4.020 Install switchgear SS5; 1.4.2.7.4.015 Testing & commissioning of switchgears; 1.4.2.7.4.025 Testing & commissioning of switchgears; Package Substations; RMU; 1.4.2.7.4.108 Testing & commissioning of generator LS9; 1.4.2.7.4.106 Testing & commissioning of generator LS12; 1.4.2.7.4.102 Testing & commissioning of generator LS10; 1.4.2.7.4.104 Testing & commissioning of generator LS11; 1.4.2.7.4.127 Testing & commissioning of LS submersible pumps LS9; 1.4.2.7.4.121 Testing & commissioning of LS submersible pumps LS10; 1.4.2.7.4.123 Testing & commissioning of LS submersible pumps LS11; 1.4.2.7.4.125 Testing & commissioning of LS submersible pumps LS12; Transformers; 1.4.2.7.4.140 Constrcution of transformer foundations; 1.4.2.7.4.150 Install transformer SS4; 1.4.2.7.4.152 Install transformer SS5; 1.4.2.7.4.151 Testing & commissioning of transformer SS4; 1.4.2.7.4.153 Testing & commissioning of transformer SS5; Automatic Transfer Switches - ATS-Fire Alarm System; 1.4.2.7.4.176 Install ATS-Fire Alarm System LS9; 1.4.2.7.4.177 Testing & commissioning of ATS-LS9; 1.4.2.7.4.174 Install ATS-Fire Alarm System LS12; 1.4.2.7.4.170 Install ATS-Fire Alarm System -LS10; 1.4.2.7.4.175 Testing & commissioning of ATS-LS12; 1.4.2.7.4.171 Testing & commissioning of ATS-LS10; 1.4.2.7.4.172 Install ATS-Fire Alarm System LS11; 1.4.2.7.4.173 Testing & commissioning of ATS-LS11; Switchboards; 1.4.2.7.4.190 Install switchboards SS4; 1.4.2.7.4.192 Install switchboards SS5; 1.4.2.7.4.191 Testing & commissioning of switchboards SS4; 1.4.2.7.4.193 Testing & commissioning of switchboards SS5; Main distribution Panel Boards; 1.4.2.7.4.210 Install main distribution panel board SS4; 1.4.2.7.4.212 Install main distribution panel board SS5; 1.4.2.7.4.211 Testing & commissioning of panel board SS4; 1.4.2.7.4.213 Testing & commissioning of panel board SS5; Circuit Breakers; 1.4.2.7.4.230 Install circuit breaker SS4; 1.4.2.7.4.232 Install circuit breaker SS5; 1.4.2.7.4.231 Testing & commissioning of circuit breaker SS4; 1.4.2.7.4.233 Testing & commissioning of circuit breaker SS5; Annunciator Panel; 1.4.2.7.4.250 Install annunciator panel SS4; 1.4.2.7.4.252 Install annunciator panel SS5; 1.4.2.7.4.251 Testing & commissioning of annunciator panel SS4; 1.4.2.7.4.253 Testing & commissioning of annunciator panel SS5; Battery Bank & Battery Charger with UPS; 1.4.2.7.4.270 Install battery bank & battery charger with system SS4; 1.4.2.7.4.272 Install battery bank & battery charger with system SS5; 1.4.2.7.4.271 Testing & commissioning of battery system SS4; 1.4.2.7.4.273 Testing & commissioning of battery system SS5; Exchange Building # 1; Communication Works at Exch Bldg #1; 1.4.5.1.010 Remove Temporary gates & Jersey Barriers; 1.4.5.1.020 Touch up of roads according to the existing roads

Changed:

| ID | Task | Start | Finish | Duration | Complete | Total float | Predecessors | Other |
| --- | --- | --- | --- | --- | --- | --- | --- | --- |
| M | **MILESTONE DATES** |  | 2013-06-29 → 2014-01-04 (+189d) |  |  |  |  |  |
| 1 | **Milestone Dates** |  | 2013-06-29 → 2014-01-04 (+189d) |  |  |  |  |  |
| M1.00 | Notice to Proceed (NTP) | 2011-01-09 A | 2011-01-09 A |  | 0% → 100% | 0d → none |  |  |
| M1.01 | PMT & Contractor Design Office | 2011-01-19 A | 2011-01-19 A |  | 0% → 100% | 63.75d → none |  |  |
| M1.02 | Submit 120 Days Schedule | 2011-02-08 A | 2011-02-08 A |  | 0% → 100% | 65.75d → none | 1.2.2.010, M1.01 → 1.2.2.010 |  |
| M1.03 | Complet Site Prep'n detailed design package | 2011-02-08 A | 2011-02-08 A |  | 0% → 100% | 85d → none | M1.02 → 1.4.1.1.210 |  |
| M2.03 | Compl't inst'n of jersey barrier & gates for zone 1 | 2011-04-09 → 2011-02-20 A (-48d) | 2011-04-09 → 2011-02-20 A (-48d) |  | 0% → 100% | 86.25d → none |  |  |
| M1.04 | Submit Project Execution Plan (PEP) | 2011-02-23 → 2011-02-27 A (+4d) | 2011-02-23 → 2011-02-27 A (+4d) |  | 0% → 100% | 81d → none | 1.2.3.010, M1.03 → 1.2.3.010 |  |
| M2.02 | Compl't temporary construction site offices | 2011-03-10 → 2011-03-20 A (+10d) | 2011-03-10 → 2011-03-20 A (+10d) |  | 0% → 100% | 117.5d → none | M1.00 FS+43d, 1.4.1.1.230, 1.4.1.1.120 → 1.4.1.1.230, 1.4.1.1.120 |  |
| M1.05 | Submit Procurement Plan & Quality Plan | 2011-02-23 → 2011-04-02 A (+38d) | 2011-02-23 → 2011-04-02 A (+38d) |  | 0% → 100% | 81d → none | 1.2.3.015, M1.04 → 1.2.3.015 |  |
| M1.08 | Complete 50% Engineering Design | 2011-05-09 → 2011-06-04 A (+26d) | 2011-05-09 → 2011-06-04 A (+26d) |  | 0% → 100% | 93.75d → none |  |  |
| M1.06 | Submit Work Schedule | 2011-03-10 → 2011-07-04 A (+116d) | 2011-03-10 → 2011-07-04 A (+116d) |  | 0% → 100% | 63.75d → none | 1.2.4.010, M1.05 → 1.2.4.010 |  |
| M1.11 | Compl't 90% Engineering Design | 2011-07-07 → 2011-07-04 A (-3d) | 2011-07-07 → 2011-07-04 A (-3d) |  | 0% → 100% | 30d → none |  |  |
| M1.12 | Issue 100% IFC Drwaings | 2011-08-07 → 2011-12-03 A (+118d) | 2011-08-07 → 2011-12-03 A (+118d) |  | 0% → 100% | 179.75d → none | 1.2.6.200, M1.11 → 1.2.6.200 |  |
| M2.01 | Compl't mobilization | 2011-03-10 → 2012-01-15 A (+311d) | 2011-03-10 → 2012-01-15 A (+311d) |  | 0% → 100% | 117.5d → none | M1.00, 1.4.1.1.230 → 1.4.1.1.230 |  |
| M2.04 | Compl't inst'n of jersey barrier & gates for zone 3 | 2011-06-08 → 2012-01-26 A (+232d) | 2011-06-08 → 2012-01-26 A (+232d) |  | 0% → 100% | 90d → none |  |  |
| M2.05 | Compl't site prep & access road for zone 1 | 2011-06-08 → 2012-03-27 A (+293d) | 2011-06-08 → 2012-03-27 A (+293d) |  | 0% → 100% | 110d → none | Z1.1030, Z1.1030 FF → Z1.1030 FF |  |
| M2.06 | Compl't inst'n of jersey barrier & gates for zone 4 | 2011-07-23 → 2012-03-29 A (+250d) | 2011-07-23 → 2012-03-29 A (+250d) |  | 0% → 100% | 112.5d → none |  |  |
| M2.07 | Compl't inst'n of jersey barrier & gates for zone 2 | 2011-07-23 → 2012-03-29 A (+250d) | 2011-07-23 → 2012-03-29 A (+250d) |  | 0% → 100% | 62.5d → none |  |  |
| M1.07 | Place PO for Long Lead Items | 2011-08-13 → 2012-04-12 A (+243d) | 2011-08-13 → 2012-04-12 A (+243d) |  | 0% → 100% | 174.75d → none | M1.06, 1.2.5.010 SF → 1.2.5.010 |  |
| M1.10 | Compl't PO Placement of Bulk Items | 2011-11-30 → 2012-04-12 A (+134d) | 2011-11-30 → 2012-04-12 A (+134d) |  | 0% → 100% | 56d → none | M1.09, 1.2.5.030 → 1.2.5.030 |  |
| M1.09 | Compl't PO Placement of Engineered Items | 2011-10-20 → 2012-04-26 A (+189d) | 2011-10-20 → 2012-04-26 A (+189d) |  | 0% → 100% | 99.75d → none | M1.08, 1.2.5.020, M1.07 → 1.2.5.020, 1.3.1.17.010 |  |
| M2.08 | Compl't site prep & access road for zone 3 | 2011-09-06 → 2012-05-31 A (+268d) | 2011-09-06 → 2012-05-31 A (+268d) |  | 0% → 100% | 37.5d → none |  |  |
| M2.09 | Compl't site prep & access roads for zone 2 & 4 | 2011-11-05 → 2012-10-04 (+334d) | 2011-11-05 → 2012-10-04 (+334d) |  |  | 130d → 91.62d | Backfill/Compaction of soil upto desired level, Backfill/Compaction of soil upto desired level, Supp/backfill/compact gen soil upto des level zone4, Temoraru access road for zone 2 → 1.4.1.3.2.010, 1.4.1.3.4.010 |  |
| M2.11 | Compl't Communications and Security Cabling | 2012-09-20 → 2012-12-19 (+90d) | 2012-09-20 → 2012-12-19 (+90d) |  |  | 94.25d → 10.5d | 1.4.2.8.1.090, 1.4.2.8.1.110, 1.4.3.2.1.1010 → 1.4.2.8.1.090, 1.4.2.8.1.150, 1.4.2.8.1.150 FF, 1.4.2.8.1.130 |  |
| M2.19 | Compl't Spare Part Data Packages | 2012-10-20 → 2013-01-24 (+96d) | 2012-10-20 → 2013-01-24 (+96d) |  |  | 62.75d → -28.25d |  |  |
| M2.10 | Energize Substation 4 and 5 | 2012-08-21 → 2013-01-30 (+162d) | 2012-08-21 → 2013-01-30 (+162d) |  |  | 37.75d → -97.5d | 1.4.3.1.1.570, 1.4.3.1.2.570, Testing & commissioning of panel board SS5, Testing & commissioning of transformer SS5, Testing & commissioning of circuit breaker SS4, Testing & commissioning of circuit breaker SS5, Testing & commissioning of switchboards SS5, Testing & commissioning of switchgears, 1.4.2.7.4.055 → 1.4.3.1.1.570, 1.4.3.1.2.570, 1.4.2.7.1.070, 1.4.2.7.730 |  |
| M2.12 | Communications and Security Systems | 2012-09-20 → 2013-03-04 (+165d) | 2012-09-20 → 2013-03-04 (+165d) |  |  | 94d → -69.8d | 1.4.3.2.1.1110 → 1.4.3.2.1.1110, 1.4.3.2.1.1210, 1.4.3.2.1.690, 1.4.3.2.1.1330 |  |
| M2.14 | Compl't Const'n & Energize the Comm'n Bld'g | 2012-09-30 → 2013-03-05 (+156d) | 2012-09-30 → 2013-03-05 (+156d) |  |  | 51.5d → -103d | 1.4.3.2.1.1340, 1.4.3.2.1.1520, 1.4.3.2.1.890, 1.4.3.2.1.940 → 1.4.3.2.1.1340, 1.4.3.2.1.1520, 1.4.3.2.1.890 |  |
| M2.16 | Compl't Irrigation System | 2012-10-20 → 2013-03-30 (+161d) | 2012-10-20 → 2013-03-30 (+161d) |  |  | 62.5d → -96.69d | 1.3.4.14.020, 1.3.4.13.020, Z3.1330, Z3.2300, Z2.2290 → 1.3.4.14.020, 1.3.4.13.020, Z3.1330, Z3.2300, Z2.2290, Z3.1340, Z3.2310 |  |
| M2.13 | Compl't Power System | 2012-09-20 → 2013-05-08 (+230d) | 2012-09-20 → 2013-05-08 (+230d) |  |  | 93.75d → -139.92d | Testing & commissioning of switchgears, Testing & commissioning of panel board SS4, Testing & commissioning of battery system SS4, 1.4.2.7.2.050, 1.4.2.7.2.090, Testing & commissioning of battery system SS5 → 1.4.2.7.4.045, 1.4.2.7.730, 1.4.2.7.4.075, 1.4.2.7.4.085 |  |
| M2.18 | Compl't Storm Drainage System | 2012-10-20 → 2013-05-23 (+215d) | 2012-10-20 → 2013-05-23 (+215d) |  |  | 62.5d → -156.25d |  |  |
| M2.17 | Compl't Sanitary Sewer System | 2012-10-20 → 2013-06-05 (+228d) | 2012-10-20 → 2013-06-05 (+228d) |  |  | 30d → -202.5d | 1.4.2.3.5.140, 1.4.2.3.6.140, 1.4.2.3.7.140, 1.4.2.3.8.140, Testing & commissioning of LS submersible pumps LS10, Testing & commissioning of ATS-LS10, 1.4.2.3.7.150, 1.4.2.3.5.150, 1.4.2.3.8.150, 1.4.2.3.6.160, 1.4.2.3.7.160, 1.4.2.3.8.160, 1.4.2.3.5.160, Testing & commissioning of ATS-LS11, Testing & commissioning of ATS-LS12, Testing & commissioning of ATS-LS9, Testing & commissioning of LS submersible pumps LS11, Testing & commissioning of LS submersible pumps LS12, Testing & commissioning of LS submersible pumps LS9 → 1.4.2.3.5.140, 1.4.2.3.6.140, 1.4.2.3.7.140, 1.4.2.3.8.140, 1.4.2.3.7.150, 1.4.2.3.5.150, 1.4.2.3.8.150, 1.4.2.3.6.160, 1.4.2.3.7.160, 1.4.2.3.8.160, 1.4.2.3.5.160, Z3.3230, Z3.5050, Z3.2055, Z4.1180 |  |
| M2.15 | Compl't Potable and Fire Water Systems | 2012-10-20 → 2013-06-17 (+240d) | 2012-10-20 → 2013-06-17 (+240d) |  |  | 62.5d → -182.5d | Z3.1320, Z3.2290, Z3.3270, Z2.1110, Z2.2310, Z4.1160, Z1.1060 → Z3.2290, Z3.3270, Z2.1110, Z2.2310, Z4.1160, Z1.1060, Z2.1120, Z2.2320, Z4.1170, Z3.3280 |  |
| M2.21 | Mech'l Compl'n Certific'n of all works | 2012-12-29 → 2013-07-03 (+186d) | 2012-12-29 → 2013-07-03 (+186d) |  |  | 80d → -200.42d | 1.4.4.6.010, M1.12, M2.01, M2.02, M2.03, M2.04, M2.05, M2.06, M2.07, M2.08, M2.09, M2.10, M2.11, M2.12, M2.13, M2.14, M2.15, M2.16, M2.17, M2.18, M2.19, M2.20, 1.4.2.5.6.020A, Install RC pavement for bicycle lane Zone3 - A3-1, constrcution (structural/archt'l) of fitness park, 1.4.3.3.1.3.120, 1.4.3.3.1.3.150, 1.4.3.3.1.3.180, 1.4.3.3.1.3.210, 1.4.3.3.1.3.300, 1.4.3.3.1.2.120, 1.4.3.5.1.140, 1.4.3.6.1.150, 1.4.3.4.4.170, 1.4.3.7.1.140, 1.4.3.7.1.100, 1.4.3.1.1.780, 1.4.3.1.1.820, constrcution (structural/archt'l) of play park fountain & fitting, 1.4.3.6.1.100, 1.4.3.3.1.2.210, 1.4.3.3.1.2.180, 1.4.3.3.1.2.300, 1.4.3.3.1.1.210, 1.4.3.3.1.1.120, 1.4.3.3.1.1.300, 1.4.2.7.4.075, natural stone boulder/sculptured(1each large & 2 small), concrete edging for walkways, 1.4.2.5.6.020D, Install RC pavement for bicycle lane Zone2 - A2-2, Install Turfin & ground cover, 1.4.2.5.3.110, 1.4.2.5.4.050, 1.4.3.4.3.170 → 1.4.2.5.6.020A, 1.4.2.6.1.140, 1.4.3.3.1.3.120, 1.4.3.3.1.3.150, 1.4.3.3.1.3.180, 1.4.3.3.1.3.210, 1.4.3.3.1.3.300, 1.4.3.3.1.2.120, 1.4.3.5.1.140, 1.4.3.6.1.150, 1.4.3.4.4.170, 1.4.3.7.1.140, 1.4.3.7.1.100, 1.4.3.1.1.780, 1.4.3.1.1.820, 1.4.3.6.1.100, 1.4.3.3.1.2.210, 1.4.3.3.1.2.180, 1.4.3.3.1.2.300, 1.4.3.3.1.1.210, 1.4.3.3.1.1.120, 1.4.3.3.1.1.300, 1.4.2.7.4.075, 1.4.2.6.1.090, 1.4.2.5.6.020D, 1.4.2.5.3.110, 1.4.2.5.4.050, 1.4.2.7.2.090, 1.4.3.4.3.170, 1.4.2.7.2.092, 1.4.2.6.5.250, 1.4.2.6.4.250, 1.4.2.6.3.250, 1.4.2.6.2.250, 1.4.2.6.1.250, 1.4.2.6.5.260, 1.4.2.8.1.110, 1.4.4.3.010 |  |
| M2.20 | Compl't Redlined As-Built drawings | 2012-11-19 → 2013-07-06 (+229d) | 2012-11-19 → 2013-07-06 (+229d) |  |  | 30d → -202d |  |  |
| M2.22 | Compl't all As-Built CAD work | 2013-01-28 → 2013-08-05 (+189d) | 2013-01-28 → 2013-08-05 (+189d) |  |  | 80d → -202.5d | 1.2.9.020 → 1.2.9.020, 1.4.4.6.020 |  |
| M2.23 | Scheduled Completion Date and Demobilization | 2013-06-29 → 2014-01-04 (+189d) | 2013-06-29 → 2014-01-04 (+189d) |  |  | 0d → -202.5d | M2.21, M2.22, M2.10, 1.4.5.1.010 → 1.4.5.1.010, 1.4.5.1.020 |  |
| E | **DETAILED ENGINEERING / DESIGN** |  | 2013-01-28 → 2013-08-05 (+189d) |  |  |  |  |  |
| 1.2.1.010 | PMT & Contractor Design office | 2011-01-09 A | 2011-01-19 A |  | 0% → 100% | 0d → none |  | resources SSH-Design Manhours [5000 h] → SSH-Design Manhours [500 h] |
| 2 | **Categories 2** | 2011-01-19 → 2011-02-03 (+15d) | 2011-02-22 → 2011-04-02 (+39d) |  |  |  |  |  |
| 1.2.2.010 | Submit 120 days schedule | 2011-01-19 → 2011-02-03 A (+15d) | 2011-02-08 A |  | 0% → 100% | 63.75d → none |  | resources SSH-Design Manhours [4000 h] → SSH-Design Manhours [400 h] |
| 1.2.2.020 | Submit drawing & document control index | 2011-02-02 → 2011-03-03 A (+29d) | 2011-02-22 → 2011-04-02 A (+39d) |  | 0% → 100% | 63.75d → none |  | resources SSH-Design Manhours [3000 h] → SSH-Design Manhours [300 h] |
| 3 | **Categories 3** | 2011-02-10 → 2011-02-15 (+5d) | 2011-02-23 → 2011-04-02 (+38d) |  |  |  |  |  |
| 1.2.3.010 | Submit project execution plan PEP | 2011-02-10 → 2011-02-15 A (+5d) | 2011-02-23 → 2011-02-27 A (+4d) |  | 0% → 100% | 63.75d → none |  | resources SSH-Design Manhours [2500 h] → SSH-Design Manhours [250 h] |
| 1.2.3.015 | Submit Procurement plan & Quality Plan | 2011-02-12 → 2011-03-22 A (+38d) | 2011-02-23 → 2011-04-02 A (+38d) |  | 0% → 100% | 81d → none |  | resources SSH-Design Manhours [2500 h] → SSH-Design Manhours [250 h] |
| 4 | **Categories 4** | 2011-02-20 → 2011-03-02 (+10d) | 2011-03-10 → 2011-07-04 (+116d) |  |  |  |  |  |
| 1.2.4.010 | Submit contractor deliverables & Work Schedule | 2011-02-20 → 2011-03-02 A (+10d) | 2011-03-10 → 2011-07-04 A (+116d) |  | 0% → 100% | 63.75d → none |  | resources SSH-Design Manhours [6000 h] → SSH-Design Manhours [600 h] |
| 5 | **Categories 5** |  | 2011-11-30 → 2011-12-12 (+12d) |  |  |  |  |  |
| 1.2.5.010 | Purchase orders placed for long lead items | 2011-08-13 A | 2011-09-15 → 2011-08-29 A (-17d) | 37.5d → 18.75d | 0% → 100% | 56d → none | 1.3.2.1.010 → 1.3.4.4.010 | resources SSH-Design Manhours [18000 h] → SSH-Design Manhours [1800 h] |
| 1.2.5.020 | Purchase orders placed for all engineered items | 2011-09-17 A | 2011-10-20 A |  | 0% → 100% | 56d → none | 1.2.5.010 → 1.2.5.010 SS+12.5d |  |
| 1.2.5.030 | Purchase orders placed for all bulk items | 2011-10-22 A | 2011-11-30 → 2011-12-12 A (+12d) | 43.75d → 56.25d | 0% → 100% | 56d → none | 1.3.1.1.010 SS, 1.2.5.020 → 1.3.1.1.010 SS, 1.2.5.020 SS |  |
| 6 | **Categories 6** | 2011-01-27 → 2011-04-23 (+86d) | 2011-08-07 → 2011-12-03 (+118d) |  |  |  |  |  |
| 1.2.6.010 | Preparation of 50% Civil drawings | 2011-01-27 → 2011-04-23 A (+86d) | 2011-03-02 → 2011-06-04 A (+94d) |  | 0% → 100% | 0d → none |  | resources SSH-Design Manhours [60000 h] → SSH-Design Manhours [6000 h] |
| 1.2.6.020 | Preparation of 50% Mechanical drawings | 2011-02-20 → 2011-04-23 A (+62d) | 2011-03-26 → 2011-06-04 A (+70d) |  | 0% → 100% | 0d → none |  | resources SSH-Design Manhours [60000 h] → SSH-Design Manhours [6000 h] |
| 1.2.6.030 | Preparation of 50% Electrical drawings | 2011-03-15 → 2011-04-23 A (+39d) | 2011-04-18 → 2011-06-04 A (+47d) |  | 0% → 100% | 0d → none |  | resources SSH-Design Manhours [60000 h] → SSH-Design Manhours [6000 h] |
| 1.2.6.040 | Preparation of 50% Communication drawings | 2011-04-05 → 2011-04-23 A (+18d) | 2011-05-09 → 2011-06-04 A (+26d) |  | 0% → 100% | 0d → none |  | resources SSH-Design Manhours [60000 h] → SSH-Design Manhours [6000 h] |
| 1.2.6.100 | Preparation of 90% Mechancial drawings | 2011-05-22 → 2011-05-10 A (-12d) | 2011-06-13 → 2011-07-04 A (+21d) |  | 0% → 100% | 0d → none |  | resources SSH-Design Manhours [40000 h] → SSH-Design Manhours [4000 h] |
| 1.2.6.110 | Preparation of 90% Electrical drawings | 2011-06-02 → 2011-05-10 A (-23d) | 2011-06-25 → 2011-07-04 A (+9d) |  | 0% → 100% | 0d → none |  | resources SSH-Design Manhours [40000 h] → SSH-Design Manhours [4000 h] |
| 1.2.6.120 | Preparation of 90% Communication drawings | 2011-06-14 → 2011-05-10 A (-35d) | 2011-07-07 → 2011-07-04 A (-3d) |  | 0% → 100% | 0d → none |  | resources SSH-Design Manhours [40000 h] → SSH-Design Manhours [4000 h] |
| 1.2.6.090 | Preparation of 90% Civil drawings | 2011-05-10 A | 2011-06-01 → 2011-07-04 A (+33d) |  | 0% → 100% | 0d → none |  | resources SSH-Design Manhours [40000 h] → SSH-Design Manhours [4000 h] |
| 1.2.6.200 | Submit 100% IFC drawings | 2011-07-09 → 2011-08-15 A (+37d) | 2011-08-07 → 2011-12-03 A (+118d) |  | 0% → 100% | 30d → none |  | resources SSH-Design Manhours [98290 h] → SSH-Design Manhours [9829 h] |
| 7 | **Categories 7** | 2012-09-29 → 2013-03-14 (+166d) | 2012-10-27 → 2013-04-10 (+165d) |  |  |  |  |  |
| 1.2.7.010 | Submit Project Record books | 2012-09-29 → 2013-03-14 (+166d) | 2012-10-27 → 2013-04-10 (+165d) |  |  | 147.75d → -80.5d | 1.2.6.200 FS+300d, 1.2.5.030, 1.4.4.3.010 → 1.2.6.200 FS+100d, 1.2.5.030, 1.4.4.3.010 | resources SSH-Design Manhours [6000 h] → SSH-Design Manhours [600 h] |
| 8 | **Categories 8** | 2012-01-24 → 2012-10-04 (+254d) | 2012-06-11 → 2013-01-09 (+212d) |  |  |  |  |  |
| 1.2.8.010 | Submit Pre-commissioning Plans | 2012-01-24 → 2012-10-04 (+254d) | 2012-04-02 → 2012-12-12 (+254d) |  |  | 95d → -90d | 1.2.6.200 FS+181.25d → 1.2.6.200 FS+112.5d | resources SSH-Design Manhours [2500 h] → SSH-Design Manhours [250 h] |
| 1.2.8.020 | Approved Pre-commissioning Plans | 2012-04-03 → 2012-11-01 (+212d) | 2012-06-11 → 2013-01-09 (+212d) |  |  | 95d → -90d | 1.2.8.010 → 1.2.8.010 FF+30d | resources SSH-Design Manhours [2500 h] → SSH-Design Manhours [250 h] |
| 9 | **Categories 9** | 2012-12-30 → 2013-07-06 (+188d) | 2013-01-28 → 2013-08-05 (+189d) |  |  |  |  |  |
| 1.2.9.020 | Complete Intergraph CADD | 2012-12-30 → 2013-07-06 (+188d) | 2013-01-28 → 2013-08-05 (+189d) | 32.5d → 33d |  | 80d → -202.5d | 1.2.9.010 SS → 1.2.9.010 FF | resources SSH-Design Manhours [1000 h] → SSH-Design Manhours [500 h] |
| 1.2.9.010 | Complete As built Red lined drawings & CAD-work | 2012-12-30 → 2013-07-06 (+188d) | 2013-01-28 → 2013-08-05 (+189d) |  |  | 80d → -202.5d | 1.4.3.1.2.570, 1.4.4.5.040, 1.2.7.010, 1.4.4.6.010, M2.21 → 1.4.3.1.2.570, 1.4.4.5.040, 1.2.7.010 SS, M2.21 | resources SSH-Design Manhours [12000 h] → SSH-Design Manhours [700 h] |

| ID | Task | Start | Finish | Duration | Complete | Total float | Predecessors | Other |
| --- | --- | --- | --- | --- | --- | --- | --- | --- |
| P.1.3 | **PROCUREMENT** | 2011-02-01 → 2011-01-12 (-20d) |  |  |  |  |  |  |
| 01 | **FBE coated rebars** | 2011-07-20 → 2011-07-10 (-10d) |  |  |  |  |  |  |
| 1.3.1.1.010 | Place PO for FBE coated rebars | 2011-07-20 → 2011-07-10 A (-10d) | 2011-08-18 → 2011-07-31 A (-18d) |  | 0% → 100% | 0d → none |  |  |
| 1.3.1.1.020 | Delivery of FBE coated rebars on site | 2011-09-10 A | 2012-06-26 A |  | 0% → 100% | 110d → none |  |  |
| 1.3.1.1.030 | Material receiving inspection & approval | 2011-09-10 A | 2012-06-26 A |  | 0% → 100% | 110d → none |  |  |
| 02 | **Structural Steel** | 2011-07-23 → 2011-10-12 (+81d) | 2011-09-29 → 2012-01-22 (+115d) |  |  |  |  |  |
| 1.3.1.2.010 | Place PO for structural stell | 2011-07-23 → 2011-10-12 A (+81d) | 2011-08-27 → 2011-11-12 A (+77d) |  | 0% → 100% | 0d → none |  |  |
| 1.3.1.2.020 | Delivery of structural steel on site | 2011-09-19 → 2012-01-03 A (+106d) | 2011-09-24 → 2012-01-07 A (+105d) |  | 0% → 100% | 88.5d → none | 1.3.1.2.010 FS+25d → 1.3.1.2.010 FS+120d |  |
| 1.3.1.2.030 | Material receiving inspection & approval | 2012-01-23 → 2012-01-17 A (-6d) | 2012-01-29 → 2012-01-22 A (-7d) |  | 0% → 100% | 48.75d → none | 1.3.1.4.020 → 1.3.1.2.020 |  |
| 03 | **Geogrid & Geotextile Materials** | 2011-08-29 → 2011-10-10 (+42d) |  |  |  |  |  |  |
| 1.3.1.3.010 | Place PO for geogrid/geotextile materials | 2011-08-29 → 2011-10-10 A (+42d) | 2011-10-03 → 2011-10-22 A (+19d) |  | 0% → 100% | 0d → none |  |  |
| 1.3.1.3.020 | Delivery of geogrid/geotextile materials on site | 2012-03-25 A | 2012-03-31 A |  | 0% → 100% | 0d → none | 1.3.1.3.010 FS+186.25d → 1.3.1.3.010 |  |
| 1.3.1.3.030 | Material receiving inspection & approval | 2012-01-04 → 2012-03-31 A (+87d) | 2012-01-09 → 2012-04-04 A (+86d) |  | 0% → 100% | 39d → none | 1.3.1.5.020 → 1.3.1.3.020 SS |  |
| 04 | **Ceramic Tiles** | 2011-07-27 → 2012-02-18 (+206d) | 2012-01-29 → 2012-05-07 (+99d) |  |  |  |  |  |
| 1.3.1.4.010 | Place PO for ceramic tiles | 2011-07-27 → 2012-02-18 A (+206d) | 2011-08-31 → 2012-03-22 A (+204d) |  | 0% → 100% | 48.75d → none | 1.3.1.2.010 SS+5d → 1.3.1.2.010 FS+5d |  |
| 1.3.1.4.020 | Delivery of ceramic tiles on site | 2012-01-18 → 2012-04-28 A (+101d) | 2012-01-23 → 2012-05-01 A (+99d) |  | 0% → 100% | 48.75d → none | 1.3.1.4.010 FS+150d → 1.3.1.4.010 FS+37.5d |  |
| 1.3.1.4.030 | Material receiving inspection & approval | 2012-03-01 → 2012-05-02 A (+62d) | 2012-03-07 → 2012-05-07 A (+61d) |  | 0% → 100% | 201d → none | 1.3.1.7.020 → 1.3.1.4.020 |  |
| 05 | **CMU Blocks** | 2011-10-03 → 2011-09-03 (-30d) |  |  |  |  |  |  |
| 1.3.1.5.010 | Place PO for CMU blocks | 2011-10-03 → 2011-09-03 A (-30d) | 2011-11-07 → 2011-10-02 A (-36d) |  | 0% → 100% | 39d → none |  |  |
| 1.3.1.5.020 | Delivery of CMU blocks | 2011-12-29 A | 2012-01-04 A |  | 0% → 100% | 39d → none |  |  |
| 1.3.1.5.030 | Material receiving inspection & approval | 2011-09-24 → 2012-01-04 A (+102d) | 2011-09-29 → 2012-01-09 A (+102d) |  | 0% → 100% | 88.5d → none | 1.3.1.2.020 → 1.3.1.5.020 SS |  |
| 06 | **Concrete Tiles** | 2011-09-04 → 2011-06-27 (-69d) |  |  |  |  |  |  |
| 1.3.1.6.010 | Place PO for concrete tiles | 2011-09-04 → 2011-06-27 A (-69d) | 2011-10-09 → 2011-07-12 A (-89d) |  | 0% → 100% | 37.25d → none |  |  |
| 1.3.1.6.020 | Delivery of concrete tiles | 2012-04-01 A | 2012-04-05 A |  | 0% → 100% | 37.25d → none |  |  |
| 1.3.1.6.030 | Material receiving inspection & approval | 2012-03-31 → 2012-04-05 A (+5d) | 2012-04-04 → 2012-04-11 A (+7d) |  | 0% → 100% | 0d → none | 1.3.1.3.020 → 1.3.1.6.020 SS |  |
| 07 | **Doors & Frames** | 2011-09-15 → 2011-11-15 (+61d) | 2012-03-07 → 2012-06-03 (+88d) |  |  |  |  |  |
| 1.3.1.7.010 | Place PO for doors & frames | 2011-09-15 → 2011-11-15 A (+61d) | 2011-10-20 → 2012-01-10 A (+82d) |  | 0% → 100% | 66.75d → none |  |  |
| 1.3.1.7.020 | Delivery of doors & frames on site | 2012-02-26 → 2012-05-24 A (+88d) | 2012-03-01 → 2012-05-28 A (+88d) |  | 0% → 100% | 201d → none | 1.3.1.7.010 FS+137.5d → 1.3.1.7.010 FS+145d |  |
| 1.3.1.7.030 | Material receiving inspection & approval | 2012-04-05 → 2012-05-29 A (+54d) | 2012-04-11 → 2012-06-03 A (+53d) |  | 0% → 100% | 37.25d → none | 1.3.1.6.020 → 1.3.1.7.020 |  |
| 08 | **Aluminium Windows** | 2011-09-18 → 2012-02-18 (+153d) | 2012-03-10 → 2012-07-04 (+116d) |  |  |  |  |  |
| 1.3.1.8.010 | Place PO for windows | 2011-09-18 → 2012-02-18 A (+153d) | 2011-10-23 → 2012-03-22 A (+151d) |  | 0% → 100% | 66.75d → none |  |  |
| 1.3.1.8.020 | Delivery of windows on site | 2012-02-28 → 2012-06-25 A (+118d) | 2012-03-04 → 2012-06-28 A (+116d) |  | 0% → 100% | 198.5d → none | 1.3.1.8.010 FS+137.5d → 1.3.1.8.010 FS+100d |  |
| 1.3.1.8.030 | Material receiving inspection & approval | 2012-03-04 → 2012-06-30 A (+118d) | 2012-03-10 → 2012-07-04 A (+116d) |  | 0% → 100% | 198.5d → none |  |  |
| 09 | **Jersey Barriers** | 2011-02-01 → 2011-02-14 (+13d) | 2011-07-17 → 2011-12-10 (+146d) |  |  |  |  |  |
| 1.3.1.9.010 | Place PO for Jersey Barriers materials Materials | 2011-02-01 → 2011-02-14 A (+13d) | 2011-02-07 → 2011-02-28 A (+21d) |  | 0% → 100% | 37.5d → none |  |  |
| 1.3.1.9.020 | Fabrication & Delivery of materials for jersey bariers | 2011-02-19 → 2011-03-09 A (+18d) | 2011-07-07 → 2011-12-10 A (+156d) |  | 0% → 100% | 57.5d → none |  | resources SSH-Procurement Manhours; SSH-Construction Manhours [900000 h] → SSH-Procurement Manhours |
| 1.3.1.9.030 | Insp/Transporation of Jersey Barriers | 2011-02-28 → 2011-03-09 A (+9d) | 2011-07-17 → 2011-12-10 A (+146d) |  | 0% → 100% | 57.5d → none |  |  |
| 10 | **Sliding & Swing Gates** | 2011-02-14 → 2011-09-15 (+213d) | 2011-03-17 → 2011-11-21 (+249d) |  |  |  |  |  |
| 1.3.1.10.010 | Place PO for sliding & swing gates | 2011-02-14 → 2011-09-15 A (+213d) | 2011-02-20 → 2011-09-21 A (+213d) |  | 0% → 100% | 37.5d → none |  |  |
| 1.3.1.10.020 | Delivery of sliding & swing gates | 2011-03-10 → 2011-11-15 A (+250d) | 2011-03-14 → 2011-11-19 A (+250d) |  | 0% → 100% | 37.5d → none |  |  |
| 1.3.1.10.030 | Material receiving inspection & approval | 2011-03-15 → 2011-11-19 A (+249d) | 2011-03-17 → 2011-11-21 A (+249d) |  | 0% → 100% | 37.5d → none |  |  |
| 11 | **Suspended Ceiling System** | 2011-10-10 → 2011-11-19 (+40d) | 2012-04-28 → 2012-05-10 (+12d) |  |  |  |  |  |
| 1.3.1.11.010 | Place PO for suspended ceiling system | 2011-10-10 → 2011-11-19 A (+40d) | 2011-11-14 → 2011-12-22 A (+38d) |  | 0% → 100% | 66.75d → none | 1.3.1.8.010 SS+23.75d → 1.3.1.10.010 |  |
| 1.3.1.11.020 | Delivery of suspended ceiling system | 2012-04-17 → 2012-04-29 A (+12d) | 2012-04-23 → 2012-05-05 A (+12d) |  | 0% → 100% | 122.5d → none | 1.3.1.11.010 FS+166.25d → 1.3.1.11.010 FS+137d |  |
| 1.3.1.11.030 | Material receiving inspection & approval | 2012-04-23 → 2012-05-05 A (+12d) | 2012-04-28 → 2012-05-10 A (+12d) |  | 0% → 100% | 122.5d → none |  |  |
| 12 | **Dry Wall Partition** | 2011-10-10 → 2011-10-16 (+6d) | 2012-04-28 → 2012-05-09 (+11d) |  |  |  |  |  |
| 1.3.1.12.010 | Place PO for dry wall partition | 2011-10-10 → 2011-10-16 A (+6d) | 2011-11-14 → 2011-11-19 A (+5d) |  | 0% → 100% | 66.75d → none |  |  |
| 1.3.1.12.020 | Delivery of dry wall partition on site | 2012-04-17 → 2012-04-29 A (+12d) | 2012-04-23 → 2012-05-05 A (+12d) |  | 0% → 100% | 70.5d → none | 1.3.1.12.010 FS+166.25d → 1.3.1.12.010 FS+173d |  |
| 1.3.1.12.030 | Material receiving inspection & approval | 2012-04-23 → 2012-05-05 A (+12d) | 2012-04-28 → 2012-05-09 A (+11d) |  | 0% → 100% | 70.5d → none |  |  |
| 13 | **Pre-Cast Concrete Wall** | 2011-10-15 → 2012-02-18 (+126d) | 2012-05-01 → 2012-05-29 (+28d) |  |  |  |  |  |
| 1.3.1.13.010 | Place PO for precast concrete wall | 2011-10-15 → 2012-02-18 A (+126d) | 2011-11-19 → 2012-03-22 A (+124d) |  | 0% → 100% | 66.75d → none | 1.3.1.12.010 SS+5d → 1.3.1.12.010 SS |  |
| 1.3.1.13.020 | Delivery of precast concrete wall | 2012-04-21 → 2012-05-19 A (+28d) | 2012-04-26 → 2012-05-23 A (+27d) |  | 0% → 100% | 66.75d → none | 1.3.1.13.010 FS+165d → 1.3.1.13.010 FS+60d |  |
| 1.3.1.13.030 | Material receiving inspection & approval | 2012-04-26 → 2012-05-23 A (+27d) | 2012-05-01 → 2012-05-29 A (+28d) |  | 0% → 100% | 66.75d → none |  |  |
| 14 | **Concrete** | 2011-02-01 → 2011-01-12 (-20d) |  |  |  |  |  |  |
| 1.3.1.14.010 | Place PO for Concrete | 2011-02-01 → 2011-01-12 A (-20d) | 2011-02-06 → 2011-01-26 A (-11d) |  | 0% → 100% | 48.75d → none |  |  |
| 1.3.1.14.020 | Delivery of concrete on site | 2011-03-08 A |  |  | 0% → 95% | 48.75d → -182.5d |  |  |
| 15 | **Aggregate, Crushed Stone & Backfilling Materials** | 2011-02-16 → 2011-01-26 (-21d) |  |  |  |  |  |  |
| 1.3.1.15.010 | Place PO for Aggregate & Backfill materials | 2011-02-16 → 2011-01-26 A (-21d) | 2011-03-22 → 2011-02-15 A (-35d) |  | 0% → 100% | 49d → none |  |  |
| 1.3.1.15.020 | Delivery of Aggregate & Backfill materials | 2011-04-04 A | 2011-09-25 A |  | 0% → 100% | 131.25d → none |  |  |
| 16 | **Premix** | 2011-07-06 → 2012-02-18 (+227d) | 2012-04-15 → 2012-10-04 (+172d) |  |  |  |  |  |
| 1.3.1.16.010 | Place PO for Premix | 2011-07-06 → 2012-02-18 A (+227d) | 2011-08-09 → 2012-03-22 A (+226d) |  | 0% → 100% | 49d → none | 1.3.1.15.010 FS+112.5d → 1.3.1.13.010 SS |  |
| 1.3.1.16.020 | Delivery of Premix | 2012-04-11 → 2012-05-19 A (+38d) | 2012-04-15 → 2012-10-04 (+172d) | 5d → 150d | 0% → 99% | 120d → -85.5d | 1.3.1.16.010 FS+262.5d → 1.3.1.16.010 FS+60d |  |
| 17 | **Road Signange & Markings** | 2011-10-15 → 2012-03-24 (+161d) | 2012-03-08 → 2012-09-13 (+189d) |  |  |  |  |  |
| 1.3.1.17.010 | Place PO for road signage, markings | 2011-10-15 → 2012-03-24 A (+161d) | 2011-11-19 → 2012-04-26 A (+159d) |  | 0% → 100% | 198.25d → none | 1.3.1.13.010 SS → 1.3.1.16.010 |  |
| 1.3.1.17.020 | Delivery of road signage , markings | 2012-03-03 → 2012-07-21 A (+140d) | 2012-03-08 → 2012-09-13 A (+189d) | 6.25d → 60d | 0% → 100% | 198.25d → none | 1.3.1.17.010 FS+112.5d → 1.3.1.17.010 FS+90d |  |
| 18 | **Ironmongery** | 2011-09-03 → 2012-02-18 (+168d) | 2012-01-25 → 2012-05-31 (+127d) |  |  |  |  |  |
| 1.3.1.18.010 | Place PO for Ironmongery | 2011-09-03 → 2012-02-18 A (+168d) | 2011-10-06 → 2012-03-22 A (+168d) |  | 0% → 100% | 49d → none | 1.3.1.16.010 FS+25d → 1.3.1.16.010 SS |  |
| 1.3.1.18.020 | Delivery of Ironmongery | 2012-01-21 → 2012-05-19 A (+119d) | 2012-01-25 → 2012-05-31 A (+127d) | 6.25d → 15d | 0% → 100% | 71d → none | 1.3.1.18.010 FS+112.5d → 1.3.1.18.010 FS+60d |  |
| 19 | **Paint** | 2011-09-07 → 2011-12-04 (+88d) | 2012-02-11 → 2012-03-27 (+45d) |  |  |  |  |  |
| 1.3.1.19.010 | Place PO for Paint | 2011-09-07 → 2011-12-04 A (+88d) | 2011-10-11 → 2011-12-20 A (+70d) |  | 0% → 100% | 49d → none | 1.3.1.18.010 SS+5d → 1.3.1.15.020 SS |  |

| ID | Task | Start | Finish | Duration | Complete | Total float | Predecessors |
| --- | --- | --- | --- | --- | --- | --- | --- |
| 1.3.1.19.020 | Delivery of Paint | 2012-02-06 → 2012-03-22 A (+45d) | 2012-02-11 → 2012-03-27 A (+45d) |  | 0% → 100% | 49d → none | 1.3.1.19.010 FS+125d → 1.3.1.19.010 FS+100d |
| 20 | **Roofing Materials, membrane etc.** | 2011-10-12 → 2011-11-15 (+34d) | 2012-03-01 → 2012-05-09 (+69d) |  |  |  |  |
| 1.3.1.20.010 | Place PO for Roofing Materials & Membrane | 2011-10-12 → 2011-11-15 A (+34d) | 2011-11-15 → 2011-12-19 A (+34d) |  | 0% → 100% | 206.25d → none | 1.3.1.19.010 SS+37.5d → 1.3.1.19.010 FF+12.5d |
| 1.3.1.20.020 | Delivery of roofing Materials & Membrane | 2012-02-29 → 2012-05-08 A (+69d) | 2012-03-01 → 2012-05-09 A (+69d) |  | 0% → 100% | 206.25d → none | 1.3.1.20.010 FS+112.5d → 1.3.1.20.010 FS+150d |
| 21 | **Building Signage** | 2011-10-12 → 2012-02-18 (+129d) | 2012-03-15 → 2012-06-28 (+105d) |  |  |  |  |
| 1.3.1.21.010 | Place PO for Building Signage | 2011-10-12 → 2012-02-18 A (+129d) | 2011-11-15 → 2012-03-22 A (+128d) |  | 0% → 100% | 178.75d → none |  |
| 1.3.1.21.020 | Delivery of Buiding Signage | 2012-03-12 → 2012-06-25 A (+105d) | 2012-03-15 → 2012-06-28 A (+105d) |  | 0% → 100% | 191.25d → none | 1.3.1.21.010 FS+125d → 1.3.1.21.010 FS+100d |
| 22 | **Wood Terrlis** | 2011-10-12 → 2012-03-24 (+164d) | 2012-03-27 → 2012-09-18 (+175d) |  |  |  |  |
| 1.3.1.22.010 | Place PO for Wood Terrlis | 2011-10-12 → 2012-03-24 A (+164d) | 2011-11-15 → 2012-04-26 A (+163d) |  | 0% → 100% | 178.75d → none | 1.3.1.21.010 SS → 1.3.1.21.010 |
| 1.3.1.22.020 | Delivery of Wood Terrlis | 2012-03-24 → 2012-09-15 A (+175d) | 2012-03-27 → 2012-09-18 A (+175d) |  | 0% → 100% | 178.75d → none | 1.3.1.22.010 FS+137.5d → 1.3.1.22.010 FS+150d |
| 23 | **Landscaping Materials** | 2011-09-24 → 2012-02-18 (+147d) | 2012-03-27 → 2012-07-24 (+119d) |  |  |  |  |
| 1.3.1.23.010 | Place PO for trees/shrubs/ground covers | 2011-09-24 → 2012-02-18 A (+147d) | 2011-10-27 → 2012-03-22 A (+147d) |  | 0% → 100% | 19.25d → none |  |
| 1.3.1.23.020 | Delivery of trees/shrubs/ground covers | 2012-03-17 → 2012-07-14 A (+119d) | 2012-03-21 → 2012-07-18 A (+119d) |  | 0% → 100% | 19.25d → none | 1.3.1.23.010 FS+150d → 1.3.1.23.010 FS+120d |
| 1.3.1.23.030 | Material receiving inspection & approval | 2012-02-26 → 2012-07-18 A (+143d) | 2012-03-03 → 2012-07-24 A (+143d) |  | 0% → 100% | 66.75d → none | 1.3.3.7.020 → 1.3.1.23.020 |
| 24 | **Playground Materials** | 2011-10-03 → 2012-03-24 (+173d) | 2012-06-14 → 2012-08-19 (+66d) |  |  |  |  |
| 1.3.1.24.010 | Place PO for playground utilities | 2011-10-03 → 2012-03-24 A (+173d) | 2011-11-06 → 2012-04-26 A (+172d) |  | 0% → 100% | 67.75d → none | 1.3.1.23.010 SS+10d → 1.3.1.23.010 |
| 1.3.1.24.020 | Delivery of playground utilities | 2012-06-04 → 2012-08-08 A (+65d) | 2012-06-09 → 2012-08-13 A (+65d) |  | 0% → 100% | 67.75d → none | 1.3.1.24.010 FS+225d → 1.3.1.24.010 FS+110d |
| 1.3.1.24.030 | Provision of startup spare parts & Non-material-req'ts | 2012-03-25 → 2012-08-14 A (+142d) | 2012-03-29 → 2012-08-19 A (+143d) |  | 0% → 100% | 132.75d → none | Delivery of MCC → 1.3.1.24.020 |
| 25 | **Fitness Shelter equipments & furniture** | 2011-12-08 → 2012-03-28 (+111d) | 2012-07-19 → 2012-07-29 (+10d) |  |  |  |  |
| 1.3.1.25.010 | Place PO for fitness & art shelters furniture | 2011-12-08 → 2012-03-28 A (+111d) | 2012-01-11 → 2012-05-01 A (+111d) |  | 0% → 100% | 59d → none | 1.3.4.16.010 FS+113.75d → 1.3.1.24.010 SS+5d |
| 1.3.1.25.020 | Delivery of fitness & art shelters furniture | 2012-07-05 → 2012-07-18 A (+13d) | 2012-07-10 → 2012-07-23 A (+13d) |  | 0% → 100% | 59d → none | 1.3.1.25.010 SS+225d → 1.3.1.25.010 SS+120d |
| 1.3.1.25.030 | SPDP/monthof fitness & art shelters furniture | 2012-07-10 → 2012-07-23 A (+13d) | 2012-07-19 → 2012-07-29 A (+10d) | 10d → 6d | 0% → 100% | 59d → none |  |
| 1 | **Switchgears** | 2011-07-09 → 2011-05-26 (-44d) | 2012-04-12 → 2012-06-28 (+77d) |  |  |  |  |
| 1.3.2.1.010 | Place PO for switchgears | 2011-07-09 → 2011-05-26 A (-44d) | 2011-08-11 → 2011-06-26 A (-46d) |  | 0% → 100% | 19.25d → none |  |
| 1.3.2.1.020 | Delivery of switchgears | 2012-04-02 → 2012-06-24 A (+83d) | 2012-04-07 → 2012-06-28 A (+82d) |  | 0% → 100% | 43d → none | 1.3.2.1.010 FS+250d → 1.3.2.1.010 FS+390d |
| 1.3.2.1.030 | Provision of startup spare parts & Non-material-req'ts | 2012-04-07 → 2012-06-24 A (+78d) | 2012-04-12 → 2012-06-28 A (+77d) |  | 0% → 100% | 43d → none | 1.3.2.1.020 → 1.3.2.1.020 FF |
| 1.3.2.2.030 | Provision of startup spare parts & Non-material-req'ts | 2012-04-21 → 2012-05-28 A (+37d) | 2012-04-25 → 2012-06-02 A (+38d) |  | 0% → 100% | 40.75d → none | 1.3.2.3.020 → 1.3.2.2.020 |
| 3 | **Package Substations** | 2011-07-09 → 2011-10-15 (+98d) | 2012-04-26 → 2012-06-24 (+59d) |  |  |  |  |
| 1.3.2.3.010 | Place PO for package substations | 2011-07-09 → 2011-10-15 A (+98d) | 2011-08-11 → 2011-11-15 A (+96d) |  | 0% → 100% | 19.25d → none |  |
| 1.3.2.3.020 | Delivery of package substations | 2012-04-14 → 2012-06-12 A (+59d) | 2012-04-19 → 2012-06-18 A (+60d) |  | 0% → 100% | 40.75d → none | 1.3.2.3.010 FS+262.5d → 1.3.2.3.010 FS+225d |
| 1.3.2.3.030 | Provision of startup spare parts & Non-material-req'ts | 2011-12-01 → 2012-06-19 A (+201d) | 2011-12-06 → 2012-06-24 A (+201d) |  | 0% → 100% | 37.75d → none | 1.3.2.5.020 → 1.3.2.3.020 |
| 4 | **RMU - Ring Main Units** | 2011-07-09 → 2011-11-01 (+115d) | 2012-04-26 → 2012-06-20 (+55d) |  |  |  |  |
| 1.3.2.4.010 | Place PO for RMU | 2011-07-09 → 2011-11-01 A (+115d) | 2011-08-11 → 2011-11-15 A (+96d) |  | 0% → 100% | 19.25d → none |  |
| 1.3.2.4.020 | Delivery of RMU | 2012-04-16 → 2012-06-10 A (+55d) | 2012-04-21 → 2012-06-16 A (+56d) |  | 0% → 100% | 50.5d → none | 1.3.2.4.010 FS+265d → 1.3.2.4.010 FS+223d |
| 1.3.2.4.030 | Provision of startup spare parts & Non-material-req'ts | 2012-05-06 → 2012-06-16 A (+41d) | 2012-05-12 → 2012-06-20 A (+39d) |  | 0% → 100% | 89.25d → none | 1.3.4.4.020 → 1.3.2.4.020 |
| 5 | **Medium Voltage Cables** | 2011-07-09 → 2011-06-20 (-19d) | 2011-12-06 → 2012-07-21 (+228d) |  |  |  |  |
| 1.3.2.5.010 | Place PO for medium voltage cables | 2011-07-09 → 2011-06-20 A (-19d) | 2011-08-11 → 2011-07-20 A (-22d) |  | 0% → 100% | 19.25d → none |  |
| 1.3.2.5.020 | Delivery of medium voltage cables | 2011-11-26 A | 2011-11-30 → 2012-07-15 A (+228d) | 6.25d → 250d | 0% → 100% | 37.75d → none |  |
| 1.3.2.5.030 | Provision of startup spare parts & Non-material-req'ts | 2012-04-21 → 2011-12-01 A (-142d) | 2012-04-26 → 2012-07-21 A (+86d) | 6d → 250d | 0% → 100% | 50.5d → none | 1.3.2.4.020 → 1.3.2.5.020 SS |
| 6 | **Diesel Generator** | 2011-07-09 → 2011-08-15 (+37d) | 2012-05-06 → 2012-05-09 (+3d) |  |  |  |  |
| 1.3.2.6.010 | Place PO for diesel generators | 2011-07-09 → 2011-08-15 A (+37d) | 2011-08-11 → 2011-09-15 A (+35d) |  | 0% → 100% | 19.25d → none |  |
| 1.3.2.6.020 | Delivery of diesel generators | 2012-04-25 → 2012-04-28 A (+3d) | 2012-04-30 → 2012-05-03 A (+3d) |  | 0% → 100% | 133d → none | 1.3.2.6.010 FS+275d → 1.3.2.6.010 FS+242d |
| 1.3.2.6.030 | SPDP/monthof diesel generators | 2012-04-30 → 2012-05-03 A (+3d) | 2012-05-06 → 2012-05-09 A (+3d) |  | 0% → 100% | 133d → none |  |
| 7 | **Transformers** | 2011-07-09 → 2011-10-13 (+96d) | 2012-05-09 → 2012-06-21 (+43d) |  |  |  |  |
| 1.3.2.7.010 | Place PO for transformers | 2011-07-09 → 2011-10-13 A (+96d) | 2011-08-11 → 2011-11-13 A (+94d) |  | 0% → 100% | 19.25d → none |  |
| 1.3.2.7.020 | Delivery of transformers | 2012-04-29 → 2012-06-10 A (+42d) | 2012-05-03 → 2012-06-16 A (+44d) |  | 0% → 100% | 61.75d → none | 1.3.2.7.010 FS+278.75d → 1.3.2.7.010 FS+226d |
| 1.3.2.7.030 | Provision of startup spare parts & Non-material-req'ts | 2012-05-03 → 2012-06-16 A (+44d) | 2012-05-09 → 2012-06-21 A (+43d) |  | 0% → 100% | 61.75d → none |  |
| 8 | **Circuit Breaker** | 2011-09-24 → 2011-10-29 (+35d) | 2012-06-05 → 2012-07-04 (+29d) |  |  |  |  |
| 1.3.2.8.010 | Place PO for circuit breaker | 2011-09-24 → 2011-10-29 A (+35d) | 2011-10-27 → 2011-12-01 A (+35d) |  | 0% → 100% | 49.25d → none |  |
| 1.3.2.8.020 | Delivery of circuit breaker | 2012-05-26 → 2012-06-30 A (+35d) | 2012-05-30 → 2012-07-04 A (+35d) |  | 0% → 100% | 71.75d → none |  |
| 1.3.2.8.030 | Provision of startup spare parts & Non-material-req'ts | 2012-05-30 → 2012-06-30 A (+31d) | 2012-06-05 → 2012-07-04 A (+29d) |  | 0% → 100% | 71.75d → none | 1.3.2.8.020 → 1.3.2.8.020 FF |
| 9 | **ATS - Automatic Transfer Switch** | 2011-07-09 → 2011-10-15 (+98d) | 2012-04-07 → 2012-05-13 (+36d) |  |  |  |  |
| 1.3.2.9.010 | Place PO for ATS | 2011-07-09 → 2011-10-15 A (+98d) | 2011-08-11 → 2011-11-14 A (+95d) |  | 0% → 100% | 19.25d → none |  |
| 1.3.2.9.020 | Delivery of ATS | 2012-03-27 → 2012-05-01 A (+35d) | 2012-04-01 → 2012-05-07 A (+36d) |  | 0% → 100% | 156.75d → none | 1.3.2.9.010 FS+243.75d → 1.3.2.9.010 FS+182d |
| 1.3.2.9.030 | Provision of startup spare parts & Non-material-req'ts | 2012-04-01 → 2012-05-07 A (+36d) | 2012-04-07 → 2012-05-13 A (+36d) |  | 0% → 100% | 156.75d → none |  |
| 10 | **Switchboard** | 2011-10-29 → 2011-11-01 (+3d) | 2012-06-05 → 2012-05-23 (-13d) |  |  |  |  |
| 1.3.2.10.010 | Place PO for switchboards | 2011-10-29 → 2011-11-01 A (+3d) | 2011-12-01 → 2011-11-20 A (-11d) |  | 0% → 100% | 49.25d → none |  |
| 1.3.2.10.020 | Delivery of switchboards | 2012-05-26 → 2012-05-13 A (-13d) | 2012-05-30 → 2012-05-17 A (-13d) |  | 0% → 100% | 49.25d → none |  |
| 1.3.2.10.030 | Provision of startup spare parts & Non-material-req'ts | 2012-05-30 → 2012-05-17 A (-13d) | 2012-06-05 → 2012-05-23 A (-13d) |  | 0% → 100% | 49.25d → none |  |
| 11 | **Distribution Panel / Panel Boards** | 2011-08-07 → 2011-10-18 (+72d) | 2012-04-18 → 2012-04-23 (+5d) |  |  |  |  |
| 1.3.2.11.010 | Place PO for Distribution panel boards | 2011-08-07 → 2011-10-18 A (+72d) | 2011-09-10 → 2011-11-21 A (+72d) |  | 0% → 100% | 56.75d → none |  |
| 1.3.2.11.020 | Delivery of Distribution panel boards | 2012-04-08 → 2012-04-12 A (+4d) | 2012-04-12 → 2012-04-18 A (+6d) |  | 0% → 100% | 111.75d → none | 1.3.2.11.010 FS+225d → 1.3.2.11.010 FS+153d |
| 1.3.2.11.030 | Provision of startup spare parts & Non-material-req'ts | 2012-04-12 → 2012-04-18 A (+6d) | 2012-04-18 → 2012-04-23 A (+5d) |  | 0% → 100% | 111.75d → none |  |
| 12 | **Annunciator Panel** | 2011-09-05 → 2011-10-12 (+37d) | 2012-06-21 → 2012-05-10 (-42d) |  |  |  |  |
| 1.3.2.12.010 | Place PO for Annunciator panels | 2011-09-05 → 2011-10-12 A (+37d) | 2011-10-09 → 2011-11-12 A (+34d) |  | 0% → 100% | 56.75d → none |  |
| 1.3.2.12.020 | Delivery of Annunciator panels | 2012-06-11 → 2012-04-29 A (-43d) | 2012-06-16 → 2012-05-05 A (-42d) |  | 0% → 100% | 65.5d → none | 1.3.2.12.010 FS+262.5d → 1.3.2.12.010 FS+182d |
| 1.3.2.12.030 | Provision of startup spare parts & Non-material-req'ts | 2012-06-16 → 2012-05-05 A (-42d) | 2012-06-21 → 2012-05-10 A (-42d) |  | 0% → 100% | 65.5d → none |  |
| 13 | **Battery Bank, Battery Charger** | 2011-10-10 → 2011-11-07 (+28d) | 2012-06-21 → 2012-07-22 (+31d) |  |  |  |  |
| 1.3.2.13.010 | Place PO for Battery bank & charger | 2011-10-10 → 2011-11-07 A (+28d) | 2011-11-13 → 2011-12-06 A (+23d) |  | 0% → 100% | 76.75d → none |  |
| 1.3.2.13.020 | Delivery of Battery bank & charger | 2012-06-11 → 2012-07-17 A (+36d) | 2012-06-16 → 2012-07-22 A (+36d) |  | 0% → 100% | 76.75d → none | 1.3.2.13.010 FS+225d → 1.3.2.13.010 FS+240d |

| ID | Task | Start | Finish | Duration | Complete | Total float | Predecessors |
| --- | --- | --- | --- | --- | --- | --- | --- |
| 1.3.2.13.030 | Provision of startup spare parts & Non-material-req'ts | 2012-06-16 → 2012-07-17 A (+31d) | 2012-06-21 → 2012-07-22 A (+31d) |  | 0% → 100% | 76.75d → none | 1.3.2.13.020 → 1.3.2.13.020 FF |
| 14 | **UPS System** | 2011-07-09 → 2011-11-07 (+121d) | 2012-04-26 → 2012-07-23 (+88d) |  |  |  |  |
| 1.3.2.14.010 | Place PO for UPS | 2011-07-09 → 2011-11-07 A (+121d) | 2011-08-11 → 2011-12-06 A (+117d) |  | 0% → 100% | 19.25d → none |  |
| 1.3.2.14.020 | Delivery of UPS | 2012-04-14 → 2012-07-15 A (+92d) | 2012-04-21 → 2012-07-23 A (+93d) |  | 0% → 100% | 133d → none | 1.3.2.14.010 FS+262.5d → 1.3.2.14.010 FS+238d |
| 1.3.2.14.030 | Provision of startup spare parts & Non-material-req'ts | 2012-04-22 → 2012-07-17 A (+86d) | 2012-04-26 → 2012-07-22 A (+87d) |  | 0% → 100% | 133d → none | 1.3.2.14.020 → 1.3.2.14.020 SS+2d |
| 15 | **Electrical Grounding System** | 2011-08-30 → 2011-11-30 (+92d) | 2012-01-10 → 2012-03-22 (+72d) |  |  |  |  |
| 1.3.2.15.010 | Place PO for Electrical grounding system & Cables | 2011-08-30 → 2011-11-30 A (+92d) | 2011-10-03 → 2011-12-12 A (+70d) |  | 0% → 100% | 38d → none |  |
| 1.3.2.15.020 | Delivery of Electrical grounding system & Cables | 2011-12-31 A | 2012-01-04 → 2012-03-22 A (+78d) | 6d → 90d | 0% → 100% | 156.75d → none | 1.3.2.15.010 FS+93.75d → 1.3.2.15.010 |
| 1.3.2.15.030 | Provision of startup spare parts & Non-material-req'ts | 2012-01-04 A | 2012-01-10 A |  | 0% → 100% | 156.75d → none | 1.3.2.15.020 → 1.3.2.15.020 SS |
| 16 | **Electrical Conduits & Fittings** | 2011-08-30 → 2011-11-21 (+83d) | 2011-12-06 → 2012-01-25 (+50d) |  |  |  |  |
| 1.3.2.16.010 | Place PO for electrical conduits & fittings | 2011-08-30 → 2011-11-21 A (+83d) | 2011-10-03 → 2011-12-28 A (+86d) |  | 0% → 100% | 38d → none |  |
| 1.3.2.16.020 | Delivery of electrical conduits & fittings | 2011-11-26 A | 2011-11-30 → 2012-01-19 A (+50d) | 6d → 60d | 0% → 100% | 38d → none | 1.3.2.16.010 FS+56.25d → 1.3.2.16.010 |
| 1.3.2.16.030 | Provision of startup spare parts & Non-material-req'ts | 2011-11-30 A | 2011-12-06 → 2012-01-25 A (+50d) | 6d → 60d | 0% → 100% | 38d → none | 1.3.2.16.020 → 1.3.2.16.020 SS |
| 17 | **Fire Detection System & FACP** | 2011-10-04 → 2011-10-03 (-1d) | 2012-05-12 → 2012-05-19 (+7d) |  |  |  |  |
| 1.3.2.17.010 | Place PO for fire detection sytem & FACP | 2011-10-04 → 2011-10-03 A (-1d) | 2011-11-07 → 2011-11-03 A (-4d) |  | 0% → 100% | 71.75d → none |  |
| 1.3.2.17.020 | Delivery of fire detection sytem & FACP | 2012-05-01 → 2012-05-08 A (+7d) | 2012-05-06 → 2012-05-13 A (+7d) |  | 0% → 100% | 71.75d → none | 1.3.2.17.010 FS+187.5d → 1.3.2.17.010 FS+200d |
| 1.3.2.17.030 | Provision of startup spare parts & Non-material-req'ts | 2012-05-06 → 2012-05-13 A (+7d) | 2012-05-12 → 2012-05-19 A (+7d) |  | 0% → 100% | 71.75d → none |  |
| 18 | **Electrical Ductbank Materials** | 2011-07-19 → 2011-11-01 (+105d) | 2011-11-12 → 2011-12-28 (+46d) |  |  |  |  |
| 1.3.2.18.020 | Delivery of electrical ductbank materials | 2011-11-01 A | 2011-11-06 A |  | 0% → 100% | 64.25d → none | 1.3.2.18.010 SS+112.5d → 1.3.2.18.010 |
| 1.3.2.18.030 | Material receiving inspection & approval | 2012-04-01 → 2011-11-06 A (-147d) | 2012-04-07 → 2011-11-12 A (-147d) |  | 0% → 100% | 104.25d → none | 1.3.3.8.020 → 1.3.2.18.020 FF |
| 1.3.2.18.010 | Place PO for comm electrical ductbank materials | 2011-07-19 → 2011-11-21 A (+125d) | 2011-08-22 → 2011-12-28 A (+128d) |  | 0% → 100% | 64.25d → none |  |
| 19 | **Street Lighting Poles (For Patrol Roads)** | 2011-06-25 → 2011-04-21 (-65d) | 2011-08-14 → 2011-12-18 (+126d) |  |  |  |  |
| 1.3.2.19.010 | Place PO for street lighting poles (Patrol Roads) | 2011-06-25 → 2011-04-21 A (-65d) | 2011-06-30 → 2011-05-21 A (-40d) |  | 0% → 100% | 59d → none |  |
| 1.3.2.19.020 | Delivery of street lighting poles (Patrol Roads) | 2011-08-06 → 2011-06-08 A (-59d) | 2011-08-10 → 2011-12-18 A (+130d) |  | 0% → 100% | 101.5d → none |  |
| 1.3.2.19.030 | Provision of startup spare parts & Non-material-req'ts | 2012-04-16 → 2011-06-08 A (-313d) | 2012-04-22 → 2011-12-18 A (-126d) | 6d → 3.75d | 0% → 100% | 59.25d → none | 1.3.3.1.020 → 1.3.2.19.020 |
| 20 | **Street Light Poles (For Permanent Roads)** | 2011-09-11 → 2011-10-13 (+32d) | 2012-04-12 → 2012-05-05 (+23d) |  |  |  |  |
| 1.3.2.20.010 | Place PO for Light Poles (Permanent Roads) | 2011-09-11 → 2011-10-13 A (+32d) | 2011-10-08 → 2011-11-09 A (+32d) |  | 0% → 100% | 76.25d → none |  |
| 1.3.2.20.020 | Delivery of Light Poles (Permenent Roads) | 2012-03-31 → 2012-04-22 A (+22d) | 2012-04-05 → 2012-04-28 A (+23d) |  | 0% → 100% | 83.75d → none | 1.3.2.20.010 FS+186.25d → 1.3.2.20.010 FS+175d |
| 1.3.2.20.030 | Provision of startup spare parts & Non-material-req'ts | 2012-06-25 → 2012-04-29 A (-57d) | 2012-07-01 → 2012-05-05 A (-57d) | 6d → 7.5d | 0% → 100% | 69.25d → none | 1.3.3.2.020 → 1.3.2.20.020 |
| 21 | **Street Lighting Fixtures (For Patrol Roads)** | 2011-06-25 → 2011-03-12 (-105d) | 2011-08-13 → 2011-09-17 (+35d) |  |  |  |  |
| 1.3.2.21.010 | Place PO for street lighting fixtures (Patrol Roads) | 2011-06-25 → 2011-03-12 A (-105d) | 2011-06-30 → 2011-04-12 A (-79d) |  | 0% → 100% | 59d → none |  |
| 1.3.2.21.020 | Delivery of street lighting fixtures (Patrol Roads) | 2011-08-06 → 2011-08-13 A (+7d) | 2011-08-09 → 2011-09-17 A (+39d) |  | 0% → 100% | 102.5d → none |  |
| 1.3.2.21.030 | Provision of startup spare parts & Non-material-req'ts | 2012-07-14 → 2011-08-13 A (-336d) | 2012-07-19 → 2011-09-17 A (-306d) | 6d → 3.75d | 0% → 100% | 69.25d → none | 1.3.3.3.020 → 1.3.2.21.020 |
| 22 | **Street Light Fixtures (For Permenent Roads)** | 2011-09-11 → 2011-10-13 (+32d) | 2012-04-19 → 2012-05-07 (+18d) |  |  |  |  |
| 1.3.2.22.010 | Place PO for Light Fixtures (Permanent Roads) | 2011-09-11 → 2011-10-13 A (+32d) | 2011-10-15 → 2011-11-16 A (+32d) |  | 0% → 100% | 76.25d → none |  |
| 1.3.2.22.020 | Delivery of Light Fixtures (Permanent Roads) | 2012-04-07 → 2012-04-24 A (+17d) | 2012-04-12 → 2012-04-30 A (+18d) |  | 0% → 100% | 76.25d → none | 1.3.2.22.010 FS+186.25d → 1.3.2.22.010 FS+170d |
| 1.3.2.22.030 | Provision of startup spare parts & Non-material-req'ts | 2012-07-14 → 2012-05-01 A (-74d) | 2012-07-19 → 2012-05-07 A (-73d) | 6d → 7.5d | 0% → 100% | 56.75d → none | 1.3.3.4.020 → 1.3.2.22.020 |
| 23 | **LV Cables (For Patrol Roads)** | 2011-06-25 → 2011-08-03 (+39d) | 2011-08-10 → 2011-09-04 (+25d) |  |  |  |  |
| 1.3.2.23.020 | Delivery of LV cables (Patrol Roads) | 2011-08-03 A | 2011-08-07 A |  | 0% → 100% | 105d → none |  |
| 1.3.2.23.010 | Place PO for LV cables (Patrol Roads) | 2011-06-25 → 2011-08-04 A (+40d) | 2011-06-28 → 2011-09-04 A (+68d) |  | 0% → 100% | 59d → none |  |
| 1.3.2.23.030 | Provision of startup spare parts & Non-material-req'ts | 2012-01-09 → 2011-08-08 A (-154d) | 2012-01-15 → 2011-08-10 A (-158d) | 6d → 3.75d | 0% → 100% | 88d → none | 1.3.3.5.020 → 1.3.2.23.020 SS |
| 24 | **LV Cables (For Permanent Roads)** | 2011-09-01 → 2011-10-01 (+30d) | 2012-02-22 → 2012-04-11 (+49d) |  |  |  |  |
| 1.3.2.24.010 | Place PO for LV cables (Permanent Roads) | 2011-09-01 → 2011-10-01 A (+30d) | 2011-09-28 → 2011-11-16 A (+49d) |  | 0% → 100% | 25d → none | 1.3.4.13.010 SS → 1.3.2.23.010 SS |
| 1.3.2.24.020 | Delivery of LV Cables (Permanent Roads) | 2012-02-16 → 2012-04-05 A (+49d) | 2012-02-22 → 2012-04-11 A (+49d) |  | 0% → 100% | 25d → none |  |
| 1.3.2.24.030 | Provision of startup spare parts & Non-material-req'ts | 2012-03-01 → 2012-04-05 A (+35d) | 2012-03-07 → 2012-04-11 A (+35d) | 6d → 7.5d | 0% → 100% | 91.75d → none | 1.3.3.6.020 → 1.3.2.24.020 SS |
| 25 | **Volume & Fire Dampers** | 2011-07-06 → 2012-02-18 (+227d) | 2012-04-22 → 2012-05-29 (+37d) |  |  |  |  |
| 1.3.2.25.010 | Place PO for volume & fire dampers | 2011-07-06 → 2012-02-18 A (+227d) | 2011-08-02 → 2012-03-15 A (+226d) |  | 0% → 100% | 59d → none |  |
| 1.3.2.25.020 | Delivery of volume & fire dampers | 2012-04-04 → 2012-05-12 A (+38d) | 2012-04-12 → 2012-05-20 A (+38d) |  | 0% → 100% | 77.25d → none | 1.3.2.25.010 FS+262.5d → 1.3.2.25.010 FS+60d |
| 1.3.2.25.030 | Provision of startup spare parts & Non-material-req'ts | 2012-04-26 → 2012-05-21 A (+25d) | 2012-05-02 → 2012-05-29 A (+27d) | 6d → 10d | 0% → 100% | 153d → none | 1.3.3.9.020 → 1.3.2.25.020 |
| 26 | **Moduler Rectifier / Inverter** | 2011-07-06 → 2011-09-28 (+84d) | 2012-04-22 → 2012-07-02 (+71d) |  |  |  |  |
| 1.3.2.26.010 | Place PO for moduler rectifier / inverter | 2011-07-06 → 2011-09-28 A (+84d) | 2011-08-02 → 2011-10-25 A (+84d) |  | 0% → 100% | 59d → none | 1.3.2.25.010 SS → 1.3.2.23.010 SS |
| 1.3.2.26.020 | Delivery of moduler rectifier / inverter | 2012-04-04 → 2012-06-25 A (+82d) | 2012-04-12 → 2012-06-30 A (+79d) | 10d → 6d | 0% → 100% | 77.25d → none | 1.3.2.26.010 FS+262.5d → 1.3.2.26.010 FS+260d |
| 1.3.2.26.030 | Provision of startup spare parts & Non-material-req'ts | 2012-06-19 → 2012-06-26 A (+7d) | 2012-06-25 → 2012-07-02 A (+7d) |  | 0% → 100% | 150.5d → none | 1.3.3.10.020 → 1.3.2.26.020 FF+2d |
| 1 | **Fiber Optic Cables** | 2011-09-14 → 2011-12-01 (+78d) | 2012-07-19 → 2012-05-03 (-77d) |  |  |  |  |
| 1.3.3.1.010 | Place PO for fiber optic cables | 2011-09-14 → 2011-12-01 A (+78d) | 2011-10-18 → 2011-12-17 A (+60d) |  | 0% → 100% | 56.75d → none |  |
| 1.3.3.1.020 | Delivery of fiber optic cables | 2012-04-11 → 2012-04-22 A (+11d) | 2012-04-16 → 2012-04-28 A (+12d) |  | 0% → 100% | 59.25d → none | 1.3.3.1.010 FS+187.5d → 1.3.3.1.010 FS+137d |
| 1.3.3.1.030 | Provision of startup spare parts & Non-material-req'ts | 2012-08-09 → 2012-04-28 A (-103d) | 2012-08-14 → 2012-05-03 A (-103d) |  | 0% → 100% | 69d → none | 1.3.3.15.020 → 1.3.3.1.020 |
| 2 | **Patch Panels** | 2011-10-19 → 2012-02-18 (+122d) | 2012-07-01 → 2012-07-29 (+28d) |  |  |  |  |
| 1.3.3.2.010 | Place PO for fiber optic patch panels | 2011-10-19 → 2012-02-18 A (+122d) | 2011-11-22 → 2012-03-22 A (+121d) |  | 0% → 100% | 56.75d → none |  |
| 1.3.3.2.020 | Delivery of fiber optic patch panels | 2012-06-20 → 2012-07-18 A (+28d) | 2012-06-25 → 2012-07-23 A (+28d) |  | 0% → 100% | 69.25d → none | 1.3.3.2.010 FS+225d → 1.3.3.2.010 FS+125d |
| 1.3.3.2.030 | Provision of startup spare parts & Non-material-req'ts | 2012-06-10 → 2012-07-23 A (+43d) | 2012-06-14 → 2012-07-29 A (+45d) |  | 0% → 100% | 67.75d → none | 1.3.1.24.020 → 1.3.3.2.020 |
| 3 | **Splice Enclosure** | 2011-11-12 → 2012-03-12 (+121d) | 2012-07-19 → 2012-07-23 (+4d) |  |  |  |  |
| 1.3.3.3.010 | Place PO for fiber optic splice closure | 2011-11-12 → 2012-03-12 A (+121d) | 2011-12-15 → 2012-04-15 A (+122d) |  | 0% → 100% | 56.75d → none |  |
| 1.3.3.3.020 | Delivery of fiber optic splice closure | 2012-07-09 → 2012-07-18 A (+9d) | 2012-07-14 → 2012-07-23 A (+9d) |  | 0% → 100% | 69.25d → none | 1.3.3.3.010 FS+220d → 1.3.3.3.010 FS+100d |
| 1.3.3.3.030 | Provision of startup spare parts & Non-material-req'ts | 2012-05-30 → 2012-07-18 A (+49d) | 2012-06-05 → 2012-07-23 A (+48d) |  | 0% → 100% | 75.5d → none | 1.3.3.14.020 → 1.3.3.3.020 FF |
| 4 | **Copper Cables** | 2011-11-12 → 2011-11-20 (+8d) | 2012-07-19 → 2012-07-02 (-17d) |  |  |  |  |
| 1.3.3.4.010 | Place PO for copper cables | 2011-11-12 → 2011-11-20 A (+8d) | 2011-12-15 → 2011-12-24 A (+9d) |  | 0% → 100% | 56.75d → none | 1.3.3.3.010 SS → 1.3.2.26.010 SS |
| 1.3.3.4.020 | Delivery of copper cables | 2012-07-09 → 2012-06-21 A (-18d) | 2012-07-14 → 2012-06-27 A (-17d) |  | 0% → 100% | 56.75d → none | 1.3.3.4.010 FS+220d → 1.3.3.4.010 FS+193d |
| 1.3.3.4.030 | Provision of startup spare parts & Non-material-req'ts | 2011-11-30 → 2012-06-27 A (+210d) | 2011-12-06 → 2012-07-02 A (+209d) |  | 0% → 100% | 104.25d → none | 1.3.4.1.020 → 1.3.3.4.020 |
| 5 | **Comm Duct & Sub-duct Conduits & Fittings** | 2011-07-13 → 2011-12-05 (+145d) |  |  |  |  |  |

| ID | Task | Start | Finish | Duration | Complete | Total float | Predecessors | Other |
| --- | --- | --- | --- | --- | --- | --- | --- | --- |
| 1.3.3.5.010 | Place PO for comm duct & subduct conduits & fittings | 2011-07-13 → 2011-12-05 A (+145d) | 2011-08-16 → 2011-12-28 A (+134d) |  | 0% → 100% | 19.25d → none |  |  |
| 1.3.3.5.020 | Delivery of comm duct & subduct conduits & fittings | 2012-01-04 A | 2012-01-09 A |  | 0% → 100% | 88d → none | 1.3.3.5.010 FS+150d → 1.3.3.5.010 |  |
| 1.3.3.5.030 | Provision of startup spare parts & Non-material-req'ts | 2012-03-26 → 2012-01-09 A (-77d) | 2012-04-01 → 2012-01-15 A (-77d) |  | 0% → 100% | 158d → none | 1.3.4.2.020 → 1.3.3.5.020 SS |  |
| 6 | **Communication Cabinet & Accs** | 2011-07-31 → 2012-02-18 (+202d) | 2012-03-07 → 2012-05-29 (+83d) |  |  |  |  |  |
| 1.3.3.6.010 | Place PO for comm cabinet & accs | 2011-07-31 → 2012-02-18 A (+202d) | 2011-09-03 → 2012-03-22 A (+201d) |  | 0% → 100% | 19.25d → none |  |  |
| 1.3.3.6.020 | Delivery of comm cabinet & accs | 2012-02-26 → 2012-05-19 A (+83d) | 2012-03-01 → 2012-05-23 A (+83d) |  | 0% → 100% | 91.75d → none | 1.3.3.6.010 FS+187.5d → 1.3.3.6.010 FS+60d |  |
| 1.3.3.6.030 | Provision of startup spare parts & Non-material-req'ts | 2012-07-22 → 2012-05-23 A (-60d) | 2012-07-28 → 2012-05-29 A (-60d) |  | 0% → 100% | 63d → none | 1.3.4.3.020 → 1.3.3.6.020 |  |
| 7 | **Comm Cable Trays** | 2011-08-07 → 2011-09-28 (+52d) | 2012-03-03 → 2012-03-13 (+10d) |  |  |  |  |  |
| 1.3.3.7.010 | Place PO for cable trays | 2011-08-07 → 2011-09-28 A (+52d) | 2011-08-29 → 2011-10-20 A (+52d) |  | 0% → 100% | 66.75d → none |  |  |
| 1.3.3.7.020 | Delivery of cabel trays | 2012-02-21 → 2012-03-03 A (+11d) | 2012-02-26 → 2012-03-08 A (+11d) |  | 0% → 100% | 66.75d → none | 1.3.3.7.010 FS+187.5d → 1.3.3.7.010 FS+143d |  |
| 1.3.3.7.030 | Material receiving inspection & approval | 2012-01-10 → 2012-03-08 A (+58d) | 2012-01-15 → 2012-03-13 A (+58d) |  | 0% → 100% | 132.75d → none | 1.3.3.11.020 → 1.3.3.7.020 |  |
| 8 | **Telecomm Equipments** | 2011-08-30 → 2011-12-19 (+111d) | 2012-04-07 → 2012-05-13 (+36d) |  |  |  |  |  |
| 1.3.3.8.010 | Place PO for Telecfomm equipments | 2011-08-30 → 2011-12-19 A (+111d) | 2011-10-03 → 2012-01-11 A (+100d) |  | 0% → 100% | 19.25d → none | 1.3.3.6.010 SS+32.5d → 1.3.3.7.010 SS |  |
| 1.3.3.8.020 | Delivery of telecomm equipments | 2012-03-27 → 2012-05-02 A (+36d) | 2012-04-01 → 2012-05-07 A (+36d) |  | 0% → 100% | 104.25d → none | 1.3.3.8.010 FS+187.5d → 1.3.3.8.010 FS+120d |  |
| 1.3.3.8.030 | Material receiving inspection & approval | 2012-02-13 → 2012-05-07 A (+84d) | 2012-02-19 → 2012-05-13 A (+84d) |  | 0% → 100% | 95.5d → none | 1.3.3.12.020 → 1.3.3.8.020 |  |
| 9 | **Comm Copper Cable Closure** | 2011-08-30 → 2012-02-18 (+172d) | 2012-05-02 → 2012-05-20 (+18d) |  |  |  |  |  |
| 1.3.3.9.010 | Place PO for comm copper cable closure | 2011-08-30 → 2012-02-18 A (+172d) | 2011-09-24 → 2012-03-13 A (+171d) |  | 0% → 100% | 19.25d → none |  |  |
| 1.3.3.9.020 | Delivery of comm copper cable closure | 2012-04-22 → 2012-05-09 A (+17d) | 2012-04-26 → 2012-05-14 A (+18d) |  | 0% → 100% | 153d → none | 1.3.3.9.010 FS+225d → 1.3.3.9.010 FS+60d |  |
| 1.3.3.9.030 | Provision of startup spare parts & Non-material-req'ts | 2011-09-15 → 2012-05-14 A (+242d) | 2011-09-20 → 2012-05-20 A (+243d) |  | 0% → 100% | 45.25d → none | 1.3.4.5.020 → 1.3.3.9.020 |  |
| 10 | **Comm Grounding System** | 2011-09-08 → 2011-12-06 (+89d) | 2012-06-25 → 2012-03-26 (-91d) |  |  |  |  |  |
| 1.3.3.10.010 | Place PO for comm grounding system | 2011-09-08 → 2011-12-06 A (+89d) | 2011-10-12 → 2012-01-09 A (+89d) |  | 0% → 100% | 19.25d → none | 1.3.3.9.010 SS+10d → 1.3.3.7.010 |  |
| 1.3.3.10.020 | Delivery of comm grounding system | 2012-06-14 → 2012-03-15 A (-91d) | 2012-06-19 → 2012-03-20 A (-91d) |  | 0% → 100% | 150.5d → none | 1.3.3.10.010 FS+262.5d → 1.3.3.10.010 FS+70d |  |
| 1.3.3.10.030 | Provision of startup spare parts & Non-material-req'ts | 2011-09-15 → 2012-03-20 A (+187d) | 2011-09-20 → 2012-03-26 A (+188d) |  | 0% → 100% | 76.5d → none | 1.3.4.6.020 → 1.3.3.10.020 |  |
| 11 | **Comm FOC [Fiber Optic Cable] Manholes** | 2011-07-13 → 2012-02-18 (+220d) | 2012-01-15 → 2012-05-29 (+135d) |  |  |  |  |  |
| 1.3.3.11.010 | Place PO for FOC Manholes | 2011-07-13 → 2012-02-18 A (+220d) | 2011-08-16 → 2012-03-22 A (+219d) |  | 0% → 100% | 64.25d → none |  |  |
| 1.3.3.11.020 | Delivery of comm manhole materials | 2012-01-04 → 2012-05-19 A (+136d) | 2012-01-09 → 2012-05-23 A (+135d) |  | 0% → 100% | 132.75d → none | 1.3.3.11.010 FS+150d → 1.3.3.11.010 FS+60d |  |
| 1.3.3.11.030 | Material receiving inspection & approval | 2011-12-11 → 2012-05-24 A (+165d) | 2011-12-17 → 2012-05-29 A (+164d) |  | 0% → 100% | 176.75d → none | 1.3.3.13.020 → 1.3.3.11.020 |  |
| 12 | **Comm Copper Cable Manholes** | 2011-07-13 → 2012-02-18 (+220d) | 2012-02-19 → 2012-05-29 (+100d) |  |  |  |  |  |
| 1.3.3.12.010 | Place PO for Copper cable Manholes | 2011-07-13 → 2012-02-18 A (+220d) | 2011-08-16 → 2012-03-22 A (+219d) |  | 0% → 100% | 64.25d → none |  |  |
| 1.3.3.12.020 | Delivery of comm copper cable manhole materials | 2012-02-08 → 2012-05-19 A (+101d) | 2012-02-13 → 2012-05-23 A (+100d) |  | 0% → 100% | 95.5d → none | 1.3.3.12.010 FS+187.5d → 1.3.3.12.010 FS+60d |  |
| 1.3.3.12.030 | Material receiving inspection & approval | 2011-11-06 → 2012-05-23 A (+199d) | 2011-11-12 → 2012-05-29 A (+199d) |  | 0% → 100% | 64.25d → none | 1.3.2.18.020 → 1.3.3.12.020 |  |
| 13 | **Comm Concrete Ductbank Materials** | 2011-07-19 → 2011-12-05 (+139d) | 2011-12-17 → 2011-12-28 (+11d) |  |  |  |  |  |
| 1.3.3.13.010 | Place PO for comm concrete ductbank materials | 2011-07-19 → 2011-12-05 A (+139d) | 2011-08-22 → 2011-12-28 A (+128d) |  | 0% → 100% | 64.25d → none | 1.3.3.12.010 SS+6.25d → 1.3.3.7.010 SS |  |
| 1.3.3.13.020 | Delivery of comm ductbank materials | 2011-12-06 A | 2011-12-11 A |  | 0% → 100% | 176.75d → none | 1.3.3.13.010 SS+150d → 1.3.3.13.010 |  |
| 1.3.3.13.030 | Material receiving inspection & approval | 2012-03-21 → 2011-12-11 A (-101d) | 2012-03-27 → 2011-12-17 A (-101d) |  | 0% → 100% | 19.25d → none | 1.3.1.23.020 → 1.3.3.13.020 SS |  |
| 14 | **Communication CCTV System** | 2011-09-24 → 2012-02-18 (+147d) | 2012-06-05 → 2012-06-20 (+15d) |  |  |  |  |  |
| 1.3.3.14.010 | Place PO for CCTV system materials | 2011-09-24 → 2012-02-18 A (+147d) | 2011-10-27 → 2012-03-22 A (+147d) |  | 0% → 100% | 19.25d → none | 1.3.3.10.010 SS+16.25d → 1.3.3.10.010 SS |  |
| 1.3.3.14.020 | Delivery of CCTV system materials | 2012-05-26 → 2012-06-16 A (+21d) | 2012-05-30 → 2012-06-20 A (+21d) |  | 0% → 100% | 75.5d → none | 1.3.3.14.010 FS+225d → 1.3.3.14.010 FS+90d |  |
| 1.3.3.14.030 | Provision of startup spare parts & Non-material-req'ts | 2012-01-25 → 2012-06-16 A (+143d) | 2012-01-31 → 2012-06-20 A (+141d) |  | 0% → 100% | 38d → none | 1.3.4.7.020 → 1.3.3.14.020 FF |  |
| 15 | **Communication SACS System** | 2011-10-29 → 2012-02-27 (+121d) | 2012-08-14 → 2012-07-11 (-34d) |  |  |  |  |  |
| 1.3.3.15.010 | Place PO for Comm SACS System | 2011-10-29 → 2012-02-27 A (+121d) | 2011-12-01 → 2012-04-01 A (+122d) |  | 0% → 100% | 69d → none | 1.3.3.14.010 SS+37.5d → 1.3.3.14.010 SS+10d |  |
| 1.3.3.15.020 | Delivery of comm SACS system | 2012-08-04 → 2012-07-04 A (-31d) | 2012-08-08 → 2012-07-09 A (-30d) |  | 0% → 100% | 69d → none | 1.3.3.15.010 FS+262.5d → 1.3.3.15.010 FS+100d |  |
| 1.3.3.15.030 | Provision of startup spare parts & Non-material-req'ts | 2012-04-30 → 2012-07-05 A (+66d) | 2012-05-06 → 2012-07-11 A (+66d) |  | 0% → 100% | 71.75d → none | 1.3.4.8.020 → 1.3.3.15.020 FF+2d |  |
| 1.3.3.16.030 | Provision of startup spare parts & Non-material-req'ts | 2012-04-18 → 2012-04-14 A (-4d) | 2012-04-24 → 2012-04-18 A (-6d) |  | 0% → 100% | 94.25d → none | 1.3.4.9.020 → 1.3.3.16.020 | resources SSH-Procurement Manhours → none |
| 1.3.3.17.030 | Provision of startup spare parts & Non-material-req'ts | 2012-04-22 → 2012-07-01 A (+70d) | 2012-04-26 → 2012-07-05 A (+70d) |  | 0% → 100% | 91.5d → none | 1.3.4.10.020 → 1.3.3.17.020 | resources SSH-Procurement Manhours → none |
| 1.3.3.18.030 | Provision of startup spare parts & Non-material-req'ts | 2012-01-14 → 2012-06-30 A (+168d) | 2012-01-19 → 2012-07-05 A (+168d) |  | 0% → 100% | 56.75d → none | 1.3.4.11.020 → 1.3.3.18.020 FF | resources SSH-Procurement Manhours → none |
| 1.3.4.1.010 | Place PO for potable / fire water /sewer pipe (RTR) | 2011-07-16 → 2011-08-13 A (+28d) | 2011-08-11 → 2011-09-12 A (+32d) |  | 0% → 100% | 25d → none |  |  |
| 1.3.4.1.020 | Delivery of RTR & fittings | 2011-11-26 → 2012-02-18 A (+84d) | 2011-11-30 → 2012-02-22 A (+84d) |  | 0% → 100% | 104.25d → none | 1.3.4.1.010 FS+112.5d → 1.3.4.1.010 FS+150d |  |
| 1.3.4.1.030 | Provision of startup spare parts & Non-material-req'ts | 2012-04-30 → 2012-02-22 A (-68d) | 2012-05-06 → 2012-02-28 A (-68d) |  | 0% → 100% | 120.5d → none | 1.3.4.12.020 → 1.3.4.1.020 |  |
| 2 | **Potable & Fire water valves & accs** | 2011-07-20 → 2012-02-18 (+213d) | 2012-04-01 → 2012-09-12 (+164d) |  |  |  |  |  |
| 1.3.4.2.010 | Place PO for potable & fire water valves | 2011-07-20 → 2012-02-18 A (+213d) | 2011-08-23 → 2012-03-22 A (+212d) |  | 0% → 100% | 38d → none |  |  |
| 1.3.4.2.020 | Delivery of valves & accs | 2012-03-21 → 2012-09-08 A (+171d) | 2012-03-26 → 2012-09-12 A (+170d) |  | 0% → 100% | 158d → none | 1.3.4.2.010 FS+225d → 1.3.4.2.010 FS+180d |  |
| 1.3.4.2.030 | Provision of startup spare parts & Non-material-req'ts | 2012-05-03 → 2012-09-08 A (+128d) | 2012-05-09 → 2012-09-12 A (+126d) |  | 0% → 100% | 36d → none | 1.3.4.13.020 → 1.3.4.2.020 FF |  |
| 3 | **Fire Hydrants & Accs** | 2011-12-19 → 2011-09-05 (-105d) | 2012-07-28 → 2012-04-15 (-104d) |  |  |  |  |  |
| 1.3.4.3.010 | Place PO for fire hydrants & accs | 2011-12-19 → 2011-09-05 A (-105d) | 2012-01-22 → 2011-09-21 A (-123d) |  | 0% → 100% | 63d → none | 1.3.4.2.010 FS+125d → 1.3.4.1.010 SS |  |
| 1.3.4.3.020 | Delivery of fire hydranst | 2012-07-17 → 2012-04-04 A (-104d) | 2012-07-22 → 2012-04-09 A (-104d) |  | 0% → 100% | 63d → none | 1.3.4.3.010 FS+188.75d → 1.3.4.3.010 FS+210d |  |
| 1.3.4.3.030 | Provision of startup spare parts & Non-material-req'ts | 2012-04-21 → 2012-04-09 A (-12d) | 2012-04-26 → 2012-04-15 A (-11d) |  | 0% → 100% | 49.75d → none | 1.3.4.14.020 → 1.3.4.3.020 |  |
| 4 | **Submersible Pumps (Lift Station Pumps)** | 2011-07-09 → 2011-08-28 (+50d) | 2012-05-12 → 2012-05-22 (+10d) |  |  |  |  |  |
| 1.3.4.4.010 | Place PO for Submersible pumps | 2011-07-09 → 2011-08-28 A (+50d) | 2011-08-11 → 2011-10-01 A (+51d) |  | 0% → 100% | 19.25d → none |  |  |
| 1.3.4.4.020 | Delivery of Submersible pumps | 2012-05-01 → 2012-05-12 A (+11d) | 2012-05-06 → 2012-05-16 A (+10d) |  | 0% → 100% | 89.25d → none | 1.3.4.4.010 FS+281.25d → 1.3.4.4.010 FS+239d |  |
| 1.3.4.4.030 | Provision of startup spare parts & Non-material-req'ts | 2011-08-10 → 2012-05-17 A (+281d) | 2011-08-14 → 2012-05-22 A (+282d) | 3.75d → 6d | 0% → 100% | 101.5d → none | 1.3.2.19.020 → 1.3.4.4.020 |  |
| 5 | **Sewer FRP Manholes** | 2011-07-16 → 2011-06-19 (-27d) |  |  |  |  |  |  |
| 1.3.4.5.010 | Place PO for sewer FRP Manhole | 2011-07-16 → 2011-06-19 A (-27d) | 2011-08-10 → 2011-07-19 A (-22d) |  | 0% → 100% | 25d → none |  |  |
| 1.3.4.5.020 | Delivery of sewer FRP Manhole | 2011-09-12 A | 2011-09-14 A |  | 0% → 100% | 45.25d → none |  |  |
| 1.3.4.5.030 | Provision of startup spare parts & Non-material-req'ts | 2011-08-10 → 2011-09-15 A (+36d) | 2011-08-13 → 2011-09-20 A (+38d) | 3.75d → 6d | 0% → 100% | 102.5d → none | 1.3.2.21.020 → 1.3.4.5.020 SS |  |
| 6 | **Sewer pipes (uPVC) & Fittings** | 2011-07-16 → 2011-06-28 (-18d) |  |  |  |  |  |  |
| 1.3.4.6.010 | Place PO for sewer (uPVC) pipes | 2011-07-16 → 2011-06-28 A (-18d) | 2011-08-15 → 2011-07-28 A (-18d) |  | 0% → 100% | 76.5d → none |  |  |
| 1.3.4.6.020 | Delivery of sewer (uPVC) pipes | 2011-09-13 A | 2011-09-14 A |  | 0% → 100% | 76.5d → none |  |  |
| 1.3.4.6.030 | Provision of startup spare parts & Non-material-req'ts | 2011-08-08 → 2011-09-15 A (+38d) | 2011-08-10 → 2011-09-20 A (+41d) | 3.75d → 6d | 0% → 100% | 105d → none | 1.3.2.23.020 → 1.3.4.6.020 SS |  |
| 7 | **Plumbing Fixtures & Accs** | 2011-07-30 → 2012-02-27 (+212d) | 2012-01-31 → 2012-05-19 (+109d) |  |  |  |  |  |

| ID | Task | Start | Finish | Duration | Complete | Total float | Predecessors | Other |
| --- | --- | --- | --- | --- | --- | --- | --- | --- |
| 1.3.4.7.010 | Place PO for Plumbing fixtures & accs | 2011-07-30 → 2012-02-27 A (+212d) | 2011-09-01 → 2012-04-01 A (+213d) |  | 0% → 100% | 38d → none |  |  |
| 1.3.4.7.020 | Delivery of Plumbing fixtures & accs | 2012-01-21 → 2012-05-14 A (+114d) | 2012-01-25 → 2012-05-19 A (+115d) |  | 0% → 100% | 38d → none | 1.3.4.7.010 FS+150d → 1.3.4.7.010 FS+45d |  |
| 1.3.4.7.030 | Provision of startup spare parts & Non-material-req'ts | 2012-04-07 → 2012-05-14 A (+37d) | 2012-04-12 → 2012-05-19 A (+37d) | 7.5d → 6d | 0% → 100% | 83.75d → none | 1.3.2.20.020 → 1.3.4.7.020 FF |  |
| 8 | **Sewer pipes valve & accs** | 2011-07-30 → 2012-02-27 (+212d) | 2012-05-06 → 2012-08-21 (+107d) |  |  |  |  |  |
| 1.3.4.8.010 | Place PO for sewer valves & accs | 2011-07-30 → 2012-02-27 A (+212d) | 2011-08-23 → 2012-03-22 A (+212d) |  | 0% → 100% | 71.75d → none |  |  |
| 1.3.4.8.020 | Delivery of sewer valves & accs | 2012-04-25 → 2012-08-11 A (+108d) | 2012-04-30 → 2012-08-15 A (+107d) |  | 0% → 100% | 71.75d → none | 1.3.4.8.010 FS+262.5d → 1.3.4.8.010 FS+150d |  |
| 1.3.4.8.030 | Provision of startup spare parts & Non-material-req'ts | 2012-04-14 → 2012-08-15 A (+123d) | 2012-04-19 → 2012-08-21 A (+124d) | 7.5d → 6d | 0% → 100% | 76.25d → none | 1.3.2.22.020 → 1.3.4.8.020 |  |
| 9 | **Sewer - odour control system** | 2011-07-16 → 2011-09-18 (+64d) | 2012-04-24 → 2012-05-19 (+25d) |  |  |  |  |  |
| 1.3.4.9.010 | Place PO for sewer odour control system | 2011-07-16 → 2011-09-18 A (+64d) | 2011-08-11 → 2011-10-03 A (+53d) |  | 0% → 100% | 25d → none |  |  |
| 1.3.4.9.020 | Delivery of sewer odour control system | 2012-04-14 → 2012-05-08 A (+24d) | 2012-04-18 → 2012-05-13 A (+25d) |  | 0% → 100% | 94.25d → none | 1.3.4.9.010 FS+262.5d → 1.3.4.9.010 FS+234d |  |
| 1.3.4.9.030 | Provision of startup spare parts & Non-material-req'ts | 2012-02-16 → 2012-05-14 A (+88d) | 2012-02-22 → 2012-05-19 A (+87d) | 7.5d → 6d | 0% → 100% | 25d → none | 1.3.2.24.020 SS → 1.3.4.9.020 |  |
| 10 | **Ductile Iron pipes & Fittings** | 2011-09-28 → 2011-10-20 (+22d) | 2012-04-26 → 2012-05-15 (+19d) |  |  |  |  |  |
| 1.3.4.10.010 | Place PO for ductile iron pipes & fittings | 2011-09-28 → 2011-10-20 A (+22d) | 2011-10-25 → 2011-11-16 A (+22d) |  | 0% → 100% | 91.5d → none |  |  |
| 1.3.4.10.020 | Delivery of ductile iron pipes & fittings | 2012-04-18 → 2012-05-07 A (+19d) | 2012-04-21 → 2012-05-10 A (+19d) |  | 0% → 100% | 91.5d → none | 1.3.4.10.010 FS+187.5d → 1.3.4.10.010 FS+184d |  |
| 1.3.4.10.030 | Provision of startup spare parts & Non-material-req'ts | 2012-04-02 → 2012-05-10 A (+38d) | 2012-04-10 → 2012-05-15 A (+35d) | 10d → 6d | 0% → 100% | 89.75d → none | 1.3.4.15.020 → 1.3.4.10.020 |  |
| 11 | **Irrigation pipeline & fittings** | 2011-07-16 → 2011-09-10 (+56d) | 2012-01-19 → 2012-01-08 (-11d) |  |  |  |  |  |
| 1.3.4.11.010 | Place PO for irrigation pipeline & fittings | 2011-07-16 → 2011-09-10 A (+56d) | 2011-08-21 → 2011-10-10 A (+50d) |  | 0% → 100% | 25d → none |  |  |
| 1.3.4.11.020 | Delivery of irrigation pipeline & fittings | 2012-01-09 → 2011-12-27 A (-13d) | 2012-01-14 → 2012-01-01 A (-13d) |  | 0% → 100% | 56.75d → none |  |  |
| 1.3.4.11.030 | Provision of startup spare parts & Non-material-req'ts | 2012-04-14 → 2012-01-03 A (-102d) | 2012-04-22 → 2012-01-08 A (-105d) | 10d → 6d | 0% → 100% | 77.25d → none | 1.3.2.25.020 → 1.3.4.11.020 |  |
| 12 | **Irrigation valves & accs** | 2011-07-27 → 2012-02-18 (+206d) | 2012-05-06 → 2012-09-20 (+137d) |  |  |  |  |  |
| 1.3.4.12.010 | Place PO for irrigation valves & accs | 2011-07-27 → 2012-02-18 A (+206d) | 2011-08-23 → 2012-03-15 A (+205d) |  | 0% → 100% | 25d → none |  |  |
| 1.3.4.12.020 | Delivery of irrigation valves & accs | 2012-04-25 → 2012-09-10 A (+138d) | 2012-04-30 → 2012-09-15 A (+138d) |  | 0% → 100% | 120.5d → none | 1.3.4.12.010 FS+262.5d → 1.3.4.12.010 FS+190d |  |
| 1.3.4.12.030 | Provision of startup spare parts & Non-material-req'ts | 2012-04-14 → 2012-09-15 A (+154d) | 2012-04-22 → 2012-09-20 A (+151d) | 10d → 6d | 0% → 100% | 77.25d → none | 1.3.2.26.020 → 1.3.4.12.020 |  |
| 13 | **Irrigation controllers** | 2011-09-01 → 2012-03-17 (+198d) | 2012-05-09 → 2012-09-13 (+127d) |  |  |  |  |  |
| 1.3.4.13.010 | Place PO for irrigation controllers | 2011-09-01 → 2012-03-17 A (+198d) | 2011-09-28 → 2012-04-12 A (+197d) |  | 0% → 100% | 25d → none | 1.3.4.12.010 SS+38.75d → 1.3.4.12.010 |  |
| 1.3.4.13.020 | Delivery of irrigation controllers | 2012-04-26 → 2012-09-01 A (+128d) | 2012-05-03 → 2012-09-08 A (+128d) |  | 0% → 100% | 36d → none | 1.3.4.13.010 FS+225d → 1.3.4.13.010 FS+150d |  |
| 1.3.4.13.030 | Provision of startup spare parts & Non-material-req'ts | 2012-05-05 → 2012-09-08 A (+126d) | 2012-05-13 → 2012-09-13 A (+123d) | 10d → 6d | 0% → 100% | 116.75d → none | 1.3.4.16.020 → 1.3.4.13.020 |  |
| 14 | **Irrigation Junction Boxes** | 2011-09-25 → 2012-03-26 (+183d) | 2012-04-26 → 2012-08-26 (+122d) |  |  |  |  |  |
| 1.3.4.14.010 | Place PO for irrigation junction boxes | 2011-09-25 → 2012-03-26 A (+183d) | 2011-10-22 → 2012-04-22 A (+183d) |  | 0% → 100% | 49.75d → none | 1.3.4.13.010 SS+25d → 1.3.4.13.010 SS+10d |  |
| 1.3.4.14.020 | Delivery of irrigation junction boxes | 2012-04-14 → 2012-08-13 A (+121d) | 2012-04-21 → 2012-08-20 A (+121d) |  | 0% → 100% | 49.75d → none | 1.3.4.14.010 FS+186.25d → 1.3.4.14.010 FS+120d |  |
| 15 | **HVAC Equipments** | 2011-06-25 → 2011-12-15 (+173d) | 2012-04-10 → 2012-04-24 (+14d) |  |  |  |  |  |
| 1.3.4.15.010 | Place PO for HVAC Equipments | 2011-06-25 → 2011-12-15 A (+173d) | 2011-07-21 → 2012-01-09 A (+172d) |  | 0% → 100% | 59d → none |  |  |
| 1.3.4.15.020 | Delivery of HVAC Equipments | 2012-03-24 → 2012-04-07 A (+14d) | 2012-04-01 → 2012-04-15 A (+14d) |  | 0% → 100% | 89.75d → none | 1.3.4.15.010 FS+262.5d → 1.3.4.15.010 FS+95d |  |
| 16 | **Exhaust Fans** | 2011-07-27 → 2011-09-03 (+38d) | 2012-05-13 → 2012-05-31 (+18d) |  |  |  |  |  |
| 1.3.4.16.010 | Place PO for exhaust fans | 2011-07-27 → 2011-09-03 A (+38d) | 2011-08-23 → 2011-10-03 A (+41d) |  | 0% → 100% | 59d → none |  |  |
| 1.3.4.16.020 | Delivery of exhasust fans | 2012-04-25 → 2012-05-14 A (+19d) | 2012-05-03 → 2012-05-22 A (+19d) |  | 0% → 100% | 116.75d → none | 1.3.4.16.010 FS+262.5d → 1.3.4.16.010 FS+240d |  |
| C.1.4 | **CONSTRUCTION** | 2011-01-09 → 2011-01-20 (+11d) | 2013-06-29 → 2014-01-04 (+189d) |  |  |  |  |  |
| 1 | **MOBILIZATION** | 2011-01-09 → 2011-01-20 (+11d) | 2011-09-28 → 2013-01-09 (+469d) |  |  |  |  |  |
| 1 | **Mobilization** | 2011-01-09 → 2011-01-20 (+11d) | 2011-03-10 → 2012-01-15 (+311d) |  |  |  |  |  |
| 2 | **Mobilization of Temp. Fac. @ Zone 4** | 2011-01-09 → 2011-01-20 (+11d) | 2011-03-10 → 2012-01-15 (+311d) |  |  |  |  |  |
| 1.4.1.1.110 | Install of temp fence at zone 4 | 2011-01-09 → 2011-01-20 A (+11d) | 2011-02-14 → 2011-02-22 A (+8d) |  | 0% → 100% | 46.25d → none |  | resources SSH-Construction Manhours [19200 h] → SSH-Construction Manhours [1678 h] |
| 1.4.1.1.220 | Mobilization of equipments | 2011-02-01 A | 2011-02-28 → 2011-09-20 A (+204d) |  | 0% → 100% | 117.5d → none |  | resources SSH-Construction Manhours [19200 h] → SSH-Construction Manhours [19982 h] |
| 1.4.1.1.230 | Mobilization of Manpower | 2011-02-10 A | 2011-03-10 → 2012-01-15 A (+311d) |  | 0% → 100% | 117.5d → none |  | resources SSH-Construction Manhours [25000 h] → SSH-Construction Manhours [4920 h] |
| 1.4.1.1.120 | Construction of SAPMT office | 2011-02-01 → 2011-02-26 A (+25d) | 2011-03-01 → 2011-03-20 A (+19d) |  | 0% → 100% | 127.5d → none |  | resources SSH-Construction Manhours [15000 h] → SSH-Construction Manhours [4612 h] |
| 1.4.1.1.130 | Const/Install of laydown yards | 2011-01-20 → 2011-02-26 A (+37d) | 2011-02-26 → 2011-03-24 A (+26d) |  | 0% → 100% | 117.5d → none |  | resources SSH-Construction Manhours [19200 h] → SSH-Construction Manhours [3074 h] |
| 1.4.1.1.210 | Construction of contractor site offices | 2011-01-18 → 2011-02-26 A (+39d) | 2011-02-23 → 2011-03-20 A (+25d) |  | 0% → 100% | 46.25d → none |  | resources SSH-Construction Manhours [19200 h] → SSH-Construction Manhours [3074 h] |
| 1.4.1.1.150 | Install water supply system for offices | 2011-02-22 → 2011-03-01 A (+7d) | 2011-03-07 → 2011-03-14 A (+7d) |  | 0% → 100% | 46.25d → none |  | resources SSH-Construction Manhours [9600 h] → SSH-Construction Manhours [615 h] |
| 1.4.1.1.140 | Install electric lighting system for site offices | 2011-02-10 → 2011-03-10 A (+28d) | 2011-02-28 → 2011-03-31 A (+31d) |  | 0% → 100% | 46.25d → none |  | resources SSH-Construction Manhours [9600 h] → SSH-Construction Manhours [1537 h] |
| 1.4.1.1.160 | Install sanitary system for offices | 2011-02-28 → 2011-03-15 A (+15d) | 2011-03-09 → 2011-03-28 A (+19d) |  | 0% → 100% | 46.25d → none |  | resources SSH-Construction Manhours [9000 h] → SSH-Construction Manhours [461 h] |
| 1.4.1.1.170 | Install fire protection sytem for offices | 2011-03-02 → 2011-03-24 A (+22d) | 2011-03-09 → 2011-03-28 A (+19d) |  | 0% → 100% | 118.75d → none |  | resources SSH-Construction Manhours [7000 h] → SSH-Construction Manhours [153 h] |
| 1.4.1.1.180 | Install furniture & accs in offices | 2011-03-02 → 2011-04-12 A (+41d) | 2011-03-09 → 2011-05-10 A (+62d) |  | 0% → 100% | 118.75d → none |  | resources SSH-Construction Manhours [7000 h] → SSH-Construction Manhours [768 h] |
| 1.4.1.1.190 | Install computers / equipments & accs in offices | 2011-03-02 → 2011-05-22 A (+81d) | 2011-03-09 → 2011-05-30 A (+82d) |  | 0% → 100% | 118.75d → none |  | resources SSH-Construction Manhours [7000 h] → SSH-Construction Manhours [922 h] |
| 1.4.1.1.200 | Install telecomm system for offices | 2011-03-02 → 2011-05-22 A (+81d) | 2011-03-09 → 2011-05-30 A (+82d) |  | 0% → 100% | 118.75d → none |  | resources SSH-Construction Manhours [7000 h] → SSH-Construction Manhours [461 h] |
| 2 | **Demolition of existing structure** | 2011-06-09 → 2011-06-12 (+3d) | 2011-09-28 → 2011-09-26 (-2d) |  |  |  |  |  |
| 1 | **Demolition of existing structure** | 2011-06-09 → 2011-06-12 (+3d) | 2011-09-28 → 2011-09-26 (-2d) |  |  |  |  |  |
| 1 | **Zone 2** | 2011-07-24 → 2011-06-13 (-41d) | 2011-09-17 → 2011-07-25 (-54d) |  |  |  |  |  |
| 1.4.1.2.1.010 | Demolition of existing laydown yard etc. | 2011-07-24 → 2011-06-13 A (-41d) | 2011-08-20 → 2011-06-25 A (-56d) |  | 0% → 100% | 195d → none | 1.4.1.3.2.010, M1.00 FS+15d, 1.4.1.1.120, 1.4.1.1.200 → 1.4.1.1.200 | resources SSH-Construction Manhours [12000 h] → SSH-Construction Manhours [8083 h] |
| 1.4.1.2.1.020 | Demolition of existing asphalt pavement | 2011-08-21 → 2011-07-03 A (-49d) | 2011-09-17 → 2011-07-25 A (-54d) |  | 0% → 100% | 195d → none |  | resources SSH-Construction Manhours [12000 h] → SSH-Construction Manhours [10086 h] |
| 2 | **Zone 3** | 2011-06-09 → 2011-06-12 (+3d) | 2011-09-28 → 2011-09-26 (-2d) |  |  |  |  |  |
| 1.4.1.2.2.010 | Demolition of existing concrete pad/structure | 2011-06-09 → 2011-06-12 A (+3d) | 2011-07-06 → 2011-06-25 A (-11d) |  | 0% → 100% | 106.25d → none | 1.4.1.3.3.010 → 1.4.1.2.1.010 SS | resources SSH-Construction Manhours [7200 h] → SSH-Construction Manhours [3195 h] |
| 1.4.1.2.2.020 | Demolition of septic tank | 2011-07-07 A | 2011-08-03 → 2011-08-01 A (-2d) |  | 0% → 100% | 106.25d → none |  | was named Demolition of existing porta cabin , tank; resources SSH-Construction Manhours [16800 h] → SSH-Construction Manhours [270 h] |
| 1.4.1.2.2.030 | Demolition of bldg foundations | 2011-08-04 → 2011-08-08 A (+4d) | 2011-08-31 → 2011-09-04 A (+4d) |  | 0% → 100% | 106.25d → none |  | was named Demolition of existing temporary bldgs; resources SSH-Construction Manhours [12000 h] → SSH-Construction Manhours [23867 h] |
| 1.4.1.2.2.040 | Demolition of generator shed foundations | 2011-09-01 → 2011-09-12 A (+11d) | 2011-09-28 → 2011-09-26 A (-2d) |  | 0% → 100% | 106.25d → none |  | was named Demolition of existing generator shed; resources SSH-Construction Manhours [12000 h] → SSH-Construction Manhours [693 h] |
| 3 | **Site Preparation** | 2011-04-10 → 2011-04-12 (+2d) | 2011-06-08 → 2013-01-09 (+581d) |  |  |  |  |  |
| 1 | **Site Topographic Survey & Layout** | 2011-05-03 → 2011-05-07 (+4d) | 2011-06-28 → 2011-06-22 (-6d) |  |  |  |  |  |
| 1 | **Site Topographic Survey & Layout** | 2011-05-03 → 2011-05-07 (+4d) | 2011-06-28 → 2011-06-22 (-6d) |  |  |  |  |  |
| 1.4.1.3.010 | Site topographic survey & survey layout & stacking | 2011-05-03 → 2011-05-07 A (+4d) | 2011-05-31 → 2011-06-05 A (+5d) |  | 0% → 100% | 61.25d → none |  | resources SSH-Construction Manhours [20001.2 h] → SSH-Construction Manhours [1420 h] |
| 1.4.1.3.020 | Geotechnical Soil Investigation | 2011-05-31 → 2011-05-25 A (-6d) | 2011-06-28 → 2011-06-22 A (-6d) |  | 0% → 100% | 61.25d → none |  | resources SSH-Construction Manhours [25000 h] → SSH-Construction Manhours [7217 h] |
| 2 | **Zone 1** | 2011-04-10 → 2011-04-12 (+2d) | 2011-06-08 → 2013-01-09 (+581d) |  |  |  |  |  |
| 2 | **Site Preparation** | none → 2011-04-12 | none → 2013-01-09 |  |  |  |  |  |

| ID | Task | Start | Finish | Duration | Complete | Total float | Predecessors | Other |
| --- | --- | --- | --- | --- | --- | --- | --- | --- |
| Z1.1010 | Site clearing/grubbing/disposal zone1 | 2011-04-10 → 2011-04-12 A (+2d) | 2011-04-23 → 2011-04-25 A (+2d) |  | 0% → 100% | 110d → none |  | resources SSH-Construction Manhours [10500 h]; Grader [120 h]; Dump Truck [120 h] → SSH-Construction Manhours [1461 h] |
| Z1.1020 | Cutting/backfilling/grading zone1 | 2011-04-24 → 2011-04-25 A (+1d) | 2011-05-16 → 2011-05-12 A (-4d) |  | 0% → 100% | 110d → none |  | resources SSH-Construction Manhours [14000 h]; Dump Truck [200 h]; Grader [200 h] → SSH-Construction Manhours [14602 h] |
| Z1.1030 | Install temporary access for Zone 1 | 2011-05-17 A | 2011-06-08 → 2013-01-09 (+581d) | 25d → 210d | 0% → 50% | 110d → -182.5d |  | resources SSH-Construction Manhours [14000 h] → SSH-Construction Manhours [3843 h] |
| 3 | **Zone 3** | 2011-07-06 → 2011-05-23 (-44d) | 2011-09-06 → 2012-12-10 (+461d) |  |  |  |  |  |
| 1 | **A3-1** | 2011-07-06 → 2011-05-23 (-44d) | 2011-08-15 → 2012-10-09 (+421d) |  |  |  |  |  |
| Z3.1010 | Site Clearing/Grubbing/Disposal | 2011-07-06 → 2011-05-23 A (-44d) | 2011-07-17 → 2011-09-04 A (+49d) |  | 0% → 100% | 61.25d → none |  | resources SSH-Construction Manhours [8000 h]; Grader [100 h]; Dump Truck [100 h] → SSH-Construction Manhours [11066 h] |
| Z3.1020 | Backfill/Compaction of soil upto desired level | 2011-07-18 A | 2011-08-15 → 2012-10-09 (+421d) | 31.25d → 150d | 0% → 96% | 61.25d → -97.5d | Z3.1010, 1.3.1.15.020 SS → Z3.1010 FF, 1.3.1.15.020 SS | resources SSH-Construction Manhours [25000 h]; Grader [250 h]; Dump Truck [250 h]; Compactor [250 h] → SSH-Construction Manhours [47149 h] |
| 2 | **A3-2** | 2011-07-09 → 2011-07-20 (+11d) | 2011-08-17 → 2012-02-20 (+187d) |  |  |  |  |  |
| Z3.2030 | Backfill/Compaction of soil upto desired level | 2011-07-20 A | 2011-08-17 → 2012-02-20 A (+187d) | 31.25d → 231d | 0% → 100% | 47.5d → none | Z3.2020 → Z3.1020 SS, Z3.2020 FF | resources SSH-Construction Manhours [25000 h]; Dump Truck [200 h]; Grader [200 h]; Compactor [250 h] → SSH-Construction Manhours [47149 h]; Grader [200 h] |
| Z3.2020 | Site Clearing/Grubbing/Disposal | 2011-07-09 → 2011-08-15 A (+37d) | 2011-07-19 → 2011-10-04 A (+77d) |  | 0% → 100% | 47.5d → none | 1.4.1.3.3.010 FS+31.25d → Z3.1020 SS | resources SSH-Construction Manhours [7000 h]; Dump Truck [100 h]; Grader [100 h] → SSH-Construction Manhours [10966 h] |
| 3 | **A3-3** | 2011-07-09 → 2011-07-26 (+17d) | 2011-08-23 → 2012-10-15 (+419d) |  |  |  |  |  |
| Z3.3020 | Backfill/Compaction of soil upto desired level | 2011-07-26 A | 2011-08-23 → 2012-10-15 (+419d) | 31.25d → 150d | 0% → 92% | 37.5d → -76.38d | Z3.3010 → Z3.1020 SS, Z3.3010 FF | resources SSH-Construction Manhours [25000 h]; Grader [250 h]; Dump Truck [250 h] → SSH-Construction Manhours [47149 h] |
| Z3.3010 | Site Clearing/Grubbing/Disposal | 2011-07-09 → 2011-09-13 A (+66d) | 2011-07-25 → 2011-10-20 A (+87d) |  | 0% → 100% | 37.5d → none | 1.4.1.3.3.010 FS+31.25d → Z3.2020 SS | resources SSH-Construction Manhours [10500 h]; Grader [150 h]; Dump Truck [150 h] → SSH-Construction Manhours [11313 h] |
| 4 | **A3-4** | 2011-08-07 → 2011-08-15 (+8d) | 2011-08-30 → 2012-12-10 (+468d) |  |  |  |  |  |
| Z3.4020 | Backfill/Compaction of soil upto desired level | 2011-08-15 A | 2011-08-30 → 2012-12-10 (+468d) | 17.5d → 150d | 0% → 52% | 45d → -22.49d | Z3.4010 → Z3.4010 FF | resources SSH-Construction Manhours [21000 h]; Excavator [140 h]; Dump Truck [140 h]; Compactor [140 h] → SSH-Construction Manhours [73288 h] |
| Z3.4010 | Site Clearing/Grubbing/Disposal | 2011-08-07 → 2011-09-30 A (+54d) | 2011-08-14 → 2011-11-14 A (+92d) |  | 0% → 100% | 37.5d → none |  | resources SSH-Construction Manhours [5600 h]; Grader [70 h]; Dump Truck [70 h] → SSH-Construction Manhours [10828 h] |
| 5 | **A3-5** | 2011-08-18 → 2011-08-25 (+7d) | 2011-09-06 → 2012-12-09 (+460d) |  |  |  |  |  |
| Z3.5020 | Backfill/Compaction of soil upto desired level | 2011-08-25 A | 2011-09-06 → 2012-12-09 (+460d) | 13.75d → 150d | 0% → 53% | 37.5d → -48.5d |  | resources SSH-Construction Manhours [7700 h]; Dump Truck [100 h]; Grader [100 h]; Compactor [110 h] → SSH-Construction Manhours [82182 h] |
| Z3.5010 | Site Clearing/Grubbing/Disposal | 2011-08-18 → 2011-10-20 A (+63d) | 2011-08-24 → 2011-11-15 A (+83d) |  | 0% → 100% | 37.5d → none | Z3.4010 FS+3.75d → Z3.4010 FS+3.75d, 1.4.1.2.2.040 | resources SSH-Construction Manhours [10500 h]; Grader [60 h]; Dump Truck [60 h] → SSH-Construction Manhours [11313 h] |
| 2 | **UTILITIES & SERVICES WORKS** | 2011-03-19 → 2011-01-28 (-50d) | 2012-12-17 → 2013-07-03 (+198d) |  |  |  |  |  |
| 1 | **PW / FW / CTMU(Cooling Tower Make Up) / Irrigation / Sea water Line** | 2011-08-21 → 2011-10-30 (+70d) | 2012-10-20 → 2013-06-17 (+240d) |  |  |  |  |  |
| 1 | **Zone 1** | none → 2012-06-28 | none → 2013-06-17 |  |  |  |  |  |
| 1 | **A1** | none → 2012-06-28 | none → 2013-06-17 |  |  |  |  |  |
| Z1.1040 | Excavation for water line & Valve boxes(2) | 2011-08-21 → 2012-06-28 A (+312d) | 2011-09-12 → 2013-05-11 (+607d) | 25d → 60d | 0% → 50% | 195d → -182.5d | Z1.1030 FS+37.5d, 1.4.1.2.1.020 SS → Z1.1030 FS+100d, 1.4.1.2.1.020 SS | resources SSH-Construction Manhours [14000 h]; Excavator [200 h]; Dump Truck [200 h] → SSH-Construction Manhours [1189 h]; Excavator [200 h]; Dump Truck [200 h] |
| Z1.1050 | Construction of vale boxes(2) | 2011-09-13 → 2012-07-17 A (+308d) | 2011-10-11 → 2013-05-29 (+596d) | 31.25d → 60d | 0% → 78% | 195d → -182.5d | Z1.1040 → Z1.1040 FF+20d | resources SSH-Construction Manhours [37500 h] → SSH-Construction Manhours [3184 h] |
| Z1.1060 | Install PW/FW/CTMU line +Irrigation line (375LM) | 2011-09-25 → 2012-08-05 A (+315d) | 2011-10-17 → 2013-06-17 (+609d) | 25d → 60d | 0% → 36% | 195d → -182.5d | Z1.1050 SS+12.5d → Z1.1050 FF+20d | resources SSH-Construction Manhours [60000 h] → SSH-Construction Manhours [5093 h] |
| 2 | **Zone 3** | 2011-07-14 → 2011-10-30 (+108d) | 2012-06-19 → 2013-03-30 (+284d) |  |  |  |  |  |
| 1 | **A3-1** | 2011-08-16 → 2012-03-14 (+211d) | 2012-06-06 → 2013-01-30 (+238d) |  |  |  |  |  |
| Z3.1070 | Construction of Valve boxes for water line (4) | 2012-01-18 → 2012-03-14 A (+56d) | 2012-02-06 → 2012-11-08 (+276d) | 21.25d → 90d | 0% → 85% | 37.5d → -3.06d | Z3.1060 → Z2.2270 | resources SSH-Construction Manhours [17000 h]; Excavator [170 h]; Dump Truck [170 h] → SSH-Construction Manhours [2257 h]; Excavator [170 h]; Dump Truck [170 h] |
| Z3.1230 | Construction of Valve boxes for water line (7) | 2011-09-29 → 2012-04-17 A (+201d) | 2011-10-27 → 2012-11-08 (+378d) | 31.25d → 90d | 0% → 85% | 106.25d → -34.81d | 1.4.1.2.2.040 → Z2.2230 SS, Z2.2270 | resources SSH-Construction Manhours [25000 h] → SSH-Construction Manhours [2122 h] |
| Z3.1240 | Installation of PW/FW/CTMU line-A(825) + Irrigation line | 2011-10-29 → 2012-04-29 A (+183d) | 2011-11-26 → 2012-11-01 (+341d) | 31.25d → 25d | 0% → 75% | 106.25d → -34.81d | Z3.1230 → Z3.1230 SS+12.5d | resources SSH-Construction Manhours [75000 h] → SSH-Construction Manhours [6366 h] |
| Z3.1250 | Installation of PW/FW/CTMU line-B(825) + Irrigation line | 2011-11-27 → 2012-05-17 A (+172d) | 2011-12-25 → 2012-11-20 (+331d) | 31.25d → 25d | 0% → 75% | 106.25d → -34.81d | Z3.1240 → Z3.1240 FF+20d | resources SSH-Construction Manhours [75000 h] → SSH-Construction Manhours [6366 h] |
| Z3.1260 | Installation of PW/FW/CTMU line-C(825) + Irrigation line | 2011-12-26 → 2012-06-05 A (+162d) | 2012-01-23 → 2012-12-09 (+321d) | 31.25d → 25d | 0% → 75% | 106.25d → -34.81d | Z3.1250 → Z3.1250 FF+20d | resources SSH-Construction Manhours [75000 h] → SSH-Construction Manhours [6366 h] |
| Z3.1080 | Installation of PW/FW/CTMU line-A(375LM) + irrigation line | 2012-02-07 → 2012-06-06 A (+120d) | 2012-02-29 → 2012-11-13 (+258d) |  | 0% → 80% | 37.5d → -3.06d | Z3.1070, 1.3.3.4.030, 1.3.3.18.030 → Z3.1070, 1.3.4.1.030, 1.3.4.11.030 | resources SSH-Construction Manhours [60000 h] → SSH-Construction Manhours [5093 h] |
| Z3.1270 | Installation of PW/FW/CTMU line-D(825) + Irrigation line | 2012-01-24 → 2012-06-24 A (+152d) | 2012-02-21 → 2012-12-27 (+310d) | 31.25d → 25d | 0% → 69% | 106.25d → -34.81d | Z3.1260 → Z3.1260 FF+20d | resources SSH-Construction Manhours [75000 h] → SSH-Construction Manhours [6366 h] |
| Z3.1090 | Installation of PW/FW/CTMU line-B(375LM) + irrigation line | 2012-03-01 → 2012-06-30 A (+121d) | 2012-03-24 → 2012-11-18 (+239d) |  | 0% → 76% | 37.5d → -3.06d |  | resources SSH-Construction Manhours [60000 h] → SSH-Construction Manhours [5093 h] |
| Z3.1280 | Instalaltion of seawater line (825LM) A | 2012-02-22 → 2012-07-12 A (+141d) | 2012-03-21 → 2013-01-15 (+300d) | 31.25d → 25d | 0% → 75% | 106.25d → -34.81d | Z3.1270 → Z3.1270 FF+20d | resources SSH-Construction Manhours [12500 h] → SSH-Construction Manhours [1062 h] |
| Z3.1290 | Instalaltion of seawater line (825LM) B | 2012-03-22 → 2012-08-05 A (+136d) | 2012-04-19 → 2013-01-15 (+271d) | 31.25d → 25d | 0% → 75% | 106.25d → -34.81d | Z3.1280 → Z3.1280 SS+25d | resources SSH-Construction Manhours [12500 h] → SSH-Construction Manhours [1062 h] |
| Z3.1300 | Instalaltion of seawater line (825LM) C | 2012-04-21 → 2012-08-28 A (+129d) | 2012-05-19 → 2013-01-15 (+241d) | 31.25d → 25d | 0% → 75% | 106.25d → -34.81d | Z3.1290 → Z3.1290 SS+25d | resources SSH-Construction Manhours [12500 h] → SSH-Construction Manhours [1062 h] |
| Z3.1310 | Instalaltion of seawater line (825LM) D | 2012-05-20 → 2012-09-11 A (+114d) | 2012-06-17 → 2013-01-15 (+212d) | 31.25d → 25d | 0% → 75% | 106.25d → -34.81d | Z3.1300 → Z3.1300 SS+15d, Z3.1090 | resources SSH-Construction Manhours [12500 h] → SSH-Construction Manhours [1062 h] |
| Z3.1340 | Install valves | 2012-05-06 → 2012-11-08 (+186d) | 2012-06-04 → 2012-12-06 (+185d) | 31.25d → 31d |  | 120.5d → 23.94d | Z3.1230 FS+37.5d, 1.3.3.5.030, 1.3.4.1.030 → Z3.1230, 1.3.4.2.030, 1.3.4.12.030 | resources SSH-Construction Manhours [25000 h] → SSH-Construction Manhours [2122 h] |
| Z3.1320 | Install fire hydrants | 2012-07-28 → 2012-12-18 (+143d) | 2012-09-18 → 2013-01-29 (+133d) | 56.25d → 45d |  | 63d → -34.81d | Z3.1310, Z3.1340, 1.3.3.6.030 → Z3.1310 FF+15d, 1.3.4.3.030, Z3.1090 | resources SSH-Construction Manhours [27000 h] → SSH-Construction Manhours [1479 h] |
| Z3.1330 | Install irrigation system & accs | 2012-09-12 → 2013-01-02 (+112d) | 2012-10-20 → 2013-01-30 (+102d) | 40d → 30d |  | 63d → -34.81d | Z3.1320 SS+50d → Z3.1320 FF+2d, 1.3.4.13.030, 1.3.4.14.030 | resources SSH-Construction Manhours [16000 h] → SSH-Construction Manhours [1357 h] |
| 2 | **A3-2** | 2011-07-14 → 2011-10-30 (+108d) | 2012-03-06 → 2013-03-30 (+389d) |  |  |  |  |  |
| Z3.2170 | Install PW/FW/CTMU line + Irrigation line A(1200LM) | 2011-10-30 A | 2011-11-27 → 2012-10-10 (+318d) |  | 0% → 77% | 47.5d → -96.69d | Z3.2160 → Z2.2270 SS | resources SSH-Construction Manhours [75000 h] → SSH-Construction Manhours [6366 h] |
| Z3.2180 | Install PW/FW/CTMU line + Irrigation line B(1200LM) | 2011-11-28 → 2012-02-20 A (+84d) | 2011-12-26 → 2012-10-11 (+290d) |  | 0% → 75% | 47.5d → -70.06d | Z3.2170 → Z3.2170 SS | resources SSH-Construction Manhours [75000 h] → SSH-Construction Manhours [6366 h] |
| Z3.2190 | Install PW/FW/CTMU line + Irrigation line C(1200LM) | 2011-12-27 → 2012-02-25 A (+60d) | 2012-01-24 → 2012-10-30 (+280d) |  | 0% → 75% | 80d → -70.06d | Z3.2180 → Z3.2180 FF+20d | resources SSH-Construction Manhours [75000 h] → SSH-Construction Manhours [6366 h] |
| Z3.2210 | Install Seawater line (1650LM) A | 2012-01-12 → 2012-03-06 A (+54d) | 2012-02-09 → 2012-10-20 (+254d) | 31.25d → 25d | 0% → 62% | 62.5d → -22.69d | Z3.2150 → Z3.2180 | resources SSH-Construction Manhours [25000 h] → SSH-Construction Manhours [2122 h] |
| Z3.2160 | Construction for valve boxes (11) | 2011-10-04 → 2012-03-11 A (+159d) | 2011-10-29 → 2012-11-13 (+381d) | 27.5d → 90d | 0% → 60% | 47.5d → -96.69d | Z3.2050 SS → Z3.2170 | resources SSH-Construction Manhours [15400 h]; Excavator [220 h]; Dump Truck [220 h] → SSH-Construction Manhours [3969 h]; Excavator [220 h]; Dump Truck [220 h] |
| Z3.2200 | Install PW/FW/CTMU line + Irrigation line D(1200LM) | 2012-01-25 → 2012-03-25 A (+60d) | 2012-02-22 → 2012-11-05 (+257d) |  | 0% → 78% | 80d → -8.5d |  | resources SSH-Construction Manhours [75000 h] → SSH-Construction Manhours [6366 h] |
| Z3.2220 | Install Seawater line (1650LM) B | 2012-02-11 → 2012-03-25 A (+43d) | 2012-03-10 → 2012-11-07 (+242d) | 31.25d → 25d | 0% → 63% | 62.5d → -22.69d | Z3.2210 → Z3.2210 FF+20d | resources SSH-Construction Manhours [25000 h] → SSH-Construction Manhours [2122 h] |
| Z3.2230 | Install Seawater line (1650LM) C | 2012-03-11 → 2012-04-23 A (+43d) | 2012-04-08 → 2012-11-26 (+232d) | 31.25d → 25d | 0% → 66% | 62.5d → -22.69d | Z3.2220, Z3.2200 → Z3.2220 FF+20d, Z3.2200 | resources SSH-Construction Manhours [12500 h] → SSH-Construction Manhours [1062 h] |
| Z3.2240 | Install Seawater line (1650LM) D | 2012-04-09 → 2012-05-12 A (+33d) | 2012-05-07 → 2012-12-15 (+222d) | 31.25d → 25d | 0% → 54% | 62.5d → -22.69d | Z3.2230 → Z3.2230 FF+20d | resources SSH-Construction Manhours [12500 h] → SSH-Construction Manhours [1062 h] |
| Z3.2250 | Install Seawater line (1650LM) E | 2012-05-08 → 2012-05-30 A (+22d) | 2012-06-05 → 2013-01-02 (+211d) | 31.25d → 25d | 0% → 47% | 62.5d → -22.69d | Z3.2240 → Z3.2240 FF+20d | resources SSH-Construction Manhours [12500 h] → SSH-Construction Manhours [1062 h] |
| Z3.2260 | Install seawater line (600LM)A | 2012-06-06 → 2012-06-23 A (+17d) | 2012-07-04 → 2013-01-09 (+189d) | 31.25d → 12.5d | 0% → 47% | 62.5d → -22.69d |  | resources SSH-Construction Manhours [12500 h] → SSH-Construction Manhours [1062 h] |
| Z3.2270 | Install seawater line (600LM)B | 2012-07-05 → 2012-07-04 A (-1d) | 2012-08-02 → 2013-01-12 (+163d) | 31.25d → 12.5d | 0% → 75% | 62.5d → -22.69d |  | resources SSH-Construction Manhours [12500 h] → SSH-Construction Manhours [1062 h] |
| Z3.2280 | Install seawater line (600LM)C | 2012-08-04 → 2012-07-16 A (-19d) | 2012-09-01 → 2013-01-15 (+136d) | 31.25d → 12.5d | 0% → 75% | 62.5d → -22.69d |  | resources SSH-Construction Manhours [12500 h] → SSH-Construction Manhours [1062 h] |
| Z3.2290 | Install fire hydrants | 2012-09-02 → 2012-11-27 (+86d) | 2012-10-20 → 2013-01-15 (+87d) |  |  | 62.5d → -22.69d | Z3.2280, Z3.2310, 1.3.3.6.030 → Z3.2280 FF, 1.3.4.3.030 | resources SSH-Construction Manhours [21000 h] → SSH-Construction Manhours [896 h] |
| Z3.2300 | Install irrigation system & accs | 2012-09-02 → 2012-12-09 (+98d) | 2012-10-20 → 2013-01-20 (+92d) | 52.5d → 45d |  | 62.5d → -22.69d | Z3.2290 SS → Z3.2290 FF+5d | resources SSH-Construction Manhours [21000 h] → SSH-Construction Manhours [896 h] |
| Z3.2310 | Install valves | 2012-03-18 → 2013-03-05 (+352d) | 2012-04-15 → 2013-03-30 (+349d) | 31.25d → 26d |  | 211.25d → -96.69d | Z3.2160 FS+150d → Z3.2160 FS+120d, 1.3.4.2.030 | resources SSH-Construction Manhours [25000 h] → SSH-Construction Manhours [1235 h] |
| 3 | **A3-3** | 2011-08-24 → 2012-03-10 (+199d) | 2012-06-19 → 2013-03-05 (+259d) |  |  |  |  |  |
| Z3.3250 | Installation of PW/FW/CTMU line + Irrigation line B | 2012-08-12 → 2012-03-10 A (-155d) | 2012-09-03 → 2012-10-20 (+47d) |  | 0% → 63% | 62.5d → 44.19d |  | resources SSH-Construction Manhours [30000 h] → SSH-Construction Manhours [2546 h] |
| Z3.3235 | Construction of valve boxes (12) A | 2012-06-20 → 2012-03-25 A (-87d) | 2012-07-18 → 2012-11-12 (+117d) | 31.25d → 90d | 0% → 85% | 62.5d → -70.06d | Z3.3230 → Z3.2190 | resources SSH-Construction Manhours [15000 h]; Excavator [250 h]; Dump Truck [250 h] → SSH-Construction Manhours [2752 h]; Excavator [250 h]; Dump Truck [250 h] |
| Z3.3260 | Installation of PW/FW/CTMU line + Irrigation line C | 2012-09-04 → 2012-04-02 A (-155d) | 2012-09-26 → 2012-10-25 (+29d) |  | 0% → 75% | 62.5d → 44.19d |  | resources SSH-Construction Manhours [30000 h] → SSH-Construction Manhours [2546 h] |
| Z3.3240 | Installation of PW/FW/CTMU line + Irrigation line A | 2012-07-19 A | 2012-08-11 → 2012-10-11 (+61d) |  | 0% → 75% | 62.5d → 1.88d | Z3.3235 → Z3.2180 FF | resources SSH-Construction Manhours [20000 h] → SSH-Construction Manhours [1698 h] |
| Z3.3270 | Install fire hydrants | 2012-09-27 → 2012-10-25 (+28d) | 2012-10-20 → 2012-11-18 (+29d) |  |  | 62.5d → 44.19d | Z3.3260, Z3.3280, 1.3.3.6.030 → Z3.3260, 1.3.4.3.030 | resources SSH-Construction Manhours [12000 h] → SSH-Construction Manhours [1019 h] |
| Z3.3236 | Construction of valve boxes (12) B | 2012-07-19 → 2012-11-12 (+116d) | 2012-08-16 → 2013-02-04 (+172d) | 31.25d → 90d |  | 75d → -70.06d |  | resources SSH-Construction Manhours [15000 h]; Excavator [250 h]; Dump Truck [250 h] → SSH-Construction Manhours [1273 h]; Excavator [250 h]; Dump Truck [250 h] |
| Z3.3280 | Install valves | 2012-08-18 → 2013-02-04 (+170d) | 2012-09-15 → 2013-03-05 (+171d) |  |  | 75d → -70.06d |  | resources SSH-Construction Manhours [25000 h] → SSH-Construction Manhours [643 h] |
| 4 | **A3-4** | none → 2012-03-10 | none → 2012-12-27 |  |  |  |  |  |
| Z3.4030 | Install seawater line (1050LM)A | 2012-01-03 → 2012-03-10 A (+67d) | 2012-01-31 → 2012-10-18 (+261d) |  | 0% → 75% | 97.5d → 1.88d | Z3.4020, Z3.3170 → Z3.3240 | resources SSH-Construction Manhours [25000 h] → SSH-Construction Manhours [2122 h] |

| ID | Task | Start | Finish | Duration | Complete | Total float | Predecessors | Other |
| --- | --- | --- | --- | --- | --- | --- | --- | --- |
| Z3.4040 | Install seawater line (1050LM)B | 2012-02-01 → 2012-04-02 A (+61d) | 2012-02-29 → 2012-11-11 (+256d) |  | 0% → 75% | 110d → 1.88d | Z3.4030 → Z3.4030 FF+25d | resources SSH-Construction Manhours [25000 h] → SSH-Construction Manhours [2122 h] |
| Z3.4050 | Install seawater line (1050LM)C | 2012-03-01 → 2012-04-25 A (+55d) | 2012-03-29 → 2012-12-04 (+250d) |  | 0% → 75% | 110d → 1.88d | Z3.4040 → Z3.4040 FF+25d | resources SSH-Construction Manhours [25000 h] → SSH-Construction Manhours [2122 h] |
| Z3.4060 | Install seawater line (1050LM)D | 2012-03-31 → 2012-05-19 A (+49d) | 2012-04-28 → 2012-12-27 (+243d) |  | 0% → 75% | 110d → 1.88d | Z3.4050 → Z3.4050 FF+25d | resources SSH-Construction Manhours [25000 h] → SSH-Construction Manhours [2122 h] |
| 5 | **A3-5** | 2012-02-01 → 2012-04-17 (+76d) | 2012-04-10 → 2012-11-14 (+218d) |  |  |  |  |  |
| Z3.5060 | Install seawater line (600LM)A | 2012-04-11 → 2012-04-17 A (+6d) | 2012-05-09 → 2012-11-03 (+178d) | 31.25d → 25d | 0% → 75% | 97.5d → 48.12d | Z3.5050 → Z3.4030 FS+10d | resources SSH-Construction Manhours [45000 h] → SSH-Construction Manhours [3820 h] |
| Z3.5070 | Install seawater line (600LM)B | 2012-05-10 A | 2012-06-07 → 2012-11-08 (+154d) | 31.25d → 25d | 0% → 75% | 97.5d → 48.12d | Z3.5060, Z3.4060 → Z3.5060 | resources SSH-Construction Manhours [45000 h] → SSH-Construction Manhours [3820 h] |
| Z3.5080 | Install seawater line (600LM)C | 2012-06-09 → 2012-06-03 A (-6d) | 2012-07-07 → 2012-11-14 (+130d) | 31.25d → 25d | 0% → 75% | 97.5d → 48.12d |  | resources SSH-Construction Manhours [45000 h] → SSH-Construction Manhours [3820 h] |
| 3 | **Zone 2** | 2011-07-24 → 2011-11-12 (+111d) | 2011-09-07 → 2013-04-06 (+577d) |  |  |  |  |  |
| 1 | **A2-1** | 2011-07-24 → 2011-12-24 (+153d) | 2011-08-21 → 2013-02-12 (+541d) |  |  |  |  |  |
| Z2.1080 | Install PW/FW/CTMU line+irrigation line (1200LM)A+Seawater | 2011-12-24 A | 2012-01-21 → 2012-10-11 (+264d) |  | 0% → 75% | 62.5d → -17.88d | Z2.1070 → Z2.1060 SS | resources SSH-Construction Manhours [75000 h] → SSH-Construction Manhours [6366 h] |
| Z2.1090 | Install PW/FW/CTMU line+irrigation line (1200LM)B+Seawater | 2012-01-22 A | 2012-02-19 → 2012-10-09 (+233d) |  | 0% → 82% | 62.5d → 0.88d | Z2.1080 → Z2.1100 SS | resources SSH-Construction Manhours [37500 h] → SSH-Construction Manhours [3184 h] |
| Z2.1100 | Install PW/FW/CTMU line+irrigation line (1200LM)C+Seawater | 2012-02-20 A | 2012-03-19 → 2012-10-27 (+222d) |  | 0% → 22% | 62.5d → -17.88d | Z2.1090, Z2.1120 → Z2.1080 SS | resources SSH-Construction Manhours [37500 h] → SSH-Construction Manhours [3184 h] |
| Z2.1060 | Excavation for valve boxes & water line trench | 2011-11-01 → 2012-10-04 (+338d) | 2011-11-23 → 2012-10-27 (+339d) |  |  | 62.5d → -48.5d | Z2.1050 → Z3.5020 SS | resources SSH-Construction Manhours [14000 h]; Excavator [200 h]; Dump Truck [200 h] → SSH-Construction Manhours [1189 h]; Excavator [200 h]; Dump Truck [200 h] |
| Z2.1110 | Install fire hydrants | 2012-07-28 → 2012-10-27 (+91d) | 2012-09-18 → 2012-12-22 (+95d) | 56.25d → 60d |  | 96.75d → -17.88d | Z2.1100, 1.3.3.6.030 → 1.3.4.3.030, Z2.1100, Z2.1090, Z2.1080, Z2.1100 FF | resources SSH-Construction Manhours [27000 h] → SSH-Construction Manhours [2292 h] |
| Z2.1070 | Construction of vale boxes for water line (5) | 2011-11-24 → 2012-10-28 (+339d) | 2011-12-22 → 2013-01-19 (+394d) | 31.25d → 90d |  | 62.5d → -48.5d |  | resources SSH-Construction Manhours [25000 h] → SSH-Construction Manhours [3009 h] |
| Z2.1120 | Install valves | 2011-12-24 → 2013-01-20 (+393d) | 2012-01-21 → 2013-02-12 (+388d) | 31.25d → 26d |  | 93.75d → -48.5d | Z2.1070 → Z2.1070, 1.3.4.2.030, Z2.1110 | resources SSH-Construction Manhours [25000 h] → SSH-Construction Manhours [1235 h] |
| 2 | **A2-2** | 2011-07-24 → 2011-11-12 (+111d) | 2011-09-07 → 2013-04-06 (+577d) |  |  |  |  |  |
| Z2.2250 | Install PW/FW/CTMU line +irrigation line (225LM)A | 2011-11-12 A | 2011-11-24 → 2012-10-07 (+318d) |  | 0% → 75% | 128.75d → -76.38d | Z2.2240 → Z3.3020 SS | resources SSH-Construction Manhours [36000 h] → SSH-Construction Manhours [3057 h] |
| Z2.2252 | Excavation for water line trench & valve boxesB | 2011-11-26 → 2012-02-29 A (+95d) | 2011-12-08 → 2012-10-25 (+322d) | 15d → 25d | 0% → 20% | 128.75d → -46.25d |  | resources SSH-Construction Manhours [8400 h]; Dump Truck [120 h]; Excavator [120 h] → SSH-Construction Manhours [713 h]; Dump Truck [120 h]; Excavator [120 h] |
| Z2.2262 | Excavation for water line trench & valve boxesC | 2012-01-29 → 2012-03-14 A (+45d) | 2012-02-14 → 2012-11-08 (+268d) |  | 0% → 23% | 128.75d → -80.38d | Z2.2260 → Z2.2270 | resources SSH-Construction Manhours [6000 h]; Excavator [150 h]; Dump Truck [150 h] → SSH-Construction Manhours [509 h]; Excavator [150 h]; Dump Truck [150 h] |
| Z2.2270 | Install PW/FW/CTMU line +irrigation line (825LM)C | 2012-03-15 A | 2012-04-12 → 2012-10-27 (+198d) |  | 0% → 23% | 128.75d → -96.69d | Z2.2264 → Z2.2250 FF | resources SSH-Construction Manhours [75000 h] → SSH-Construction Manhours [6366 h] |
| Z2.2264 | Construction of valve boxesC (2) | 2012-02-15 → 2012-04-01 A (+46d) | 2012-03-14 → 2012-11-22 (+253d) | 31.25d → 60d | 0% → 75% | 128.75d → -80.38d |  | resources SSH-Construction Manhours [25000 h] → SSH-Construction Manhours [2122 h] |
| Z2.2240 | Construction of valve boxesA (2) | 2011-10-13 → 2012-05-10 A (+210d) | 2011-11-10 → 2013-01-16 (+433d) | 31.25d → 90d | 0% → 3% | 128.75d → -104.8d |  | resources SSH-Construction Manhours [25000 h] → SSH-Construction Manhours [2122 h] |
| Z2.2300 | Installation of irrigation line to existing facilities(900LM)B | 2012-05-30 → 2012-07-12 A (+43d) | 2012-06-27 → 2013-02-05 (+223d) |  | 0% → 6% | 128.75d → -80.38d |  | resources SSH-Construction Manhours [15000 h] → SSH-Construction Manhours [1273 h] |
| Z2.2260 | Install PW/FW/CTMU line +irrigation line (450LM)B | 2012-01-08 → 2012-08-26 A (+231d) | 2012-01-28 → 2013-03-09 (+406d) | 22.5d → 30d | 0% → 44% | 128.75d → -104.8d | Z2.2254 → Z2.2254 FF+25d | resources SSH-Construction Manhours [54000 h] → SSH-Construction Manhours [4584 h] |
| Z2.2230 | Excavation for water line trench & valve boxesA | 2011-10-02 → 2012-10-04 (+368d) | 2011-10-12 → 2012-10-27 (+381d) | 12.5d → 25d |  | 128.75d → -104.8d | 1.4.1.3.2.010 FS+75d → 1.4.1.3.2.010 FS+18.75d, M2.07 | resources SSH-Construction Manhours [7000 h]; Excavator [100 h]; Dump Truck [100 h] → SSH-Construction Manhours [594 h]; Excavator [100 h]; Dump Truck [100 h] |
| Z2.2280 | Excavation for irrigation line to exisitng facilities | 2012-04-14 → 2012-11-22 (+222d) | 2012-04-30 → 2012-12-10 (+224d) |  |  | 128.75d → -80.38d | Z2.2270 → Z2.2264 | resources SSH-Construction Manhours [10500 h]; Excavator [150 h]; Dump Truck [150 h] → SSH-Construction Manhours [892 h]; Excavator [150 h]; Dump Truck [150 h] |
| Z2.2290 | Installation of irrigation line to existing facilities(900LM)A | 2012-05-01 → 2012-12-10 (+223d) | 2012-05-29 → 2013-01-08 (+224d) |  |  | 128.75d → -80.38d |  | resources SSH-Construction Manhours [15000 h] → SSH-Construction Manhours [1273 h] |
| Z2.2254 | Construction of valve boxesB (2) | 2011-12-10 → 2012-12-19 (+375d) | 2012-01-07 → 2013-02-13 (+403d) | 31.25d → 60d |  | 128.75d → -104.8d | Z2.2252 → Z2.2252, Z2.2240 FF+30d | resources SSH-Construction Manhours [25000 h] → SSH-Construction Manhours [2122 h] |
| Z2.2310 | Install fire hydrants | 2012-07-28 → 2013-01-21 (+177d) | 2012-09-18 → 2013-03-14 (+177d) |  |  | 96.75d → -80.38d | Z2.2300, Z2.2320, 1.3.3.6.030 → Z2.2300 FF+40d, 1.3.4.3.030 | resources SSH-Construction Manhours [27000 h] → SSH-Construction Manhours [2292 h] |
| Z2.2320 | Install valves | 2012-03-15 → 2013-03-09 (+359d) | 2012-04-12 → 2013-04-06 (+359d) | 31.25d → 30d |  | 210d → -104.8d | Z2.2264 → Z2.2264, 1.3.4.2.030, Z2.2260 | resources SSH-Construction Manhours [25000 h] → SSH-Construction Manhours [2122 h] |
| 4 | **Zone 4** | 2011-09-08 → 2012-05-15 (+250d) | 2011-11-05 → 2013-05-27 (+569d) |  |  |  |  |  |
| 1 | **A4** | 2011-11-06 → 2012-05-15 (+191d) | 2012-06-07 → 2013-05-27 (+354d) |  |  |  |  |  |
| Z4.1110 | Excavation for water lineA | 2012-06-09 → 2012-05-15 A (-25d) | 2012-06-19 → 2013-02-02 (+228d) | 12.5d → 25d |  | 62.5d → -160d | Z4.1100, Z4.1180 → Z4.1040 FF, M2.05 | resources SSH-Construction Manhours [5000 h]; Excavator [100 h]; Dump Truck [100 h] → SSH-Construction Manhours [424 h]; Excavator [100 h]; Dump Truck [100 h] |
| Z4.1120 | Construction of valve boxes (3) | 2012-06-20 → 2013-02-03 (+228d) | 2012-07-18 → 2013-03-30 (+255d) | 31.25d → 60d |  | 62.5d → -160d |  | resources SSH-Construction Manhours [12500 h] → SSH-Construction Manhours [2097 h] |
| Z4.1130 | Install PW/FW/CTMU line(180LM)A | 2012-07-19 → 2013-03-31 (+255d) | 2012-07-30 → 2013-04-10 (+254d) |  |  | 62.5d → -160d |  | resources SSH-Construction Manhours [7000 h] → SSH-Construction Manhours [594 h] |
| Z4.1170 | Install valves | 2012-07-19 → 2013-03-31 (+255d) | 2012-08-05 → 2013-04-16 (+254d) |  |  | 106.25d → -116.25d | Z4.1120 → Z4.1120, 1.3.4.2.030 | resources SSH-Construction Manhours [15000 h] → SSH-Construction Manhours [1265 h] |
| Z4.1140 | Excavation for water lineB | 2012-07-31 → 2013-04-11 (+254d) | 2012-08-16 → 2013-04-28 (+255d) |  |  | 62.5d → -160d |  | resources SSH-Construction Manhours [6000 h] → SSH-Construction Manhours [509 h] |
| Z4.1160 | Install fire hydrants | 2012-09-16 → 2013-04-23 (+219d) | 2012-10-20 → 2013-05-27 (+219d) |  |  | 62.5d → -160d | Z4.1150, Z4.1170, 1.3.3.6.030 → Z4.1150 FF, 1.3.4.3.030 | resources SSH-Construction Manhours [27000 h] → SSH-Construction Manhours [1257 h] |
| Z4.1150 | Install PW/FW/CTMU line(495LM)B | 2012-08-18 → 2013-04-29 (+254d) | 2012-09-15 → 2013-05-27 (+254d) |  |  | 62.5d → -160d |  | resources SSH-Construction Manhours [17500 h] → SSH-Construction Manhours [1486 h] |
| 2 | **Sewer Sanitary System** | 2011-07-14 → 2011-07-24 (+10d) | 2012-06-19 → 2013-06-05 (+351d) |  |  |  |  |  |
| 1 | **Zone 3** | 2011-09-29 → 2011-08-07 (-53d) | 2012-10-20 → 2012-12-24 (+65d) |  |  |  |  |  |
| 1 | **A3-1** | 2011-09-29 → 2011-08-16 (-44d) | 2012-10-20 → 2012-12-17 (+58d) |  |  |  |  |  |
| Z3.1180 | Excavation for sewer trench SMH02RA-SMH08RA+Dewatering | 2011-08-16 A | 2011-08-27 → 2011-08-28 A (+1d) |  | 0% → 100% | 70d → none | Z3.1020 → M2.04 FF | resources SSH-Construction Manhours [7000 h]; Excavator [100 h]; Dump Truck [100 h] → SSH-Construction Manhours [1407 h]; Excavator [100 h]; Dump Truck [100 h] |
| Z3.1030 | Excavation for gravity trench SMH19R3-SMH11R3+Dewatering | 2011-09-07 A | 2011-09-27 A |  | 0% → 100% | 37.5d → none | Z3.1020, M2.08 → M2.04 FF | resources SSH-Construction Manhours [5400 h]; Excavator [180 h]; Dump Truck [180 h] → SSH-Construction Manhours [1089 h]; Excavator [180 h]; Dump Truck [180 h] |
| Z3.1212 | Install sewer manholes (3) | 2011-10-24 → 2011-10-10 A (-14d) | 2011-11-21 → 2012-10-07 (+321d) |  | 0% → 90% | 70d → 25.75d | Z3.1211 → Z3.1211 SS | resources SSH-Construction Manhours [10500 h] → SSH-Construction Manhours [2111 h] |
| Z3.1211 | Excavation for sewer trench SMH06RA- SMH08RA | 2011-10-15 A | 2011-10-23 → 2011-10-24 A (+1d) |  | 0% → 100% | 70d → none | Z3.1210 → Z3.1180 SS | resources SSH-Construction Manhours [7000 h] → SSH-Construction Manhours [1407 h] |
| Z3.1050 | Installation of sewer pipe (750LM) | 2011-10-27 A | 2011-11-19 → 2012-10-06 (+322d) |  | 0% → 90% | 37.5d → 33.71d | Z3.1040, 1.3.3.10.030 → Z3.1030 SS, 1.3.4.6.030 SS | resources SSH-Construction Manhours [30000 h] → SSH-Construction Manhours [6040 h] |
| Z3.1214 | Excavation for sewer trench SMH01RP- SMH07RP | 2011-12-04 → 2011-11-04 A (-30d) | 2011-12-20 A |  | 0% → 100% | 70d → none | Z3.1213 → Z3.1213 SS | resources SSH-Construction Manhours [9000 h] → SSH-Construction Manhours [1811 h] |
| Z3.1040 | Installation of Sewer Manholes SMH19R3-SMH11R3(9) | 2011-09-28 → 2011-11-10 A (+43d) | 2011-10-26 → 2012-10-07 (+347d) |  | 0% → 90% | 37.5d → 33.71d | Z3.1030, 1.3.3.9.030 → Z3.1050 SS | resources SSH-Construction Manhours [37500 h] → SSH-Construction Manhours [7551 h] |
| Z3.1215 | Install sewer manholes (7) | 2011-12-21 → 2011-11-10 A (-41d) | 2012-01-18 → 2012-10-07 (+263d) |  | 0% → 90% | 70d → 25.75d | Z3.1214 → Z3.1214 SS | resources SSH-Construction Manhours [22000 h] → SSH-Construction Manhours [4430 h] |
| Z3.1213 | Install sewer pipe line (210LM) | 2011-11-22 A | 2011-12-03 → 2012-10-04 (+306d) |  | 0% → 90% | 70d → 25.75d | Z3.1212 → Z3.1212 SS | resources SSH-Construction Manhours [5000 h] → SSH-Construction Manhours [1004 h] |
| Z3.1216 | Install sewer pipeline (575LM) | 2012-01-19 A | 2012-02-15 → 2012-10-04 (+232d) |  | 0% → 97% | 70d → 28.75d | Z3.1215 → Z3.1215 SS | resources SSH-Construction Manhours [12000 h] → SSH-Construction Manhours [2417 h] |
| Z3.1190 | Installation of Sewer Manholes 01 - 07 (7) | 2011-08-28 → 2012-01-21 A (+146d) | 2011-09-25 → 2012-10-07 (+378d) |  | 0% → 90% | 70d → 40.06d | Z3.1180 → Z3.1180 SS | resources SSH-Construction Manhours [25000 h] → SSH-Construction Manhours [5030 h] |
| Z3.1210 | Installation of sewer pipe (560LM) | 2011-09-26 → 2012-02-26 A (+153d) | 2011-10-13 → 2012-10-08 (+361d) |  | 0% → 75% | 70d → 38.19d | Z3.1190 → Z3.1211 SS | resources SSH-Construction Manhours [16000 h] → SSH-Construction Manhours [3219 h] |
| Z3.1051 | Install sewer manhoels SMH11R2-SMH08R4 (03) | 2011-11-20 → 2012-03-03 A (+104d) | 2011-12-18 → 2012-10-13 (+300d) | 31.25d → 60d | 0% → 90% | 37.5d → 33.71d | Z3.1050 → Z3.1040 | resources SSH-Construction Manhours [12500 h] → SSH-Construction Manhours [2515 h] |
| Z3.1052 | Install sewer pipe (325LM) | 2011-12-19 → 2012-04-28 A (+131d) | 2012-01-10 → 2012-10-17 (+281d) |  | 0% → 80% | 37.5d → 33.71d |  | resources SSH-Construction Manhours [13000 h] → SSH-Construction Manhours [2619 h] |
| Z3.1100 | Excavation for sewer trench SMH11R3-LS10+Dewatering | 2012-03-25 → 2012-04-28 A (+34d) | 2012-03-29 → 2012-05-02 A (+34d) |  | 0% → 100% | 37.5d → none | Z3.1090 → Z3.1040, Z3.1051 | resources SSH-Construction Manhours [3500 h]; Excavator [50 h]; Dump Truck [50 h] → SSH-Construction Manhours [704 h]; Excavator [50 h]; Dump Truck [50 h] |
| Z3.1110 | Installation of Sewer Manholes SMH11R3-LS10 (5) | 2012-03-31 → 2012-05-03 A (+33d) | 2012-04-22 → 2012-10-15 (+176d) |  | 0% → 90% | 37.5d → 35.88d |  | resources SSH-Construction Manhours [30000 h] → SSH-Construction Manhours [6040 h] |
| Z3.1060 | Partial Backfilling | 2012-01-11 → 2012-05-21 A (+131d) | 2012-01-17 → 2012-10-21 (+278d) |  | 0% → 42% | 37.5d → 33.71d |  | resources SSH-Construction Manhours [4200 h]; Dump Truck [60 h] → SSH-Construction Manhours [844 h]; Dump Truck [60 h] |
| Z3.1120 | Installation of Sewer Pipe (225LM) | 2012-04-23 → 2012-05-27 A (+34d) | 2012-05-06 → 2012-10-16 (+163d) |  | 0% → 90% | 37.5d → 35.88d |  | resources SSH-Construction Manhours [18000 h] → SSH-Construction Manhours [3623 h] |
| Z3.1130 | Installation of Sewer Manholes SMHRL1-SMH07RP (4) | 2012-05-07 → 2012-06-10 A (+34d) | 2012-05-26 → 2012-12-15 (+203d) | 21.25d → 60d | 0% → 90% | 37.5d → -22.49d | Z3.1120 → Z3.1120, M2.08 | resources SSH-Construction Manhours [25500 h] → SSH-Construction Manhours [5134 h] |
| Z3.1140 | Installation of Sewer Pipe SMHRL1-SMH07RP (290LM) | 2012-05-27 → 2012-08-05 A (+70d) | 2012-06-06 → 2012-12-17 (+194d) |  | 0% → 80% | 37.5d → -22.49d |  | resources SSH-Construction Manhours [10000 h] → SSH-Construction Manhours [2013 h] |
| Z3.1220 | Partial Backfilling | 2012-02-16 → 2012-08-16 A (+182d) | 2012-02-22 → 2012-09-08 A (+199d) | 7.5d → 25d | 0% → 100% | 70d → none | Z3.1210, Z3.1216 → Z3.1216 SS | resources SSH-Construction Manhours [4200 h]; Dump Truck [60 h] → SSH-Construction Manhours [844 h]; Dump Truck [60 h] |
| 2 | **A3-2** | 2011-10-04 → 2011-08-07 (-58d) | 2012-10-20 → 2012-12-19 (+60d) |  |  |  |  |  |
| Z3.2080 | Installation of sewer pipe SMH01R2-SMH28RA (300LM) | 2011-08-07 A | 2011-08-31 → 2012-10-08 (+404d) |  | 0% → 85% | 62.5d → 57d | Z3.2075 → Z3.1215 SS | resources SSH-Construction Manhours [39600 h] → SSH-Construction Manhours [7973 h] |
| Z3.2110 | Excavation for sanitary trench SMH01R3-LS11 | 2011-10-01 A | 2011-10-17 A |  | 0% → 100% | 62.5d → none | Z3.2090 → Z3.2080 SS | resources SSH-Construction Manhours [10500 h]; Excavator [150 h]; Dump Truck [150 h] → SSH-Construction Manhours [2111 h]; Excavator [150 h]; Dump Truck [150 h] |
| Z3.2120 | Installation of sewer pipe SMH01R3-LS11(327LM) | 2011-10-18 A | 2011-11-15 → 2012-10-06 (+326d) |  | 0% → 92% | 62.5d → 57.66d | Z3.2110 → Z3.2110 SS | resources SSH-Construction Manhours [37500 h] → SSH-Construction Manhours [7551 h] |
| Z3.2051 | Excavation for sanitary trench SMH05R3-SMH01R | 2011-11-02 A | 2011-11-15 A |  | 0% → 100% | 136.25d → none | Z3.2050 → Z3.1215 SS | resources SSH-Construction Manhours [8000 h] → SSH-Construction Manhours [1609 h] |
| Z3.2140 | Installation of Manholes SMHRL16 -LS11 (7) | 2011-11-28 → 2011-11-10 A (-18d) | 2011-12-21 → 2012-10-06 (+290d) |  | 0% → 95% | 62.5d → 58.31d | Z3.2130 → Z3.2130 SS | resources SSH-Construction Manhours [21000 h] → SSH-Construction Manhours [4228 h] |

| ID | Task | Start | Finish | Duration | Complete | Total float | Predecessors | Other |
| --- | --- | --- | --- | --- | --- | --- | --- | --- |
| Z3.2130 | Excavation of sanitary trench SMHRL16 -LS11 | 2011-11-16 A | 2011-11-27 A |  | 0% → 100% | 62.5d → none | Z3.2120 → Z3.1215 SS | resources SSH-Construction Manhours [7000 h]; Excavator [100 h]; Dump Truck [100 h] → SSH-Construction Manhours [1407 h]; Excavator [100 h]; Dump Truck [100 h] |
| Z3.2060 | Installation of sewer pipe SMH05R3 -SMH01R3 (360LM) | 2011-12-10 A | 2012-01-03 → 2012-10-06 (+277d) |  | 0% → 95% | 136.25d → 25.75d | Z3.2055 → Z3.2051 SS | resources SSH-Construction Manhours [33000 h] → SSH-Construction Manhours [6646 h] |
| Z3.2150 | Installation of sewer pipe SMHRL16 -LS11 (730LM) | 2011-12-22 A | 2012-01-11 → 2012-10-06 (+269d) |  | 0% → 92% | 62.5d → 58.31d | Z3.2140 → Z3.2140 SS | resources SSH-Construction Manhours [27000 h] → SSH-Construction Manhours [5434 h] |
| Z3.2075 | Installation of Manholes SMH01R2-SMH28RA(5) | 2011-07-14 → 2012-01-28 A (+198d) | 2011-08-06 → 2012-10-07 (+428d) | 25d → 60d | 0% → 95% | 62.5d → 25.75d | 1.4.1.3.3.010 FS+37.5d → Z3.2060 SS | resources SSH-Construction Manhours [14000 h] → SSH-Construction Manhours [2821 h] |
| Z3.2090 | Installation of Manholes SMHRL16 -SMH28RA (7) | 2011-09-01 → 2012-01-29 A (+150d) | 2011-09-29 → 2012-10-07 (+374d) | 31.25d → 60d | 0% → 95% | 62.5d → 57d | Z3.2080 → Z3.2080 SS | resources SSH-Construction Manhours [25000 h] → SSH-Construction Manhours [5030 h] |
| Z3.2065 | Installation of Manholes SMH01R3 -SMH28RA (5) | 2012-01-04 → 2012-01-30 A (+26d) | 2012-01-26 → 2012-10-07 (+255d) | 25d → 60d | 0% → 95% | 136.25d → 57.94d | Z3.2060 → Z3.2060 SS | resources SSH-Construction Manhours [20000 h] → SSH-Construction Manhours [4027 h] |
| Z3.2066 | Excavation of sewer trench SMH01R3-SMH28RA | 2012-01-28 → 2012-02-01 A (+4d) | 2012-02-09 → 2012-02-14 A (+5d) |  | 0% → 100% | 136.25d → none | Z3.2065 → Z3.2065 SS | resources SSH-Construction Manhours [10000 h] → SSH-Construction Manhours [2013 h] |
| Z3.2070 | Installation of sewer pipe SMH01R3 -SMH28RA (380LM) | 2012-02-11 → 2012-02-18 A (+7d) | 2012-03-06 → 2012-10-06 (+214d) |  | 0% → 92% | 136.25d → 57.94d |  | resources SSH-Construction Manhours [33000 h] → SSH-Construction Manhours [6646 h] |
| Z3.2040 | Excavation for sanitary trench SMH06R3 -SMH05R4 | 2011-08-18 → 2012-05-16 A (+272d) | 2011-09-10 → 2012-06-07 A (+271d) |  | 0% → 100% | 47.5d → none | Z3.2030, 1.2.6.200 → Z3.2030, 1.2.6.200, Z3.1190, Z3.1210 | resources SSH-Construction Manhours [14000 h]; Excavator [200 h]; Dump Truck [200 h] → SSH-Construction Manhours [2821 h]; Excavator [200 h]; Dump Truck [200 h] |
| Z3.2045 | Installation of Manholes SMH06R3 -SMH05R4 (5) | 2011-09-11 → 2012-06-09 A (+272d) | 2011-10-03 → 2012-10-17 (+380d) | 25d → 60d | 0% → 85% | 47.5d → 38.19d |  | resources SSH-Construction Manhours [20000 h] → SSH-Construction Manhours [4027 h] |
| Z3.2050 | Installation of sewer pipe SMH06R3 -SMH05R4 (400LM) | 2011-10-04 → 2012-08-04 A (+305d) | 2011-11-01 → 2012-10-22 (+356d) |  | 0% → 83% | 47.5d → 38.19d |  | resources SSH-Construction Manhours [37500 h] → SSH-Construction Manhours [7551 h] |
| Z3.2055 | Installation of Manholes SMH05R3 -SMH01R3 (5) | 2011-11-16 → 2012-09-02 A (+291d) | 2011-12-08 → 2012-12-19 (+377d) | 25d → 50d | 0% → 95% | 136.25d → -22.49d | Z3.2050, Z3.2051 → Z3.2050, Z3.1140 | resources SSH-Construction Manhours [20000 h] → SSH-Construction Manhours [4027 h] |
| 3 | **A3-3** | 2012-06-20 → 2011-09-01 (-293d) | 2012-10-20 → 2012-10-21 (+1d) |  |  |  |  |  |
| Z3.3110 | Excavation for sewer line SMH13RA-SMH09RA | 2011-08-24 → 2011-09-01 A (+8d) | 2011-09-10 → 2011-12-12 A (+93d) |  | 0% → 100% | 62.5d → none | Z3.3020 → Z3.3020 SS | resources SSH-Construction Manhours [10500 h]; Excavator [150 h]; Dump Truck [150 h] → SSH-Construction Manhours [2120 h]; Excavator [150 h]; Dump Truck [150 h] |
| Z3.3120 | Instalaltion of sewer Manholes SMH13RA-SMH09RA (5) | 2011-09-11 → 2011-09-03 A (-8d) | 2011-10-09 → 2012-10-08 (+365d) |  | 0% → 88% | 62.5d → 11.09d | Z3.3110 → M2.04 FF | resources SSH-Construction Manhours [25000 h] → SSH-Construction Manhours [5030 h] |
| Z3.3130 | Instalaltion of sewer line SMH13RA-SMH09RA (285LM) | 2011-10-10 → 2011-09-13 A (-27d) | 2011-10-26 → 2012-10-06 (+346d) |  | 0% → 90% | 62.5d → 54.22d | Z3.3120 → 1.3.4.5.030 SS, Z3.3110 FF | resources SSH-Construction Manhours [22500 h] → SSH-Construction Manhours [4528 h] |
| Z3.3140 | Excavation for sewer line SMH09RA-SMH11R2 | 2011-10-27 A | 2011-11-07 A |  | 0% → 100% | 62.5d → none | Z3.3130 → M2.04 FF, Z3.3120 FF | resources SSH-Construction Manhours [7000 h]; Excavator [100 h]; Dump Truck [100 h] → SSH-Construction Manhours [1407 h]; Excavator [100 h]; Dump Truck [100 h] |
| Z3.3170 | Excavation for sewer line SMH13RA - SMH01R2 | 2011-12-11 A | 2012-01-02 A |  | 0% → 100% | 62.5d → none | Z3.3160 → Z3.3140 SS | resources SSH-Construction Manhours [14000 h]; Excavator [200 h]; Dump Truck [200 h] → SSH-Construction Manhours [2821 h]; Excavator [200 h]; Dump Truck [200 h] |
| Z3.3180 | Installaiton of manholes SMH13RA - SMH01R2 (7) | 2012-01-03 → 2011-12-17 A (-17d) | 2012-01-31 → 2012-10-11 (+254d) |  | 0% → 88% | 62.5d → 52.19d | Z3.3170 → Z3.3170 SS | resources SSH-Construction Manhours [37500 h] → SSH-Construction Manhours [7551 h] |
| Z3.3190 | Installation of sewer line SMH13RA - SMH01R2 (598LM) | 2012-02-01 A | 2012-02-29 → 2012-10-11 (+225d) |  | 0% → 88% | 62.5d → 52.19d | Z3.3180 → Z3.3180 SS | resources SSH-Construction Manhours [50000 h] → SSH-Construction Manhours [10066 h] |
| Z3.3210 | Installation of sewer manholes SM10R2 - SM02R2 (9) | 2012-03-25 → 2012-02-20 A (-34d) | 2012-04-22 → 2012-10-11 (+172d) |  | 0% → 88% | 62.5d → 52.19d | Z3.3200 → Z3.3200, Z3.3130 | resources SSH-Construction Manhours [17500 h] → SSH-Construction Manhours [3525 h] |
| Z3.3150 | Installation of sewer manhole SMH09RA-SMH11R2 (3) | 2011-11-08 → 2012-02-25 A (+109d) | 2011-11-24 → 2012-10-15 (+326d) | 18.75d → 60d | 0% → 88% | 62.5d → 11.09d |  | resources SSH-Construction Manhours [15000 h] → SSH-Construction Manhours [3017 h] |
| Z3.3200 | Excavation for sewer line SM10R2 - SM02R2 | 2012-03-01 A | 2012-03-24 A |  | 0% → 100% | 62.5d → none | Z3.3190, Z3.1220 → Z3.3190 SS | resources SSH-Construction Manhours [14000 h]; Excavator [200 h]; Dump Truck [200 h] → SSH-Construction Manhours [2821 h]; Excavator [200 h]; Dump Truck [200 h] |
| Z3.3220 | Installation of sewer line SM10R2 - SM02R2 (780)A | 2012-04-23 → 2012-03-20 A (-34d) | 2012-05-21 → 2012-04-18 A (-33d) |  | 0% → 100% | 62.5d → none | Z3.3210 → Z3.3210, Z3.2070 | resources SSH-Construction Manhours [17500 h] → SSH-Construction Manhours [3525 h] |
| Z3.3230 | Installation of sewer line SM10R2 - SM02R2 (780)B | 2012-05-22 → 2012-04-18 A (-34d) | 2012-06-19 → 2012-05-17 A (-33d) |  | 0% → 100% | 62.5d → none | Z3.3220 → Z3.3220, Z3.2090, Z3.2120, Z3.2150 | resources SSH-Construction Manhours [17500 h] → SSH-Construction Manhours [3525 h] |
| Z3.3160 | Installaiton of sewer line SMH09RA-SMH11R2 (270LM) | 2011-11-26 → 2012-04-21 A (+147d) | 2011-12-10 → 2012-10-21 (+316d) | 16.25d → 25d | 0% → 75% | 62.5d → 11.09d |  | resources SSH-Construction Manhours [19500 h] → SSH-Construction Manhours [3922 h] |
| 5 | **A3-5** | 2012-04-11 → 2012-05-31 (+50d) | 2012-07-07 → 2012-12-24 (+170d) |  |  |  |  |  |
| Z3.5030 | Excvation for sewer line SMH10R3-SMH01R4 | 2012-02-01 → 2012-05-31 A (+120d) | 2012-02-18 → 2012-06-18 A (+121d) |  | 0% → 100% | 97.5d → none |  | resources SSH-Construction Manhours [6000 h]; Excavator [150 h]; Dump Truck [150 h] → SSH-Construction Manhours [1206 h]; Excavator [150 h]; Dump Truck [150 h] |
| Z3.5040 | Installation of sewer manholes SMH10R3-SMH01R4(5) | 2012-02-19 → 2012-06-18 A (+120d) | 2012-03-12 → 2012-12-17 (+280d) | 25d → 60d | 0% → 85% | 97.5d → -27.01d |  | resources SSH-Construction Manhours [20000 h] → SSH-Construction Manhours [4027 h] |
| Z3.5050 | Installation of sewer line SMH10R3-SMH01R4 (350LM) | 2012-03-13 → 2012-08-13 A (+153d) | 2012-04-10 → 2012-12-24 (+258d) |  | 0% → 75% | 97.5d → -27.01d | Z3.5040 → Z3.5040, Z3.1060 | resources SSH-Construction Manhours [37500 h] → SSH-Construction Manhours [7554 h] |
| 2 | **Zone 2** |  | 2012-04-22 → 2013-01-05 (+258d) |  |  |  |  |  |
| 1 | **A2-1** |  | 2011-10-31 → 2012-10-13 (+348d) |  |  |  |  |  |
| Z2.1030 | Excavation for sewer line SMH01RC-SMH04R7 | 2011-08-22 A | 2011-09-07 → 2012-10-06 (+395d) |  | 0% → 90% | 62.5d → -182.11d | Backfill/Compaction of soil upto desired level → M2.04 FF | resources SSH-Construction Manhours [10500 h]; Excavator [150 h]; Dump Truck [150 h] → SSH-Construction Manhours [2111 h]; Excavator [150 h]; Dump Truck [150 h] |
| Z2.1050 | Install sewer line SMH01RC-SMH04R7 (350LM) | 2011-10-03 A | 2011-10-31 → 2012-10-13 (+348d) |  | 0% → 69% | 62.5d → -190d | Z2.1040 → Z2.1030 FF | resources SSH-Construction Manhours [37500 h] → SSH-Construction Manhours [7551 h] |
| Z2.1040 | Install sewer manholes SMH01RC-SMH04R7 (5) | 2011-09-08 → 2012-02-26 A (+171d) | 2011-10-02 → 2012-10-13 (+377d) | 26.25d → 60d | 0% → 88% | 62.5d → 44.02d |  | resources SSH-Construction Manhours [21000 h] → SSH-Construction Manhours [4228 h] |
| 2 | **A2-2** |  | 2012-04-22 → 2013-01-05 (+258d) |  |  |  |  |  |
| Z2.2120 | Excavation for sewer trench SMH01R7-SMH04R7 | 2011-07-24 A | 2011-08-09 A |  | 0% → 100% | 86.25d → none | 1.4.1.3.2.010 → Z2.2060 SS | resources SSH-Construction Manhours [10500 h]; Dump Truck [150 h]; Excavator [150 h] → SSH-Construction Manhours [2111 h]; Dump Truck [150 h]; Excavator [150 h] |
| Z2.2140 | Install sewer line SMH01R7-SMH04R7 (330LM) | 2011-09-03 A | 2011-09-19 → 2012-10-08 (+385d) |  | 0% → 78% | 86.25d → -39.31d | Z2.2130 → Z2.2120 SS | resources SSH-Construction Manhours [22500 h] → SSH-Construction Manhours [4528 h] |
| Z2.2030 | Excavation for sewer trench SMH05R7 - SMH18RC | 2011-09-08 A | 2011-09-25 → 2012-10-04 (+375d) |  | 0% → 98% | 117.5d → -190d | Backfill/Compaction of soil upto desired level → Z2.1050 SS | resources SSH-Construction Manhours [10500 h]; Excavator [150 h]; Dump Truck [150 h] → SSH-Construction Manhours [2111 h]; Excavator [150 h]; Dump Truck [150 h] |
| Z2.2150 | Excavation for sewer trench SMH04R7-SMH12RC | 2011-09-20 A | 2011-10-12 → 2012-10-06 (+360d) |  | 0% → 90% | 86.25d → -39.31d | Z2.2140 → Z2.2140 SS | resources SSH-Construction Manhours [14000 h]; Dump Truck [200 h]; Excavator [200 h] → SSH-Construction Manhours [2811 h]; Dump Truck [200 h]; Excavator [200 h] |
| Z2.2050 | Install sewer line SMH05R7 - SMH18RC (406LM) | 2011-10-25 A | 2011-11-16 → 2012-10-08 (+327d) |  | 0% → 83% | 117.5d → -39.31d | Z2.2040 → Z2.2030 SS | resources SSH-Construction Manhours [30000 h] → SSH-Construction Manhours [6040 h] |
| Z2.2170 | Installation of sewer line SMH04R7-SMH12RC (652LM)A | 2011-11-12 A | 2011-11-28 → 2012-10-07 (+314d) |  | 0% → 80% | 86.25d → 25d | Z2.2160 → Z2.2180 SS | resources SSH-Construction Manhours [22500 h] → SSH-Construction Manhours [4528 h] |
| Z2.2060 | Excavation for sewer line SMH13R7-SMH17RC | 2011-11-17 A | 2011-12-04 A |  | 0% → 100% | 117.5d → none | Z2.2050, M2.09 → Z2.2050 SS | resources SSH-Construction Manhours [10500 h]; Dump Truck [150 h]; Excavator [150 h] → SSH-Construction Manhours [2111 h]; Dump Truck [150 h]; Excavator [150 h] |
| Z2.2180 | Installation of sewer line SMH04R7-SMH12RC (652LM)B | 2011-11-29 A | 2011-12-15 → 2012-10-13 (+303d) |  | 0% → 49% | 86.25d → -39.31d | Z2.2170 → Z2.2150 SS | resources SSH-Construction Manhours [22500 h] → SSH-Construction Manhours [4528 h] |
| Z2.2130 | Install sewer manholes SMH01R7-SMH04R7 (5) | 2011-08-10 → 2012-02-18 A (+192d) | 2011-09-01 → 2012-10-10 (+405d) | 25d → 50d | 0% → 85% | 86.25d → 21.25d | Z2.2120 → Z2.2120, Z2.2140 SS | resources SSH-Construction Manhours [20000 h] → SSH-Construction Manhours [4027 h] |
| Z2.2040 | Install sewer manholes SMH05R7 - SMH18RC (6) | 2011-09-26 → 2012-02-27 A (+154d) | 2011-10-24 → 2012-10-11 (+353d) | 31.25d → 60d | 0% → 88% | 117.5d → 45.43d |  | resources SSH-Construction Manhours [25000 h] → SSH-Construction Manhours [5030 h] |
| Z2.2070 | Install sewer line manhole SMH13R7-SMH17RC (5) | 2011-12-05 → 2012-02-29 A (+86d) | 2011-12-27 → 2012-10-23 (+301d) | 25d → 40d | 0% → 47% | 117.5d → 8d |  | resources SSH-Construction Manhours [20000 h] → SSH-Construction Manhours [4027 h] |
| Z2.2190 | Excavation for sewer line SMH02AR7-interface point-A | 2011-12-17 → 2012-03-01 A (+75d) | 2012-01-02 → 2012-11-08 (+311d) | 18.75d → 50d | 0% → 42% | 86.25d → -39.31d |  | resources SSH-Construction Manhours [10500 h]; Dump Truck [150 h]; Excavator [150 h] → SSH-Construction Manhours [2111 h]; Dump Truck [150 h]; Excavator [150 h] |
| Z2.2160 | Installation of manhoels SMH04R7-SMH12RC (11) | 2011-10-13 → 2012-03-06 A (+145d) | 2011-11-10 → 2012-10-13 (+338d) | 31.25d → 50d | 0% → 85% | 86.25d → 18.75d |  | resources SSH-Construction Manhours [25000 h] → SSH-Construction Manhours [5030 h] |
| Z2.2080 | Install sewer line SMH13R7-SMH17RC (294LM) | 2011-12-28 → 2012-04-07 A (+101d) | 2012-01-14 → 2012-11-11 (+302d) | 18.75d → 40d | 0% → 52% | 117.5d → 8d |  | resources SSH-Construction Manhours [22500 h] → SSH-Construction Manhours [4528 h] |
| Z2.2200 | Instal F.sewer line SMH02AR7-interface point (29040LM)A | 2012-01-03 → 2012-04-17 A (+105d) | 2012-01-25 → 2012-06-03 A (+130d) | 25d → 50d | 0% → 100% | 86.25d → none |  | resources SSH-Construction Manhours [30000 h] → SSH-Construction Manhours [6040 h] |
| Z2.2202 | Excavation for sewer line SMH02AR7-interface point-B | 2012-01-26 → 2012-05-05 A (+100d) | 2012-02-12 → 2012-11-21 (+283d) |  | 0% → 31% | 86.25d → -39.31d | Z2.2200 → Z2.2200 SS+18.75d | resources SSH-Construction Manhours [6000 h]; Dump Truck [150 h]; Excavator [150 h] → SSH-Construction Manhours [1206 h]; Dump Truck [150 h]; Excavator [150 h] |
| Z2.2090 | Excavation for sewer line SMH17RC-SMH12RC | 2012-01-15 → 2012-05-14 A (+120d) | 2012-01-31 → 2012-06-20 A (+141d) | 18.75d → 40d | 0% → 100% | 117.5d → none |  | resources SSH-Construction Manhours [10500 h]; Dump Truck [150 h]; Excavator [150 h] → SSH-Construction Manhours [2111 h]; Dump Truck [150 h]; Excavator [150 h] |
| Z2.2210 | Instal F.sewer line SMH02AR7-interface point (2940LM)B | 2012-02-13 → 2012-05-16 A (+93d) | 2012-03-06 → 2012-12-23 (+292d) | 25d → 50d | 0% → 6% | 86.25d → -39.31d | Z2.2202 → Z2.2202 SS+12.5d | resources SSH-Construction Manhours [14000 h] → SSH-Construction Manhours [2821 h] |
| Z2.2212 | Excavation for sewer line SMH02AR7-interface point-C | 2012-03-07 → 2012-06-03 A (+88d) | 2012-03-24 → 2012-11-19 (+240d) |  | 0% → 43% | 86.25d → -39.31d | Z2.2210 → Z2.2210 SS+18.75d | resources SSH-Construction Manhours [6000 h]; Dump Truck [150 h]; Excavator [150 h] → SSH-Construction Manhours [1206 h]; Dump Truck [150 h]; Excavator [150 h] |
| Z2.2220 | Instal F.sewer line SMH02AR7-interface point (2940LM)C | 2012-03-25 → 2012-06-14 A (+81d) | 2012-04-16 → 2012-12-06 (+234d) | 25d → 50d | 0% → 41% | 86.25d → -39.31d | Z2.2212 → Z2.2212 SS+12.5d | resources SSH-Construction Manhours [30000 h] → SSH-Construction Manhours [6040 h] |
| Z2.2100 | Install sewer manholes SMH17RC-SMH12RC (7) | 2012-02-01 → 2012-06-20 A (+140d) | 2012-02-29 → 2012-11-15 (+260d) | 31.25d → 40d | 0% → 87% | 117.5d → 8d |  | resources SSH-Construction Manhours [17500 h] → SSH-Construction Manhours [3525 h] |
| Z2.2110 | Install sewer line SMH17RC-SMH12RC (410LM) | 2012-03-01 → 2012-07-28 A (+149d) | 2012-03-24 → 2012-11-21 (+242d) | 25d → 40d | 0% → 84% | 117.5d → 8d | Z2.2100 → Z2.2100, Z2.1040, Z2.2040 | resources SSH-Construction Manhours [30000 h] → SSH-Construction Manhours [6040 h] |
| Z2.2340 | Backfilling | 2012-03-25 → 2012-12-06 (+256d) | 2012-04-22 → 2013-01-05 (+258d) |  |  | 86.25d → -39.31d | Z2.2220 SS → Z2.2220, Z2.2110 FF, Z2.2130, Z2.2160, Z2.2170, Z3.1220, Z3.2075, Z3.3160 | resources SSH-Construction Manhours [17500 h] → SSH-Construction Manhours [3525 h] |
| 3 | **Zone 4** | 2011-11-06 → 2012-04-17 (+163d) | 2012-06-07 → 2013-02-04 (+242d) |  |  |  |  |  |
| 1 | **A4** | 2012-06-09 → 2012-04-17 (-53d) | 2012-10-20 → 2013-02-04 (+107d) |  |  |  |  |  |
| Z4.1030 | Excavation for sewer line SMH18R2-SMH29R3+Dewatering | 2011-11-06 → 2012-04-17 A (+163d) | 2011-11-28 → 2012-10-20 (+327d) | 25d → 35d | 0% → 50% | 62.5d → -71.5d | Supp/backfill/compact gen soil upto des level zone4 → Z2.2230 SS | resources SSH-Construction Manhours [14000 h]; Excavator [200 h]; Dump Truck [200 h] → SSH-Construction Manhours [2821 h]; Excavator [200 h]; Dump Truck [200 h] |
| Z4.1040 | Install sewer manholes SMH18R2-SMH29R3 (7) | 2011-11-29 → 2012-05-06 A (+159d) | 2011-12-27 → 2012-11-07 (+316d) | 31.25d → 35d | 0% → 45% | 62.5d → -71.5d | Z4.1030 → Z4.1030 FF+20d | resources SSH-Construction Manhours [25000 h] → SSH-Construction Manhours [5030 h] |
| Z4.1050 | Install sewer line SMH18R2-SMH29R3 (405LM) | 2011-12-28 → 2012-05-24 A (+148d) | 2012-01-19 → 2012-11-26 (+312d) | 25d → 35d | 0% → 55% | 62.5d → -71.5d | Z4.1040 → Z4.1040 FF+20d | resources SSH-Construction Manhours [30000 h] → SSH-Construction Manhours [6040 h] |
| Z4.1060 | Excavation for sewer line SMH20R3-SMH29R3 | 2012-01-21 → 2012-06-26 A (+157d) | 2012-02-18 → 2012-07-14 A (+147d) | 31.25d → 20d | 0% → 100% | 62.5d → none |  | resources SSH-Construction Manhours [10000 h] → SSH-Construction Manhours [2013 h] |
| Z4.1070 | Install sewer manholes SMH20R3-SMH29R3 (7) | 2012-02-19 → 2012-07-10 A (+142d) | 2012-03-18 → 2012-11-26 (+253d) | 31.25d → 35d | 0% → 60% | 62.5d → -71.5d | Z4.1060, Z1.1060 → Z4.1060 FF+30d | resources SSH-Construction Manhours [20000 h] → SSH-Construction Manhours [4027 h] |
| Z4.1080 | Install sewr line SMH20R3-SMH29R3 (630LM) | 2012-03-19 → 2012-08-02 A (+136d) | 2012-04-16 → 2012-12-19 (+247d) | 31.25d → 35d | 0% → 77% | 62.5d → -71.5d | Z4.1070 → Z4.1070 FF+25d | resources SSH-Construction Manhours [37500 h] → SSH-Construction Manhours [7551 h] |
| Z4.1090 | Excvation for sewer line SMH20R3- SD CHAMBER | 2012-04-17 → 2012-09-09 A (+145d) | 2012-05-09 → 2013-01-12 (+248d) | 25d → 20d | 0% → 83% | 62.5d → -71.5d | Z4.1080 → Z4.1080 FF+25d | resources SSH-Construction Manhours [10000 h]; Excavator [200 h]; Dump Truck [200 h] → SSH-Construction Manhours [2013 h]; Excavator [200 h]; Dump Truck [200 h] |
| Z4.1100 | Install sewer line SMH20R3- SD CHAMBER | 2012-05-10 → 2012-09-13 A (+126d) | 2012-06-07 → 2013-01-30 (+237d) | 31.25d → 35d | 0% → 33% | 62.5d → -71.5d | Z4.1090 → Z4.1090 FF+20d | resources SSH-Construction Manhours [17500 h] → SSH-Construction Manhours [3525 h] |
| Z4.1180 | Backfilling | 2012-05-10 → 2013-01-02 (+237d) | 2012-06-07 → 2013-02-04 (+242d) | 31.25d → 35d |  | 62.5d → -71.5d | Z4.1100 SS → Z4.1100 FF+4d, Z2.2340 FF | resources SSH-Construction Manhours [12500 h] → SSH-Construction Manhours [2515 h] |

| ID | Task | Start | Finish | Duration | Complete | Total float | Predecessors | Other |
| --- | --- | --- | --- | --- | --- | --- | --- | --- |
| 4 | **Lift Station Buildings** | 2011-08-08 → 2011-09-13 (+36d) | 2012-10-20 → 2013-06-05 (+228d) |  |  |  |  |  |
| 1 | **LS 9 Building - Zone 4** | 2011-09-11 → 2012-03-22 (+193d) | 2012-10-02 → 2013-04-15 (+195d) |  |  |  |  |  |
| 1.4.2.3.5.010 | Excavation leveling & compaction for LS9 | 2011-09-11 → 2012-03-22 A (+193d) | 2011-10-03 → 2012-10-21 (+384d) |  | 0% → 25% | 56d → -147.5d | 1.4.2.3.8.010 SS → 1.4.2.3.6.030 SS+6d | resources SSH-Construction Manhours [7000 h]; Excavator [100 h]; Dump Truck [100 h] → SSH-Construction Manhours [703.06 h]; Excavator [100 h]; Dump Truck [100 h] |
| 1.4.2.3.5.025 | Install Base slab for LS9 | 2011-11-02 → 2012-10-21 (+354d) | 2011-11-30 → 2012-11-18 (+354d) |  |  | 56d → -147.5d | 1.4.2.3.5.020 → 1.4.2.3.5.020 FF+10d | resources SSH-Construction Manhours [9000 h] → SSH-Construction Manhours [1115.97 h] |
| 1.4.2.3.5.020 | Install lean concrete & water proofing works LS9 | 2011-10-04 → 2012-10-23 (+385d) | 2011-11-01 → 2012-11-08 (+373d) | 31.25d → 18.75d |  | 56d → -147.5d | 1.4.2.3.5.010 → 1.4.2.3.5.010 FF+20d | resources SSH-Construction Manhours [9000 h] → SSH-Construction Manhours [862.09 h] |
| 1.4.2.3.5.030 | Construction for retaining walls LS9 | 2011-12-01 → 2012-11-19 (+354d) | 2011-12-24 → 2012-12-05 (+347d) | 25d → 18.75d |  | 56d → -147.5d |  | resources SSH-Construction Manhours [9969.72 h] → SSH-Construction Manhours [1673.96 h] |
| 1.4.2.3.5.040 | Constrcution for sump pit LS9 | 2011-12-25 → 2012-11-22 (+333d) | 2012-01-16 → 2012-12-15 (+334d) |  |  | 56d → -147.5d | 1.4.2.3.5.030 → 1.4.2.3.5.030 SS+3.75d | resources SSH-Construction Manhours [30000 h] → SSH-Construction Manhours [3905.91 h] |
| 1.4.2.3.5.050 | Construction for top slab LS9 | 2012-01-17 → 2012-12-16 (+334d) | 2012-02-14 → 2013-01-13 (+334d) |  |  | 56d → -147.5d |  | resources SSH-Construction Manhours [30000 h] → SSH-Construction Manhours [3905.91 h] |
| 1.4.2.3.5.060 | Construction of wall with water proofing LS9 | 2012-02-09 → 2013-01-08 (+334d) | 2012-03-14 → 2013-01-24 (+316d) | 37.5d → 18.75d |  | 56d → -147.5d | 1.4.2.3.5.050 SS+25d, 1.3.1.18.020 → 1.4.2.3.5.050 SS+25d | resources SSH-Construction Manhours [36000 h] → SSH-Construction Manhours [3905.91 h] |
| 1.4.2.3.5.070 | Backfilling & Compaction LS9 | 2012-03-13 → 2013-01-12 (+305d) | 2012-04-04 → 2013-02-03 (+305d) |  |  | 56d → -147.5d | 1.4.2.3.5.060 SS+35d → 1.4.2.3.5.060 FF+10d | resources SSH-Construction Manhours [12000 h] → SSH-Construction Manhours [1149.45 h] |
| 1.4.2.3.5.080 | Plastering & Painting work LS9 -Door installation | 2012-04-05 → 2013-02-04 (+305d) | 2012-05-03 → 2013-03-04 (+305d) |  |  | 56d → -147.5d |  | resources SSH-Construction Manhours [10000 h]; Dump Truck [160 h] → SSH-Construction Manhours [958.06 h]; Dump Truck [160 h] |
| 1.4.2.3.5.130 | Install precast concrete fence & gate LS9 | 2012-04-23 → 2013-02-10 (+293d) | 2012-05-21 → 2013-03-09 (+292d) |  |  | 56d → -147.5d | 1.4.2.3.5.080 SS+19d → 1.4.2.3.5.080 FF+5d | resources SSH-Construction Manhours [9585.81 h] → SSH-Construction Manhours [919.01 h] |
| 1.4.2.3.5.140 | Install asphalt pavement LS9 | 2012-05-02 → 2013-02-19 (+293d) | 2012-05-30 → 2013-03-18 (+292d) |  |  | 56d → -147.5d |  | resources SSH-Construction Manhours [12000 h] → SSH-Construction Manhours [3386.98 h] |
| 1.4.2.3.5.150 | Install piping System & odour control system | 2012-05-30 → 2013-02-19 (+265d) | 2012-06-27 → 2013-03-18 (+264d) |  |  | 56d → -147.5d | 1.4.2.3.5.140, 1.3.3.16.030, 1.3.3.17.030 → 1.4.2.3.5.140 FF, 1.3.4.9.030, 1.3.4.10.030 | resources SSH-Construction Manhours [12000 h]; Welding Machine [240 h] → SSH-Construction Manhours [1149.45 h]; Welding Machine [240 h] |
| 1.4.2.3.5.155 | Install electrical/instr work / fire alarm system in LS9 | 2012-06-27 → 2013-02-19 (+237d) | 2012-07-25 → 2013-03-18 (+236d) |  |  | 78.5d → -147.5d | 1.4.2.3.5.150 → 1.4.2.3.5.150 FF | resources SSH-Construction Manhours [12000 h] → SSH-Construction Manhours [1149.45 h] |
| 1.4.2.3.5.160 | Testing & Commissioning of LS 9 | 2012-08-21 → 2013-03-19 (+210d) | 2012-10-02 → 2013-04-15 (+195d) | 45d → 30d |  | 49d → -147.5d | Testing & commissioning of generator LS9, 1.4.2.3.5.155, Z3.5080, 1.4.3.1.1.570, 1.4.3.1.2.570, M2.10 → 1.4.2.3.5.155, 1.4.3.1.1.570, 1.4.3.1.2.570, M2.10, 1.4.2.7.4.126, 1.4.2.3.5.152 | resources SSH-Construction Manhours [36000 h] → SSH-Construction Manhours [658.43 h] |
| 2 | **LS 10 - Building - Zone 3** | 2011-08-08 → 2011-09-13 (+36d) | 2012-10-13 → 2013-02-25 (+135d) |  |  |  |  |  |
| 1.4.2.3.6.010 | Excavation leveling & compaction for LS10 | 2011-08-08 → 2011-09-13 A (+36d) | 2011-08-30 → 2011-12-19 A (+111d) |  | 0% → 100% | 30d → none | 1.2.6.200 → 1.2.6.200, Z2.2030 SS | resources SSH-Construction Manhours [8000 h]; Excavator [100 h]; Dump Truck [100 h] → SSH-Construction Manhours [766.12 h]; Excavator [100 h]; Dump Truck [100 h] |
| 1.4.2.3.6.020 | Install lean concrete & water proofing works LS10 | 2011-08-31 → 2011-12-10 A (+101d) | 2011-09-28 → 2011-12-28 A (+91d) |  | 0% → 100% | 57.5d → none |  | resources SSH-Construction Manhours [9000 h] → SSH-Construction Manhours [862.09 h] |
| 1.4.2.3.6.025 | Install base slab for LS10 | 2011-09-29 → 2012-02-18 A (+142d) | 2011-10-27 → 2012-03-17 A (+142d) |  | 0% → 100% | 57.5d → none |  | resources SSH-Construction Manhours [9000 h] → SSH-Construction Manhours [1115.97 h] |
| 1.4.2.3.6.030 | Construction for retaining walls LS10 | 2011-10-29 → 2012-03-18 A (+141d) | 2011-11-20 → 2012-10-04 (+319d) |  | 0% → 95% | 57.5d → -147.5d | 1.4.2.3.6.010 SS+12.5d, 1.3.1.1.030 SS, 1.3.1.5.030, 1.4.2.3.6.025 → 1.4.2.3.6.020, 1.4.2.3.6.025 | resources SSH-Construction Manhours [9969.72 h] → SSH-Construction Manhours [1673.96 h] |
| 1.4.2.3.6.040 | Constrcution for sump pit LS10 | 2011-11-19 → 2012-03-27 A (+129d) | 2011-12-11 → 2012-04-18 A (+129d) |  | 0% → 100% | 57.5d → none | 1.4.2.3.6.030 SS+22.5d, 1.3.1.14.020 SS → 1.3.1.14.020 SS, 1.4.2.3.6.025, 1.4.2.3.6.030 FF+10d | resources SSH-Construction Manhours [50000 h] → SSH-Construction Manhours [3905.91 h] |
| 1.4.2.3.6.050 | Construction for top slab LS10 | 2011-12-12 → 2012-04-19 A (+129d) | 2012-01-09 → 2012-11-08 (+304d) |  | 0% → 14% | 57.5d → -95d |  | resources SSH-Construction Manhours [62500 h] → SSH-Construction Manhours [3905.91 h] |
| 1.4.2.3.6.060 | Construction of wall with water proofing LS10 | 2012-01-10 → 2012-05-19 A (+130d) | 2012-02-13 → 2012-11-14 (+275d) |  | 0% → 83% | 57.5d → -95d |  | resources SSH-Construction Manhours [75000 h] → SSH-Construction Manhours [3905.91 h] |
| 1.4.2.3.6.070 | Backfilling & Compaction LS10 | 2012-02-12 → 2012-11-08 (+270d) | 2012-03-05 → 2012-11-20 (+260d) | 25d → 12.5d |  | 57.5d → -95d | 1.4.2.3.6.060 SS+35d → 1.4.2.3.6.060 FF+6.25d | resources SSH-Construction Manhours [8000 h] → SSH-Construction Manhours [766.12 h] |
| 1.4.2.3.6.080 | Plastering & Painting work LS10 -Door installation | 2012-03-06 → 2012-11-20 (+259d) | 2012-04-03 → 2012-12-19 (+260d) |  |  | 57.5d → -95d |  | resources SSH-Construction Manhours [17500 h] → SSH-Construction Manhours [1676.75 h] |
| 1.4.2.3.6.130 | Install precast concrete fence & gate LS10 | 2012-03-25 → 2012-12-01 (+251d) | 2012-04-21 → 2012-12-29 (+252d) |  |  | 57.5d → -95d | 1.4.2.3.6.080 SS+20d → 1.4.2.3.6.080 FF+10d | resources SSH-Construction Manhours [16800 h] → SSH-Construction Manhours [1609.24 h] |
| 1.4.2.3.6.150 | Install piping system & odour control sytem | 2012-06-07 → 2012-12-27 (+203d) | 2012-07-05 → 2013-01-26 (+205d) |  |  | 37.5d → -95d | 1.4.2.3.6.140, 1.3.3.15.030, Z3.2070, Z3.2150, Z3.1140, Z2.2110, Z2.2220, Z2.2340 → 1.4.2.3.6.140 FF, 1.3.4.8.030 | resources SSH-Construction Manhours [12500 h]; Welding Machine [250 h] → SSH-Construction Manhours [1197.44 h]; Welding Machine [250 h] |
| 1.4.2.3.6.155 | Install electrical/instr work/fire detection system LS10 | 2012-07-07 → 2012-12-27 (+173d) | 2012-08-04 → 2013-01-26 (+175d) |  |  | 67.5d → -95d | 1.4.2.3.6.150 → 1.4.2.3.6.150 FF | resources SSH-Construction Manhours [12500 h] → SSH-Construction Manhours [948.58 h] |
| 1.4.2.3.6.140 | Install asphalt pavement LS10 | 2012-04-22 → 2012-12-29 (+251d) | 2012-05-19 → 2013-01-26 (+252d) |  |  | 57.5d → -95d |  | resources SSH-Construction Manhours [7200 h] → SSH-Construction Manhours [689.67 h] |
| 1.4.2.3.6.160 | Testing & Commissioning of LS 10 | 2012-09-02 → 2013-02-09 (+160d) | 2012-10-13 → 2013-02-25 (+135d) | 45d → 18d |  | 37.5d → -95d | Testing & commissioning of generator LS10, 1.4.2.3.6.155, 1.4.3.1.1.570, 1.4.3.1.2.570, M2.10 → 1.4.2.3.6.155, 1.4.3.1.1.570, 1.4.3.1.2.570, M2.10, 1.4.2.7.4.120, 1.4.2.3.6.152 | resources SSH-Construction Manhours [18000 h] → SSH-Construction Manhours [578.07 h] |
| 3 | **LS 11 - Building - Zone 3** | 2011-08-31 → 2011-11-15 (+76d) | 2012-10-20 → 2013-04-28 (+190d) |  |  |  |  |  |
| 1.4.2.3.7.010 | Excavation leveling & compaction for LS11 | 2011-08-31 → 2011-11-15 A (+76d) | 2011-09-22 → 2012-01-25 A (+125d) |  | 0% → 100% | 30d → none | 1.4.2.3.6.010 → 1.4.2.3.6.010 SS | resources SSH-Construction Manhours [8000 h]; Excavator [100 h]; Dump Truck [100 h] → SSH-Construction Manhours [766.12 h]; Excavator [100 h]; Dump Truck [100 h] |
| 1.4.2.3.7.020 | Install lean concrete & water proofing works LS11 | 2011-09-24 → 2012-02-18 A (+147d) | 2011-10-22 → 2012-03-17 A (+147d) |  | 0% → 100% | 30d → none |  | resources SSH-Construction Manhours [9000 h] → SSH-Construction Manhours [862.09 h] |
| 1.4.2.3.7.025 | Install base slab for LS11 | 2011-10-23 → 2012-03-18 A (+147d) | 2011-11-20 → 2012-10-04 (+319d) | 31.25d → 12.5d | 0% → 90% | 30d → -161d |  | resources SSH-Construction Manhours [9000 h] → SSH-Construction Manhours [1115.97 h] |
| 1.4.2.3.7.040 | Constrcution for sump pit LS11 | 2011-12-08 → 2012-04-08 A (+122d) | 2011-12-31 → 2012-11-06 (+311d) |  | 0% → 20% | 30d → -161d | 1.4.2.3.7.030 SS+18.75d → 1.4.2.3.7.030 FF+10d | resources SSH-Construction Manhours [50000 h] → SSH-Construction Manhours [3905.91 h] |
| 1.4.2.3.7.030 | Construction for retaining walls LS11 | 2011-11-21 → 2012-10-06 (+320d) | 2011-12-13 → 2012-10-28 (+320d) |  |  | 30d → -161d |  | resources SSH-Construction Manhours [9969.72 h] → SSH-Construction Manhours [1673.96 h] |
| 1.4.2.3.7.050 | Construction for top slab LS11 | 2012-01-01 → 2012-11-07 (+311d) | 2012-01-29 → 2012-12-05 (+311d) |  |  | 30d → -161d |  | resources SSH-Construction Manhours [37500 h] → SSH-Construction Manhours [3905.91 h] |
| 1.4.2.3.7.060 | Construction of wall with water proofing LS11 | 2012-02-02 → 2012-12-10 (+312d) | 2012-03-07 → 2013-01-13 (+312d) |  |  | 30d → -161d |  | resources SSH-Construction Manhours [45000 h] → SSH-Construction Manhours [3905.91 h] |
| 1.4.2.3.7.070 | Backfilling & Compaction LS11 | 2012-03-06 → 2013-01-08 (+308d) | 2012-03-28 → 2013-01-19 (+297d) | 25d → 12.5d |  | 30d → -161d | 1.4.2.3.7.060 SS+35d → 1.4.2.3.7.060 FF+6.25d | resources SSH-Construction Manhours [14000 h] → SSH-Construction Manhours [1340.84 h] |
| 1.4.2.3.7.080 | Plastering & Painting work LS11 -Door installation | 2012-03-29 → 2013-01-20 (+297d) | 2012-04-16 → 2013-02-06 (+296d) |  |  | 30d → -161d |  | resources SSH-Construction Manhours [8000 h]; Dump Truck [160 h] → SSH-Construction Manhours [766.12 h]; Dump Truck [160 h] |
| 1.4.2.3.7.130 | Install precast concrete fence & gate LS11 | 2012-04-17 → 2013-01-20 (+278d) | 2012-05-14 → 2013-02-16 (+278d) |  |  | 30d → -161d | 1.4.2.3.7.080 → 1.4.2.3.7.080 FF+10d | resources SSH-Construction Manhours [12000 h] → SSH-Construction Manhours [1149.45 h] |
| 1.4.2.3.7.140 | Install asphalt pavement LS11 | 2012-05-15 → 2013-02-17 (+278d) | 2012-06-06 → 2013-03-11 (+278d) |  |  | 30d → -161d |  | resources SSH-Construction Manhours [10000 h] → SSH-Construction Manhours [958.06 h] |
| 1.4.2.3.7.150 | Install piping System & odour control system | 2012-06-07 → 2013-02-25 (+263d) | 2012-07-05 → 2013-03-25 (+263d) |  |  | 30d → -161d | 1.4.2.3.7.140 → 1.4.2.3.7.140 FF+15d | resources SSH-Construction Manhours [12500 h]; Welding Machine [250 h] → SSH-Construction Manhours [1197.44 h]; Welding Machine [250 h] |
| 1.4.2.3.7.155 | Install electrical/instr work / fire alarm system LS11 | 2012-07-07 → 2013-02-25 (+233d) | 2012-08-04 → 2013-03-25 (+233d) |  |  | 68.75d → -161d | 1.4.2.3.7.150 → 1.4.2.3.7.150 FF | resources SSH-Construction Manhours [12500 h] → SSH-Construction Manhours [974.25 h] |
| 1.4.2.3.7.160 | Testing & Commissioning of LS 11 | 2012-09-10 → 2013-04-13 (+215d) | 2012-10-20 → 2013-04-28 (+190d) | 43.75d → 17d |  | 30d → -161d | Testing & commissioning of generator LS11, 1.4.2.3.7.155, 1.4.3.1.1.570, 1.4.3.1.2.570, M2.10 → 1.4.2.3.7.155, 1.4.3.1.1.570, 1.4.3.1.2.570, M2.10, 1.4.2.7.4.122, 1.4.2.3.7.152 | resources SSH-Construction Manhours [25000 h] → SSH-Construction Manhours [720.92 h] |
| 4 | **LS 12 - Building - Zone 2** | 2011-09-11 → 2011-11-28 (+78d) | 2012-10-18 → 2013-06-05 (+230d) |  |  |  |  |  |
| 1.4.2.3.8.010 | Excavation leveling & compaction for LS12 | 2011-09-11 → 2011-11-28 A (+78d) | 2011-10-03 → 2012-01-25 A (+114d) |  | 0% → 100% | 31.25d → none | 1.4.2.3.7.010 SS+11.25d → 1.4.2.3.7.010 SS | resources SSH-Construction Manhours [8000 h]; Excavator [100 h]; Dump Truck [100 h] → SSH-Construction Manhours [766.12 h]; Excavator [100 h]; Dump Truck [100 h] |
| 1.4.2.3.8.020 | Install lean concrete & water proofing works LS12 | 2011-10-04 → 2012-10-04 (+366d) | 2011-11-01 → 2012-10-15 (+349d) | 31.25d → 12.5d |  | 31.25d → -202.5d | 1.4.2.3.8.010 → 1.4.2.3.8.010 FF | resources SSH-Construction Manhours [9000 h] → SSH-Construction Manhours [862.09 h] |
| 1.4.2.3.8.025 | Install base slab for LS12 | 2011-11-02 → 2012-10-16 (+349d) | 2011-11-30 → 2012-11-01 (+337d) | 31.25d → 18.75d |  | 31.25d → -202.5d |  | resources SSH-Construction Manhours [9000 h] → SSH-Construction Manhours [1115.97 h] |
| 1.4.2.3.8.030 | Construction for retaining walls LS12 | 2011-12-01 → 2012-11-03 (+338d) | 2011-12-24 → 2012-11-25 (+337d) |  |  | 31.25d → -202.5d |  | resources SSH-Construction Manhours [9969.72 h] → SSH-Construction Manhours [1673.96 h] |
| 1.4.2.3.8.040 | Constrcution for sump pit LS12 | 2011-12-22 → 2012-11-12 (+326d) | 2012-01-14 → 2012-12-04 (+325d) |  |  | 31.25d → -202.5d | 1.4.2.3.8.030 SS+22.5d → 1.4.2.3.8.030 FF+10d | resources SSH-Construction Manhours [50000 h] → SSH-Construction Manhours [3905.91 h] |
| 1.4.2.3.8.050 | Construction for top slab LS12 | 2012-01-15 → 2012-12-05 (+325d) | 2012-02-12 → 2013-01-02 (+325d) |  |  | 31.25d → -202.5d |  | resources SSH-Construction Manhours [50000 h] → SSH-Construction Manhours [3905.91 h] |
| 1.4.2.3.8.060 | Construction of wall with water proofing LS12 | 2012-02-13 → 2013-01-03 (+325d) | 2012-03-12 → 2013-01-31 (+325d) |  |  | 31.25d → -202.5d |  | resources SSH-Construction Manhours [37500 h] → SSH-Construction Manhours [3905.91 h] |
| 1.4.2.3.8.070 | Backfilling & Compaction LS12 | 2012-03-13 → 2013-01-27 (+320d) | 2012-04-04 → 2013-02-06 (+308d) | 25d → 12.5d |  | 31.25d → -202.5d | 1.4.2.3.8.060 → 1.4.2.3.8.060 FF+6.25d | resources SSH-Construction Manhours [8000 h] → SSH-Construction Manhours [766.12 h] |
| 1.4.2.3.8.080 | Plastering & Painting work LS11 -Door installation | 2012-04-05 → 2013-02-07 (+308d) | 2012-04-23 → 2013-02-25 (+308d) |  |  | 31.25d → -202.5d |  | resources SSH-Construction Manhours [8000 h]; Dump Truck [160 h] → SSH-Construction Manhours [766.12 h]; Dump Truck [160 h] |
| 1.4.2.3.8.130 | Install precast concrete fence & gate LS12 | 2012-04-24 → 2013-02-07 (+289d) | 2012-05-21 → 2013-03-06 (+289d) |  |  | 31.25d → -202.5d | 1.4.2.3.8.080 → 1.4.2.3.8.080 FF+10d | resources SSH-Construction Manhours [12000 h] → SSH-Construction Manhours [1149.45 h] |
| 1.4.2.3.8.150 | Install piping System & odour control system | 2012-06-19 → 2013-02-28 (+254d) | 2012-07-29 → 2013-04-09 (+254d) |  |  | 31.25d → -202.5d | 1.4.2.3.8.140 → 1.4.2.3.8.140 FF+6.25d | resources SSH-Construction Manhours [12500 h]; Welding Machine [350 h] → SSH-Construction Manhours [1197.44 h]; Welding Machine [350 h] |
| 1.4.2.3.8.140 | Install asphalt pavement LS12 | 2012-05-22 → 2013-03-07 (+289d) | 2012-06-18 → 2013-04-03 (+289d) |  |  | 31.25d → -202.5d |  | resources SSH-Construction Manhours [9600 h] → SSH-Construction Manhours [919.56 h] |
| 1.4.2.3.8.155 | Install electrical/instr work / fire alarm system LS12 | 2012-07-30 → 2013-03-18 (+231d) | 2012-08-27 → 2013-04-15 (+231d) |  |  | 31.25d → -202.5d | 1.4.2.3.8.150 → 1.4.2.3.8.150 FF+6.25d | resources SSH-Construction Manhours [19200 h] → SSH-Construction Manhours [1169.54 h] |
| 1.4.2.3.8.160 | Testing & Commissioning of LS 12 | 2012-08-28 → 2013-05-09 (+254d) | 2012-10-18 → 2013-06-05 (+230d) | 56.25d → 30d |  | 31.25d → -202.5d | Testing & commissioning of generator LS12, 1.4.2.3.8.155, 1.4.3.1.1.570, 1.4.3.1.2.570, M2.10 → 1.4.2.3.8.155, 1.4.3.1.1.570, 1.4.3.1.2.570, M2.10, 1.4.2.7.4.124, 1.4.2.3.8.152 | resources SSH-Construction Manhours [25500 h] → SSH-Construction Manhours [768.91 h] |
| 1 | **Zone 1** | 2011-08-21 → 2012-03-04 (+196d) | 2011-10-17 → 2012-10-25 (+374d) |  |  |  |  |  |
| 1 | **Storm Drainage Ditches** | 2012-04-12 → 2012-03-04 (-39d) | 2012-06-30 → 2012-10-25 (+117d) |  |  |  |  |  |
| 1.4.2.4.1.020 | Construction of concrete drainage ditch | 2012-05-03 → 2012-03-04 A (-60d) | 2012-05-26 → 2012-10-24 (+151d) |  | 0% → 60% | 182.5d → -114.69d | 1.4.2.4.1.010 SS+22.5d → 1.4.2.4.1.010 | resources SSH-Construction Manhours [10000 h] → SSH-Construction Manhours [1093.19 h] |
| 1.4.2.4.1.015 | Leveling -compaction of drainage ditch | 2012-06-02 → 2012-04-02 A (-61d) | 2012-06-30 → 2012-10-25 (+117d) |  | 0% → 65% | 182.5d → -114.69d |  | resources SSH-Construction Manhours [10000 h] → SSH-Construction Manhours [1093.19 h] |
| 1.4.2.4.1.010 | Excavation for storm water drainage ditch (750LM) | 2012-04-12 A | 2012-05-05 → 2012-10-15 (+163d) |  | 0% → 50% | 80d → -156.25d | 1.4.2.4.2.090A SS+25d → 1.4.2.3.8.010 FF | resources SSH-Construction Manhours [8000 h] → SSH-Construction Manhours [874.34 h] |
| 2 | **Zone 2** | 2011-10-02 → 2012-08-02 (+305d) | 2012-09-18 → 2013-03-28 (+191d) |  |  |  |  |  |
| 1 | **Storm Drainage Ditches** | 2012-03-20 → 2012-10-25 (+219d) | 2012-08-20 → 2013-03-28 (+220d) |  |  |  |  |  |
| 1.4.2.4.2.090A | Excavation for storm water drainage ditch (2550LM)A | 2012-03-20 → 2012-10-25 (+219d) | 2012-03-28 → 2012-11-04 (+221d) |  |  | 62.5d → -114.69d | Z2.1100 → 1.4.2.4.1.015 | resources SSH-Construction Manhours [3200 h] → SSH-Construction Manhours [349.74 h] |
| 1.4.2.4.2.090B | Leveling - compaction of drainage ditchA | 2012-03-29 → 2012-11-04 (+220d) | 2012-04-09 → 2012-11-15 (+220d) |  |  | 127.5d → -95.94d |  | resources SSH-Construction Manhours [4000 h] → SSH-Construction Manhours [437.17 h] |

| ID | Task | Start | Finish | Duration | Complete | Total float | Predecessors | Other |
| --- | --- | --- | --- | --- | --- | --- | --- | --- |
| 1.4.2.4.2.090C | Construction of concrete drainage ditchA | 2012-04-10 → 2012-11-15 (+219d) | 2012-04-26 → 2012-12-27 (+245d) | 18.75d → 45d |  | 127.5d → -95.94d |  | resources SSH-Construction Manhours [7500 h] → SSH-Construction Manhours [819.76 h] |
| 1.4.2.4.2.091A | Excavation for storm water drainage ditch (2550LM)B | 2012-04-28 → 2012-11-25 (+211d) | 2012-05-06 → 2012-12-04 (+212d) |  |  | 127.5d → -95.94d | 1.4.2.4.2.090C → 1.4.2.4.2.090C SS+10d | resources SSH-Construction Manhours [3200 h] → SSH-Construction Manhours [377.29 h] |
| 1.4.2.4.2.091B | Leveling - compaction of drainage ditchB | 2012-05-07 → 2012-12-04 (+211d) | 2012-05-17 → 2012-12-16 (+213d) |  |  | 127.5d → -95.94d |  | resources SSH-Construction Manhours [4000 h] → SSH-Construction Manhours [437.17 h] |
| 1.4.2.4.2.091C | Construction of concrete drainage ditchB | 2012-05-19 → 2012-12-16 (+211d) | 2012-06-04 → 2013-01-27 (+237d) | 18.75d → 45d |  | 127.5d → -95.94d |  | resources SSH-Construction Manhours [7500 h] → SSH-Construction Manhours [819.76 h] |
| 1.4.2.4.2.092A | Excavation for storm water drainage ditch (2550LM)C | 2012-06-05 → 2012-12-25 (+203d) | 2012-06-13 → 2013-01-03 (+204d) |  |  | 127.5d → -95.94d | 1.4.2.4.2.091C → 1.4.2.4.2.091C SS+10d | resources SSH-Construction Manhours [3200 h] → SSH-Construction Manhours [349.74 h] |
| 1.4.2.4.2.092B | Leveling - compaction of drainage ditchC | 2012-06-14 → 2013-01-03 (+203d) | 2012-06-25 → 2013-01-15 (+204d) |  |  | 127.5d → -95.94d |  | resources SSH-Construction Manhours [4000 h] → SSH-Construction Manhours [437.17 h] |
| 1.4.2.4.2.092D | Construction of concrete drainage ditchC | 2012-06-26 → 2013-01-15 (+203d) | 2012-07-12 → 2013-02-26 (+229d) | 18.75d → 45d |  | 127.5d → -95.94d |  | resources SSH-Construction Manhours [6000 h] → SSH-Construction Manhours [656.02 h] |
| 1.4.2.4.2.093A | Excavation for storm water drainage ditch (2550LM)D | 2012-07-14 → 2013-01-24 (+194d) | 2012-07-22 → 2013-02-03 (+196d) |  |  | 127.5d → -95.94d | 1.4.2.4.2.092D → 1.4.2.4.2.092D SS+10d | resources SSH-Construction Manhours [3200 h] → SSH-Construction Manhours [349.74 h] |
| 1.4.2.4.2.093B | Leveling - compaction of drainage ditchD | 2012-07-23 → 2013-02-03 (+195d) | 2012-08-02 → 2013-02-14 (+196d) |  |  | 127.5d → -95.94d |  | resources SSH-Construction Manhours [4000 h] → SSH-Construction Manhours [437.17 h] |
| 1.4.2.4.2.093C | Construction of concrete drainage ditchD | 2012-08-04 → 2013-02-14 (+194d) | 2012-08-20 → 2013-03-28 (+220d) | 18.75d → 45d |  | 127.5d → -95.94d |  | resources SSH-Construction Manhours [7500 h] → SSH-Construction Manhours [819.76 h] |
| 2 | **Strom Drainage Ponds & Box Culverts** | 2012-03-20 → 2012-08-02 (+135d) | 2012-10-20 → 2013-03-28 (+159d) |  |  |  |  |  |
| 1.4.2.4.2.053A | Excavation for Box culvert-4 | 2012-09-01 → 2012-08-02 A (-30d) | 2012-09-06 → 2012-08-09 A (-28d) |  | 0% → 100% | 62.5d → none | 1.4.2.4.2.052C → 1.4.2.4.2.052C SS+20d | resources SSH-Construction Manhours [2400 h] → SSH-Construction Manhours [262.3 h] |
| 1.4.2.4.2.053B | Leveling -compaction of box culvert-4 | 2012-09-08 → 2012-08-09 A (-30d) | 2012-09-13 → 2013-01-31 (+140d) |  | 0% → 35% | 62.5d → -95.81d |  | resources SSH-Construction Manhours [2400 h] → SSH-Construction Manhours [262.3 h] |
| 1.4.2.4.2.010 | Excavation for storm water drainage pond | 2012-03-20 → 2012-11-04 (+229d) | 2012-03-28 → 2012-11-13 (+230d) |  |  | 62.5d → -114.69d | 1.4.2.4.2.090A SS → 1.4.2.4.2.090A | resources SSH-Construction Manhours [3200 h]; Excavator [80 h]; Dump Truck [80 h] → SSH-Construction Manhours [349.74 h]; Excavator [80 h]; Dump Truck [80 h] |
| 1.4.2.4.2.050A | Excavation for Box culvert-1 | 2012-03-20 → 2012-11-04 (+229d) | 2012-03-26 → 2012-11-11 (+230d) |  |  | 62.5d → -95.81d |  | resources SSH-Construction Manhours [2400 h] → SSH-Construction Manhours [262.3 h] |
| 1.4.2.4.2.050B | Leveling -compaction of box culvert-1 | 2012-03-27 → 2012-11-11 (+229d) | 2012-04-02 → 2012-11-18 (+230d) |  |  | 62.5d → -95.81d |  | resources SSH-Construction Manhours [2400 h] → SSH-Construction Manhours [262.3 h] |
| 1.4.2.4.2.020 | Construction of RC spillways | 2012-03-29 → 2012-11-13 (+229d) | 2012-04-21 → 2012-12-25 (+248d) | 25d → 45d |  | 212.5d → -40.94d |  | resources SSH-Construction Manhours [16000 h] → SSH-Construction Manhours [1749.21 h] |
| 1.4.2.4.2.050C | Construction of box culvert-1 | 2012-04-03 → 2012-11-18 (+229d) | 2012-05-13 → 2013-01-13 (+245d) | 43.75d → 60d |  | 62.5d → -95.81d |  | resources SSH-Construction Manhours [70000 h] → SSH-Construction Manhours [7652.35 h] |
| 1.4.2.4.2.051A | Excavation for Box culvert-2 | 2012-05-14 → 2012-12-06 (+206d) | 2012-05-20 → 2012-12-13 (+207d) |  |  | 62.5d → -95.81d | 1.4.2.4.2.050C → 1.4.2.4.2.050C SS+20d | resources SSH-Construction Manhours [2400 h] → SSH-Construction Manhours [262.3 h] |
| 1.4.2.4.2.051B | Leveling -compaction of box culvert-2 | 2012-05-21 → 2012-12-13 (+206d) | 2012-05-27 → 2012-12-20 (+207d) |  |  | 62.5d → -95.81d |  | resources SSH-Construction Manhours [2400 h] → SSH-Construction Manhours [262.3 h] |
| 1.4.2.4.2.051C | Construction of box culvert-2 | 2012-05-28 → 2012-12-13 (+199d) | 2012-07-07 → 2013-02-07 (+215d) | 43.75d → 60d |  | 62.5d → -95.81d | 1.4.2.4.2.051B → 1.4.2.4.2.051B SS | resources SSH-Construction Manhours [12500 h] → SSH-Construction Manhours [1366.62 h] |
| 1.4.2.4.2.015 | Leveling - compaction for drainage pond | 2012-04-22 → 2012-12-25 (+247d) | 2012-05-02 → 2013-01-06 (+249d) |  |  | 212.5d → -40.94d |  | resources SSH-Construction Manhours [4000 h] → SSH-Construction Manhours [437.17 h] |
| 1.4.2.4.2.052A | Excavation for Box culvert-3 | 2012-07-08 → 2013-01-01 (+177d) | 2012-07-14 → 2013-01-08 (+178d) |  |  | 62.5d → -95.81d | 1.4.2.4.2.051C → 1.4.2.4.2.051C SS+20d | resources SSH-Construction Manhours [2400 h] → SSH-Construction Manhours [262.3 h] |
| 1.4.2.4.2.052B | Leveling -compaction of box culvert-3 | 2012-07-15 → 2013-01-08 (+177d) | 2012-07-21 → 2013-01-15 (+178d) |  |  | 62.5d → -95.81d |  | resources SSH-Construction Manhours [2400 h] → SSH-Construction Manhours [262.3 h] |
| 1.4.2.4.2.052C | Construction of box culvert-3 | 2012-07-22 → 2013-01-08 (+170d) | 2012-08-30 → 2013-03-05 (+187d) | 43.75d → 60d |  | 62.5d → -95.81d | 1.4.2.4.2.052B → 1.4.2.4.2.052B SS | resources SSH-Construction Manhours [10000 h] → SSH-Construction Manhours [1093.19 h] |
| 1.4.2.4.2.040 | Marl caping for drainage pond | 2012-05-10 → 2013-01-13 (+248d) | 2012-06-02 → 2013-02-05 (+248d) |  |  | 212.5d → -40.94d |  | resources SSH-Construction Manhours [8000 h] → SSH-Construction Manhours [874.34 h] |
| 1.4.2.4.2.054A | Excavation for Box culvert-5 | 2012-09-01 → 2013-01-27 (+148d) | 2012-09-06 → 2013-02-03 (+150d) |  |  | 62.5d → -90.94d | 1.4.2.4.2.053A SS → 1.4.2.4.2.053A SS+20d | resources SSH-Construction Manhours [2400 h] → SSH-Construction Manhours [127.18 h] |
| 1.4.2.4.2.053C | Construction of box culvert-4 | 2012-09-15 → 2013-01-31 (+138d) | 2012-10-20 → 2013-03-28 (+159d) | 38.75d → 60d |  | 62.5d → -95.81d |  | resources SSH-Construction Manhours [8500 h] → SSH-Construction Manhours [929.45 h] |
| 1.4.2.4.2.054B | Leveling -compaction of box culvert-5 | 2012-09-08 → 2013-02-03 (+148d) | 2012-09-13 → 2013-02-10 (+150d) |  |  | 62.5d → -90.94d |  | resources SSH-Construction Manhours [2400 h] → SSH-Construction Manhours [262.3 h] |
| 1.4.2.4.2.054C | Construction of box culvert-5 | 2012-09-15 → 2013-02-10 (+148d) | 2012-10-20 → 2013-03-24 (+155d) | 38.75d → 45d |  | 62.5d → -90.94d |  | resources SSH-Construction Manhours [8500 h] → SSH-Construction Manhours [262.3 h] |
| 3 | **Zone 3** | 2012-01-28 → 2012-06-07 (+131d) | 2012-10-20 → 2013-04-15 (+177d) |  |  |  |  |  |
| 1 | **Storm Drainage Ditches-A3-1** | 2012-01-28 → 2012-11-13 (+290d) | 2012-06-20 → 2013-04-02 (+286d) |  |  |  |  |  |
| 1.4.2.4.3.090A | Excavation for storm water drainage ditchA3-1-1 | 2012-01-28 → 2012-11-13 (+290d) | 2012-02-04 → 2012-11-20 (+290d) |  |  | 62.75d → -114.69d | 1.4.2.7.3.030 SS+31.25d → 1.4.2.4.2.010 | resources SSH-Construction Manhours [3600 h] → SSH-Construction Manhours [393.72 h] |
| 1.4.2.4.3.090B | Leveling -compaction of drainage ditchA3-1-1 | 2012-02-04 → 2012-11-20 (+290d) | 2012-02-15 → 2012-12-02 (+291d) |  |  | 66.5d → -113.44d |  | resources SSH-Construction Manhours [6000 h] → SSH-Construction Manhours [656.02 h] |
| 1.4.2.4.3.090C | Construction of concrete drainage ditchA3-1-1 | 2012-02-15 → 2012-12-02 (+291d) | 2012-03-04 → 2013-01-08 (+310d) | 18.75d → 40d |  | 66.5d → -113.44d |  | resources SSH-Construction Manhours [9000 h] → SSH-Construction Manhours [984.03 h] |
| 1.4.2.4.3.092A | Excavation for storm water drainage ditchA3-1-2 | 2012-03-04 → 2012-12-11 (+282d) | 2012-03-11 → 2012-12-18 (+282d) |  |  | 66.5d → -113.44d | 1.4.2.4.3.090C → 1.4.2.4.3.090C SS+10d | resources SSH-Construction Manhours [2400 h] → SSH-Construction Manhours [262.3 h] |
| 1.4.2.4.3.092B | Leveling -compaction of drainage ditchA3-1-2 | 2012-03-11 → 2012-12-18 (+282d) | 2012-03-22 → 2012-12-30 (+283d) |  |  | 66.5d → -100.94d |  | resources SSH-Construction Manhours [4000 h] → SSH-Construction Manhours [437.17 h] |
| 1.4.2.4.3.092C | Construction of concrete drainage ditchA3-1-2 | 2012-03-22 → 2012-12-30 (+283d) | 2012-04-09 → 2013-02-05 (+302d) | 18.75d → 40d |  | 66.5d → -100.94d |  | resources SSH-Construction Manhours [7500 h] → SSH-Construction Manhours [819.76 h] |
| 1.4.2.4.3.094A | Excavation for storm water drainage ditchA3-1-3 | 2012-04-09 → 2013-01-08 (+274d) | 2012-04-16 → 2013-01-15 (+274d) |  |  | 66.5d → -100.94d | 1.4.2.4.3.092C → 1.4.2.4.3.092C SS+10d | resources SSH-Construction Manhours [2400 h] → SSH-Construction Manhours [262.3 h] |
| 1.4.2.4.3.094B | Leveling -compaction of drainage ditchA3-1-3 | 2012-04-16 → 2013-01-15 (+274d) | 2012-04-28 → 2013-01-27 (+274d) |  |  | 66.5d → -100.94d |  | resources SSH-Construction Manhours [4000 h] → SSH-Construction Manhours [437.17 h] |
| 1.4.2.4.3.094C | Construction of concrete drainage ditchA3-1-3 | 2012-04-28 → 2013-01-27 (+274d) | 2012-05-15 → 2013-03-05 (+294d) | 18.75d → 40d |  | 66.5d → -100.94d |  | resources SSH-Construction Manhours [7500 h] → SSH-Construction Manhours [819.76 h] |
| 1.4.2.4.3.096A | Excavation for storm water drainage ditchA3-1-4 | 2012-05-15 → 2013-02-05 (+266d) | 2012-05-22 → 2013-02-12 (+266d) |  |  | 66.5d → -100.94d | 1.4.2.4.3.094C → 1.4.2.4.3.094C SS+10d | resources SSH-Construction Manhours [2400 h] → SSH-Construction Manhours [262.3 h] |
| 1.4.2.4.3.096B | Leveling -compaction of drainage ditchA3-1-4 | 2012-05-22 → 2013-02-12 (+266d) | 2012-06-03 → 2013-02-24 (+266d) |  |  | 66.5d → -100.94d |  | resources SSH-Construction Manhours [4000 h] → SSH-Construction Manhours [437.17 h] |
| 1.4.2.4.3.096C | Construction of concrete drainage ditchA3-1-4 | 2012-06-03 → 2013-02-24 (+266d) | 2012-06-20 → 2013-04-02 (+286d) | 18.75d → 40d |  | 66.5d → -100.94d |  | resources SSH-Construction Manhours [7500 h] → SSH-Construction Manhours [819.76 h] |
| 2 | **Strom Drainage Ponds-A3-1** | 2012-06-20 → 2012-12-11 (+174d) | 2012-10-16 → 2013-04-14 (+180d) |  |  |  |  |  |
| 1.4.2.4.3.010 | Excavation for storm water drainage pond (1) | 2012-06-20 → 2012-12-11 (+174d) | 2012-06-27 → 2012-12-18 (+174d) |  |  | 66.5d → -113.44d | 1.4.2.4.3.096C → 1.4.2.4.3.092A FF | resources SSH-Construction Manhours [3000 h]; Excavator [60 h]; Dump Truck [60 h] → SSH-Construction Manhours [328.01 h]; Excavator [60 h]; Dump Truck [60 h] |
| 1.4.2.4.3.015 | Leveling- compaction for drainage pond | 2012-06-27 → 2012-12-18 (+174d) | 2012-07-11 → 2013-01-01 (+174d) |  |  | 66.5d → -113.44d |  | resources SSH-Construction Manhours [6000 h] → SSH-Construction Manhours [656.02 h] |
| 1.4.2.4.3.020 | Construction of RC spillwaysA | 2012-07-11 → 2013-01-01 (+174d) | 2012-08-04 → 2013-01-24 (+173d) |  |  | 66.5d → -113.44d |  | resources SSH-Construction Manhours [12000 h] → SSH-Construction Manhours [1312.04 h] |
| 1.4.2.4.3.030 | Construction of RC spillwaysB | 2012-08-04 → 2013-01-20 (+169d) | 2012-08-27 → 2013-02-12 (+169d) |  |  | 66.5d → -113.44d | 1.4.2.4.3.020 → 1.4.2.4.3.020 FF+20d | resources SSH-Construction Manhours [12000 h] → SSH-Construction Manhours [1312.04 h] |
| 1.4.2.4.3.040 | Marl caping for drainage pond | 2012-08-27 → 2013-02-12 (+169d) | 2012-09-19 → 2013-03-07 (+169d) |  |  | 66.5d → -113.44d |  | resources SSH-Construction Manhours [8000 h] → SSH-Construction Manhours [874.34 h] |
| 1.4.2.4.3.050 | Excavation for Box culvert | 2012-08-27 → 2013-02-12 (+169d) | 2012-09-03 → 2013-02-19 (+169d) |  |  | 66.5d → -113.44d |  | resources SSH-Construction Manhours [2400 h] → SSH-Construction Manhours [262.3 h] |
| 1.4.2.4.3.060 | Leveling -compaction of box culvert | 2012-09-03 → 2013-02-19 (+169d) | 2012-09-10 → 2013-02-26 (+169d) |  |  | 66.5d → -113.44d |  | resources SSH-Construction Manhours [2400 h] → SSH-Construction Manhours [262.3 h] |
| 1.4.2.4.3.070 | Construction of box culvert | 2012-09-10 → 2013-02-26 (+169d) | 2012-10-16 → 2013-04-14 (+180d) | 38.75d → 50d |  | 66.5d → -113.44d | 1.4.2.4.3.060 → 1.4.2.4.3.060, 1.4.2.4.3.096C FF | resources SSH-Construction Manhours [8500 h] → SSH-Construction Manhours [929.45 h] |
| 3 | **Storm Drainage Ditches-A3-2** | 2012-02-04 → 2012-11-20 (+290d) | 2012-09-03 → 2013-04-15 (+224d) |  |  |  |  |  |
| 1.4.2.4.3.100A | Excavation for storm water drainage ditchA3-2.-1 | 2012-02-04 → 2012-11-20 (+290d) | 2012-02-21 → 2012-12-08 (+291d) |  |  | 62.75d → -114.69d | 1.4.2.4.3.090A → 1.4.2.4.3.090A, M1.07 | resources SSH-Construction Manhours [6000 h] → SSH-Construction Manhours [656.02 h] |
| 1.4.2.4.3.100B | Leveling -compaction of drainage ditchA3-2-1 | 2012-02-21 → 2012-12-08 (+291d) | 2012-03-06 → 2012-12-22 (+291d) |  |  | 112.75d → -114.69d |  | resources SSH-Construction Manhours [4800 h] → SSH-Construction Manhours [524.61 h] |
| 1.4.2.4.3.100C | Construction of concrete drainage ditchA3-2-1 | 2012-03-06 → 2012-12-22 (+291d) | 2012-03-29 → 2013-02-02 (+310d) | 25d → 45d |  | 112.75d → -98.44d |  | resources SSH-Construction Manhours [10000 h] → SSH-Construction Manhours [1093.19 h] |
| 1.4.2.4.3.104A | Excavation for storm water drainage ditchA3-2-3 | 2012-05-21 → 2012-12-22 (+215d) | 2012-06-07 → 2013-01-08 (+215d) |  |  | 112.75d → -114.69d | 1.4.2.4.3.102C → 1.4.2.4.3.100B | resources SSH-Construction Manhours [6000 h] → SSH-Construction Manhours [656.02 h] |
| 1.4.2.4.3.102A | Excavation for storm water drainage ditchA3-2-2 | 2012-03-29 → 2013-01-05 (+282d) | 2012-04-16 → 2013-01-22 (+281d) |  |  | 112.75d → -98.44d | 1.4.2.4.3.100C → 1.4.2.4.3.100C SS+15d | resources SSH-Construction Manhours [6000 h] → SSH-Construction Manhours [656.02 h] |
| 1.4.2.4.3.104B | Leveling -compaction of drainage ditchA3-2-3 | 2012-06-07 → 2013-01-08 (+215d) | 2012-06-19 → 2013-01-20 (+215d) |  |  | 112.75d → -114.69d |  | resources SSH-Construction Manhours [7000 h] → SSH-Construction Manhours [765.18 h] |
| 1.4.2.4.3.104C | Construction of concrete drainage ditchA3-2-3 | 2012-06-19 → 2013-01-20 (+215d) | 2012-07-12 → 2013-03-03 (+234d) | 25d → 45d |  | 112.75d → -114.69d |  | resources SSH-Construction Manhours [10000 h] → SSH-Construction Manhours [1093.19 h] |
| 1.4.2.4.3.102B | Leveling -compaction of drainage ditchA3-2-2 | 2012-04-16 → 2013-01-22 (+281d) | 2012-04-28 → 2013-02-03 (+281d) |  |  | 112.75d → -98.44d |  | resources SSH-Construction Manhours [4000 h] → SSH-Construction Manhours [437.17 h] |
| 1.4.2.4.3.102C | Construction of concrete drainage ditchA3-2-2 | 2012-04-28 → 2013-02-03 (+281d) | 2012-05-21 → 2013-03-17 (+300d) | 25d → 45d |  | 112.75d → -98.44d |  | resources SSH-Construction Manhours [10000 h] → SSH-Construction Manhours [1093.19 h] |
| 1.4.2.4.3.106A | Excavation for storm water drainage ditchA3-2-4 | 2012-07-12 → 2013-02-03 (+206d) | 2012-07-30 → 2013-02-20 (+205d) |  |  | 112.75d → -114.69d | 1.4.2.4.3.104C → 1.4.2.4.3.104C SS+15d | resources SSH-Construction Manhours [7500 h] → SSH-Construction Manhours [819.76 h] |
| 1.4.2.4.3.106B | Leveling -compaction of drainage ditchA3-2-4 | 2012-07-30 → 2013-02-20 (+205d) | 2012-08-11 → 2013-03-04 (+205d) |  |  | 112.75d → -114.69d |  | resources SSH-Construction Manhours [5000 h] → SSH-Construction Manhours [546.86 h] |
| 1.4.2.4.3.106C | Construction of concrete drainage ditchA3-2-4 | 2012-08-11 → 2013-03-04 (+205d) | 2012-09-03 → 2013-04-15 (+224d) | 25d → 45d |  | 112.75d → -114.69d | 1.4.2.4.3.106B → 1.4.2.4.3.106B, 1.4.2.4.3.102C SS+15d | resources SSH-Construction Manhours [12000 h] → SSH-Construction Manhours [1312.04 h] |
| 5 | **Storm Drainage Ditches & Box Culvert -A3-3** | 2012-02-21 → 2012-06-13 (+113d) | 2012-09-10 → 2013-04-02 (+204d) |  |  |  |  |  |
| 1.4.2.4.3.110A | Excavation for storm water drainage ditchA3-3-1 | 2012-02-21 → 2012-06-13 A (+113d) | 2012-03-10 → 2012-12-20 (+285d) |  | 0% → 25% | 62.75d → -103.9d |  | resources SSH-Construction Manhours [6000 h] → SSH-Construction Manhours [656.02 h] |
| 1.4.2.4.3.110B | Leveling -compaction of drainage ditchA3-3-1 | 2012-03-10 → 2012-07-01 A (+113d) | 2012-03-24 → 2013-01-02 (+284d) |  | 0% → 16% | 62.75d → -100.1d |  | resources SSH-Construction Manhours [4800 h] → SSH-Construction Manhours [524.61 h] |
| 1.4.2.4.3.110C | Construction of concrete drainage ditchA3-3-1 | 2012-03-24 → 2012-07-15 A (+113d) | 2012-04-16 → 2013-02-04 (+294d) | 25d → 45d | 0% → 20% | 62.75d → -90.1d |  | resources SSH-Construction Manhours [10000 h] → SSH-Construction Manhours [1093.19 h] |

| ID | Task | Start | Finish | Duration | Complete | Total float | Predecessors | Other |
| --- | --- | --- | --- | --- | --- | --- | --- | --- |
| 1.4.2.4.3.114A | Excavation for storm water drainage ditchA3-3-3 | 2012-06-07 → 2012-12-16 (+192d) | 2012-06-25 → 2013-01-02 (+191d) |  |  | 62.75d → -100.1d | 1.4.2.4.3.112C → 1.4.2.4.3.110B FF | resources SSH-Construction Manhours [6000 h] → SSH-Construction Manhours [656.02 h] |
| 1.4.2.4.3.112A | Excavation for storm water drainage ditchA3-3-2 | 2012-04-16 → 2013-01-02 (+261d) | 2012-05-03 → 2013-01-20 (+262d) |  |  | 62.75d → -90.1d | 1.4.2.4.3.110C → 1.4.2.4.3.110C SS+15d | resources SSH-Construction Manhours [6000 h] → SSH-Construction Manhours [656.02 h] |
| 1.4.2.4.3.114B | Leveling -compaction of drainage ditchA3-3-3 | 2012-06-25 → 2013-01-02 (+191d) | 2012-07-07 → 2013-01-14 (+191d) |  |  | 105.25d → -100.1d |  | resources SSH-Construction Manhours [4000 h] → SSH-Construction Manhours [437.17 h] |
| 1.4.2.4.3.114C | Construction of concrete drainage ditchA3-3-3 | 2012-07-07 → 2013-01-14 (+191d) | 2012-07-30 → 2013-02-25 (+210d) | 25d → 45d |  | 105.25d → -100.1d |  | resources SSH-Construction Manhours [10000 h] → SSH-Construction Manhours [1093.19 h] |
| 1.4.2.4.3.112B | Leveling -compaction of drainage ditchA3-3-2 | 2012-05-03 → 2013-01-20 (+262d) | 2012-05-15 → 2013-01-31 (+261d) |  |  | 62.75d → -90.1d |  | resources SSH-Construction Manhours [4000 h] → SSH-Construction Manhours [437.17 h] |
| 1.4.2.4.3.116A | Excavation for storm water drainage ditchA3-3-4 | 2012-07-30 → 2013-01-28 (+182d) | 2012-08-16 → 2013-02-14 (+182d) |  |  | 105.25d → -100.1d | 1.4.2.4.3.114C → 1.4.2.4.3.114C SS+15d | resources SSH-Construction Manhours [6000 h] → SSH-Construction Manhours [656.02 h] |
| 1.4.2.4.3.112C | Construction of concrete drainage ditchA3-3-2 | 2012-05-15 → 2013-01-31 (+261d) | 2012-06-07 → 2013-03-14 (+280d) | 25d → 45d |  | 62.75d → -90.1d |  | resources SSH-Construction Manhours [10000 h] → SSH-Construction Manhours [1093.19 h] |
| 1.4.2.4.3.116B | Leveling -compaction of drainage ditchA3-3-4 | 2012-08-16 → 2013-02-14 (+182d) | 2012-08-28 → 2013-02-26 (+182d) |  |  | 105.25d → -100.1d |  | resources SSH-Construction Manhours [4000 h] → SSH-Construction Manhours [437.17 h] |
| 1.4.2.4.3.116C | Construction of concrete drainage ditchA3-3-4 | 2012-08-21 → 2013-02-19 (+182d) | 2012-09-10 → 2013-04-02 (+204d) | 21.25d → 45d |  | 105.25d → -100.1d | 1.4.2.4.3.116B SS+5d → 1.4.2.4.3.116B SS+5d, 1.4.2.4.3.112C SS+10d | resources SSH-Construction Manhours [6800 h] → SSH-Construction Manhours [743.46 h] |
| 6 | **Strom Drainage Ponds -A3-3** | 2012-06-07 → 2012-06-24 (+17d) | 2012-10-20 → 2013-04-06 (+168d) |  |  |  |  |  |
| 1.4.2.4.3.310 | Excavation for storm water drainage pond (1) | 2012-06-07 → 2012-06-24 A (+17d) | 2012-06-14 → 2012-12-20 (+189d) |  | 0% → 10% | 62.75d → -103.9d | 1.4.2.4.3.114A SS → 1.4.2.4.3.110A FF | resources SSH-Construction Manhours [4200 h]; Dump Truck [60 h]; Excavator [60 h] → SSH-Construction Manhours [458.9 h]; Dump Truck [60 h]; Excavator [60 h] |
| 1.4.2.4.3.320 | Leveling- compaction for drainage pond | 2012-06-14 → 2012-07-01 A (+17d) | 2012-06-24 → 2012-12-29 (+188d) |  | 0% → 14% | 62.75d → -103.9d |  | resources SSH-Construction Manhours [4000 h] → SSH-Construction Manhours [437.17 h] |
| 1.4.2.4.3.330 | Construction of RC spillways | 2012-06-24 → 2012-12-29 (+188d) | 2012-07-17 → 2013-01-21 (+188d) |  |  | 62.75d → -103.9d |  | resources SSH-Construction Manhours [16000 h] → SSH-Construction Manhours [1749.21 h] |
| 1.4.2.4.3.340 | Marl caping for drainage pond | 2012-07-17 → 2013-01-14 (+181d) | 2012-07-26 → 2013-01-23 (+181d) |  |  | 62.75d → -103.9d | 1.4.2.4.3.330 → 1.4.2.4.3.330 FF+2d | resources SSH-Construction Manhours [24000 h] → SSH-Construction Manhours [2623.56 h] |
| 1.4.2.4.3.350 | Excavation for storm water drainage pond (2) | 2012-07-26 → 2013-01-23 (+181d) | 2012-08-02 → 2013-01-30 (+181d) |  |  | 62.75d → -103.9d |  | resources SSH-Construction Manhours [4200 h] → SSH-Construction Manhours [458.9 h] |
| 1.4.2.4.3.360 | Leveling- compaction for drainage pond | 2012-08-02 → 2013-01-30 (+181d) | 2012-08-09 → 2013-02-06 (+181d) |  |  | 62.75d → -103.9d |  | resources SSH-Construction Manhours [4200 h] → SSH-Construction Manhours [458.9 h] |
| 1.4.2.4.3.370 | Construction of RC spillways | 2012-08-09 → 2013-02-06 (+181d) | 2012-09-02 → 2013-03-02 (+181d) |  |  | 62.75d → -103.9d |  | resources SSH-Construction Manhours [12000 h] → SSH-Construction Manhours [1312.04 h] |
| 1.4.2.4.3.450 | Construction of box culvert | 2012-09-16 → 2013-02-18 (+155d) | 2012-10-20 → 2013-04-06 (+168d) | 36.25d → 50d |  | 62.75d → -103.9d | 1.4.2.4.3.400 → 1.4.2.4.3.400 FF+30d | resources SSH-Construction Manhours [8500 h] → SSH-Construction Manhours [929.45 h] |
| 1.4.2.4.3.380 | Marl caping for drainage pond | 2012-09-02 → 2013-02-23 (+174d) | 2012-09-11 → 2013-03-04 (+174d) |  |  | 62.75d → -103.9d | 1.4.2.4.3.370 → 1.4.2.4.3.370 FF+2d | resources SSH-Construction Manhours [24000 h] → SSH-Construction Manhours [2623.56 h] |
| 1.4.2.4.3.390 | Excavation for Box culvert | 2012-09-02 → 2013-02-23 (+174d) | 2012-09-09 → 2013-03-02 (+174d) |  |  | 62.75d → -103.9d |  | resources SSH-Construction Manhours [2400 h] → SSH-Construction Manhours [262.3 h] |
| 1.4.2.4.3.400 | Leveling -compaction of box culvert | 2012-09-09 → 2013-03-02 (+174d) | 2012-09-16 → 2013-03-09 (+174d) |  |  | 62.75d → -103.9d |  | resources SSH-Construction Manhours [2400 h] → SSH-Construction Manhours [262.3 h] |
| 7 | **Strom Drainage Ponds -A3-4** |  | 2012-10-10 → 2013-03-12 (+153d) |  |  |  |  |  |
| 1.4.2.4.3.410 | Excavation for storm water drainage ditchA | 2012-06-07 A | 2012-06-19 → 2012-10-11 (+114d) |  | 0% → 30% | 72.75d → -156.25d | 1.4.2.4.3.310 SS → 1.4.2.4.1.010 SS | resources SSH-Construction Manhours [4200 h]; Excavator [60 h]; Dump Truck [60 h] → SSH-Construction Manhours [458.9 h]; Excavator [60 h]; Dump Truck [60 h] |
| 1.4.2.4.3.420 | Leveling -compaction of drainage ditchA | 2012-06-19 → 2012-10-13 (+116d) | 2012-07-01 → 2012-10-30 (+121d) | 12.5d → 20d |  | 72.75d → -156.25d |  | resources SSH-Construction Manhours [4000 h] → SSH-Construction Manhours [437.17 h] |
| 1.4.2.4.3.430 | Construction of concrete drainage ditchA | 2012-07-01 → 2012-10-31 (+122d) | 2012-07-24 → 2012-12-11 (+140d) | 25d → 45d |  | 72.75d → -156.25d |  | resources SSH-Construction Manhours [16000 h] → SSH-Construction Manhours [1749.21 h] |
| 1.4.2.4.3.440 | Excavation for storm water drainage ditchB | 2012-07-24 → 2012-11-19 (+118d) | 2012-08-05 → 2012-12-02 (+119d) | 12.5d → 15d |  | 72.75d → -156.25d | 1.4.2.4.3.430 → 1.4.2.4.3.430 SS+20d | resources SSH-Construction Manhours [3200 h] → SSH-Construction Manhours [349.74 h] |
| 1.4.2.4.3.460 | Leveling -compaction of drainage ditchB | 2012-08-05 → 2012-12-03 (+120d) | 2012-08-16 → 2012-12-16 (+122d) | 12.5d → 15d |  | 72.75d → -78.75d |  | resources SSH-Construction Manhours [4000 h] → SSH-Construction Manhours [437.17 h] |
| 1.4.2.4.3.470 | Construction of concrete drainage ditchB | 2012-08-16 → 2012-12-17 (+123d) | 2012-09-09 → 2013-01-27 (+140d) | 25d → 45d |  | 72.75d → -78.75d |  | resources SSH-Construction Manhours [16000 h] → SSH-Construction Manhours [1749.21 h] |
| 1.4.2.4.3.480 | Excavation for Box culvert A | 2012-08-16 → 2013-01-05 (+142d) | 2012-08-23 → 2013-01-10 (+140d) |  |  | 72.75d → -78.75d | 1.4.2.4.3.470 SS → 1.4.2.4.3.470 SS+20d | resources SSH-Construction Manhours [2400 h] → SSH-Construction Manhours [476.91 h] |
| 1.4.2.4.3.490 | Leveling -compaction of box culvertA | 2012-08-23 → 2013-01-12 (+142d) | 2012-08-30 → 2013-01-17 (+140d) |  |  | 77.75d → -66.25d |  | resources SSH-Construction Manhours [2400 h] → SSH-Construction Manhours [262.3 h] |
| 1.4.2.4.3.510 | Excavation for Box culvert B | 2012-08-23 → 2013-01-12 (+142d) | 2012-08-30 → 2013-01-20 (+143d) | 7.5d → 10d |  | 72.75d → -78.75d |  | resources SSH-Construction Manhours [2400 h] → SSH-Construction Manhours [262.3 h] |
| 1.4.2.4.3.500 | Construction of box culvertA | 2012-08-30 → 2013-01-19 (+142d) | 2012-10-06 → 2013-02-28 (+145d) | 38.75d → 45d |  | 77.75d → -66.25d |  | resources SSH-Construction Manhours [8500 h] → SSH-Construction Manhours [929.45 h] |
| 1.4.2.4.3.520 | Leveling -compaction of box culvertB | 2012-08-30 → 2013-01-21 (+144d) | 2012-09-06 → 2013-01-29 (+145d) | 7.5d → 10d |  | 72.75d → -78.75d |  | resources SSH-Construction Manhours [2400 h] → SSH-Construction Manhours [262.3 h] |
| 1.4.2.4.3.530 | Construction of box culvertB | 2012-09-06 → 2013-01-30 (+146d) | 2012-10-10 → 2013-03-12 (+153d) | 36.25d → 45d |  | 72.75d → -78.75d |  | resources SSH-Construction Manhours [8500 h] → SSH-Construction Manhours [929.45 h] |
| 8 | **Strom Drainage Ponds -A3-5** | 2012-06-07 → 2012-12-03 (+179d) | 2012-10-02 → 2013-03-19 (+168d) |  |  |  |  |  |
| 1.4.2.4.3.610 | Excavation for storm water drainage ditchA | 2012-06-07 → 2012-12-03 (+179d) | 2012-06-14 → 2012-12-09 (+178d) |  |  | 81.5d → -156.25d | 1.4.2.4.3.410 SS → 1.4.2.4.3.440 | resources SSH-Construction Manhours [4200 h]; Excavator [60 h]; Dump Truck [60 h] → SSH-Construction Manhours [458.9 h]; Excavator [60 h]; Dump Truck [60 h] |
| 1.4.2.4.3.620 | Leveling -compaction of drainage ditchA | 2012-06-14 → 2012-12-10 (+179d) | 2012-06-21 → 2012-12-16 (+178d) |  |  | 81.5d → -86.25d |  | resources SSH-Construction Manhours [4000 h] → SSH-Construction Manhours [437.17 h] |
| 1.4.2.4.3.630 | Construction of concrete drainage ditchA | 2012-06-21 → 2012-12-17 (+179d) | 2012-07-09 → 2013-01-27 (+202d) | 18.75d → 45d |  | 81.5d → -86.25d |  | resources SSH-Construction Manhours [16000 h] → SSH-Construction Manhours [1749.21 h] |
| 1.4.2.4.3.640 | Excavation for storm water drainage ditchB | 2012-07-09 → 2012-12-31 (+175d) | 2012-07-16 → 2013-01-06 (+174d) |  |  | 81.5d → -86.25d | 1.4.2.4.3.630 → 1.4.2.4.3.630 SS+15d | resources SSH-Construction Manhours [3200 h] → SSH-Construction Manhours [476.91 h] |
| 1.4.2.4.3.650 | Leveling -compaction of drainage ditchB | 2012-07-16 → 2013-01-07 (+175d) | 2012-07-23 → 2013-01-13 (+174d) |  |  | 81.5d → -86.25d |  | resources SSH-Construction Manhours [4000 h] → SSH-Construction Manhours [437.17 h] |
| 1.4.2.4.3.690 | Construction of box culvertA | 2012-08-23 → 2013-01-09 (+139d) | 2012-09-29 → 2013-02-19 (+143d) | 38.75d → 45d |  | 292.75d → -86.25d | 1.4.2.4.3.680 → 1.4.2.4.3.680 FF+10d | resources SSH-Construction Manhours [8500 h] → SSH-Construction Manhours [929.45 h] |
| 1.4.2.4.3.660 | Construction of concrete drainage ditchB | 2012-07-23 → 2013-01-14 (+175d) | 2012-08-09 → 2013-02-24 (+199d) | 18.75d → 45d |  | 81.5d → -86.25d |  | resources SSH-Construction Manhours [16000 h] → SSH-Construction Manhours [1749.21 h] |
| 1.4.2.4.3.720 | Construction of box culvertB | 2012-08-30 → 2013-01-23 (+146d) | 2012-10-02 → 2013-03-19 (+168d) | 35d → 60d |  | 81.5d → -86.25d | 1.4.2.4.3.710 → 1.4.2.4.3.710 FF+4d, 1.4.2.4.3.690 SS+15d | resources SSH-Construction Manhours [8500 h] → SSH-Construction Manhours [929.45 h] |
| 1.4.2.4.3.670 | Excavation for Box culvert A | 2012-08-09 → 2013-01-28 (+172d) | 2012-08-16 → 2013-02-03 (+171d) |  |  | 81.5d → -86.25d | 1.4.2.4.3.660 → 1.4.2.4.3.660 SS+15d | resources SSH-Construction Manhours [2400 h] → SSH-Construction Manhours [262.3 h] |
| 1.4.2.4.3.680 | Leveling -compaction of box culvertA | 2012-08-16 → 2013-02-04 (+172d) | 2012-08-23 → 2013-02-10 (+171d) |  |  | 292.75d → -86.25d |  | resources SSH-Construction Manhours [2400 h] → SSH-Construction Manhours [262.3 h] |
| 1.4.2.4.3.700 | Excavation for Box culvert B | 2012-08-16 → 2013-02-04 (+172d) | 2012-08-23 → 2013-02-10 (+171d) |  |  | 81.5d → -57.75d |  | resources SSH-Construction Manhours [2400 h] → SSH-Construction Manhours [476.91 h] |
| 1.4.2.4.3.710 | Leveling -compaction of box culvertB | 2012-08-23 → 2013-02-11 (+172d) | 2012-08-30 → 2013-02-17 (+171d) |  |  | 81.5d → -57.75d |  | resources SSH-Construction Manhours [2400 h] → SSH-Construction Manhours [262.3 h] |
| 4 | **Zone 4** | 2012-06-09 → 2012-12-10 (+184d) | 2012-10-20 → 2013-05-23 (+215d) |  |  |  |  |  |
| 1 | **Storm Drainage Ditches** | 2012-06-10 → 2012-12-10 (+183d) | 2012-08-29 → 2013-04-14 (+228d) |  |  |  |  |  |
| 1.4.2.4.4.110A | Excavation for storm water drainage ditch-A(1200LM) | 2012-06-10 → 2012-12-10 (+183d) | 2012-06-18 → 2012-12-18 (+183d) |  |  | 80d → -156.25d | 1.4.2.4.1.010 FS+37.5d → 1.4.2.4.3.610, M2.06 | resources SSH-Construction Manhours [4000 h] → SSH-Construction Manhours [437.17 h] |
| 1.4.2.4.4.110B | Leveling -compaction of drainage ditch-A | 2012-06-19 → 2012-12-19 (+183d) | 2012-06-30 → 2012-12-30 (+183d) |  |  | 117.5d → -113.75d |  | resources SSH-Construction Manhours [15000 h] → SSH-Construction Manhours [1640.05 h] |
| 1.4.2.4.4.110C | Construction of concrete drainage ditch-A | 2012-07-01 → 2012-12-31 (+183d) | 2012-07-23 → 2013-02-10 (+202d) | 25d → 45d |  | 117.5d → -113.75d |  | resources SSH-Construction Manhours [14000 h] → SSH-Construction Manhours [1530.36 h] |
| 1.4.2.4.4.120A | Excavation for storm water drainage ditch-B(1200LM) | 2012-07-24 → 2013-02-11 (+202d) | 2012-08-01 → 2013-02-19 (+202d) |  |  | 117.5d → -113.75d |  | resources SSH-Construction Manhours [4000 h] → SSH-Construction Manhours [437.17 h] |
| 1.4.2.4.4.120B | Leveling -compaction of drainage ditch-B | 2012-08-02 → 2013-02-20 (+202d) | 2012-08-13 → 2013-03-03 (+202d) |  |  | 117.5d → -113.75d |  | resources SSH-Construction Manhours [5000 h] → SSH-Construction Manhours [546.86 h] |
| 1.4.2.4.4.120C | Construction of concrete drainage ditch-B | 2012-08-14 → 2013-03-04 (+202d) | 2012-08-29 → 2013-04-14 (+228d) | 17.5d → 45d |  | 117.5d → -113.75d |  | resources SSH-Construction Manhours [8400 h] → SSH-Construction Manhours [918.32 h] |
| 2 | **Storm Drainage Ponds** | 2012-06-14 → 2012-12-15 (+184d) | 2012-10-03 → 2013-05-23 (+232d) |  |  |  |  |  |
| 1.4.2.4.4.010 | Excavation for storm water drainage pond(1) | 2012-06-14 → 2012-12-15 (+184d) | 2012-06-20 → 2013-01-01 (+195d) | 7.5d → 20d |  | 80d → -156.25d |  | resources SSH-Construction Manhours [4200 h] → SSH-Construction Manhours [458.9 h] |
| 1.4.2.4.4.015 | Leveling - compactionfor drainage pond | 2012-06-21 → 2013-01-02 (+195d) | 2012-07-04 → 2013-01-15 (+195d) |  |  | 80d → -156.25d |  | resources SSH-Construction Manhours [24000 h] → SSH-Construction Manhours [2623.56 h] |
| 1.4.2.4.4.020 | Construction of RC spillways | 2012-07-05 → 2013-01-16 (+195d) | 2012-07-28 → 2013-02-07 (+194d) |  |  | 80d → -156.25d |  | resources SSH-Construction Manhours [21568.1 h] → SSH-Construction Manhours [2358.08 h] |
| 1.4.2.4.4.040 | Marl caping for drainage pond | 2012-07-29 → 2013-02-09 (+195d) | 2012-08-08 → 2013-02-19 (+195d) |  |  | 80d → -156.25d |  | resources SSH-Construction Manhours [10000 h] → SSH-Construction Manhours [1093.19 h] |
| 1.4.2.4.4.050 | Excavation for storm water drainage pond(2) | 2012-08-09 → 2013-02-20 (+195d) | 2012-08-15 → 2013-05-14 (+272d) | 7.5d → 90d |  | 80d → -156.25d |  | resources SSH-Construction Manhours [2400 h] → SSH-Construction Manhours [476.91 h] |
| 1.4.2.4.4.060 | Leveling - compactionfor drainage pond | 2012-08-16 → 2013-03-11 (+207d) | 2012-08-29 → 2013-03-24 (+207d) |  |  | 80d → -156.25d | 1.4.2.4.4.050 → 1.4.2.4.4.050 SS+20d | resources SSH-Construction Manhours [2400 h] → SSH-Construction Manhours [262.3 h] |
| 1.4.2.4.4.070 | Construction of RC spillways | 2012-08-30 → 2013-03-25 (+207d) | 2012-09-22 → 2013-04-30 (+220d) | 25d → 40d |  | 80d → -156.25d |  | resources SSH-Construction Manhours [8500 h] → SSH-Construction Manhours [929.45 h] |
| 1.4.2.4.4.080 | Marl caping for drainage pond | 2012-09-23 → 2013-05-01 (+220d) | 2012-10-03 → 2013-05-23 (+232d) | 12.5d → 25d |  | 80d → -156.25d |  | resources SSH-Construction Manhours [2400 h] → SSH-Construction Manhours [263.89 h] |
| 4 | **Road Networks** | 2011-03-19 → 2011-01-28 (-50d) | 2012-12-17 → 2013-04-29 (+133d) |  |  |  |  |  |
| 1 | **Fencing System & Gates** | 2011-03-19 → 2011-01-28 (-50d) | 2011-07-23 → 2012-10-04 (+439d) |  |  |  |  |  |
| 1.4.1.3.1.010 | Install temp gate & jersey barriers for zone1 | 2011-03-19 → 2011-01-31 A (-47d) | 2011-04-09 → 2011-02-20 A (-48d) |  | 0% → 100% | 37.5d → none | 1.3.1.9.030 SS, 1.4.1.1.160, 1.3.1.10.030, 1.3.1.14.020 SS → 1.3.1.9.030 SS, 1.4.1.1.160, 1.3.1.10.030, 1.3.1.14.020 SS, 1.4.1.1.110 SS+5d | resources SSH-Construction Manhours [57000 h]; Crane [190 h]; Trailer [190 h]; Fork-Lifter [190 h] → SSH-Construction Manhours [4335.76 h]; Truck Crane [190 ea]; Trailer [190 h]; Fork-Lifter [190 h] |
| 1.4.1.3.3.010 | Install temp gate & jersey barriers for zone3 | 2011-04-10 → 2011-02-28 A (-41d) | 2011-06-08 → 2012-01-26 A (+232d) | 65d → 50d | 0% → 100% | 37.5d → none | 1.4.1.3.1.010 → 1.4.1.3.2.010 SS | resources SSH-Construction Manhours [312000 h]; Crane [520 h]; Trailer [520 h]; Fork-Lifter [520 h] → SSH-Construction Manhours [9182.3 h]; Truck Crane [520 ea]; Trailer [520 h]; Fork-Lifter [520 h] |
| 1.4.1.3.2.010 | Install temp gate & jersey barriers for zone2 | 2011-05-26 A | 2011-07-23 → 2011-08-03 A (+11d) | 62.5d → 75d | 0% → 100% | 50d → none | 1.4.1.3.3.010 SS+50d → 1.4.1.3.1.010 SS | resources SSH-Construction Manhours [360000 h]; Crane [600 h]; Trailer [600 h]; Fork-Lifter [600 h] → SSH-Construction Manhours [10839.8 h]; Truck Crane [600 ea]; Trailer [600 h]; Fork-Lifter [600 h] |
| 1.4.1.3.4.010 | Install temp gate & jersey barriers for zone4 | 2011-06-13 A | 2011-07-23 → 2012-10-04 (+439d) |  | 0% → 98% | 93.75d → -99.5d | 1.4.1.3.2.010 SS+18.75d → 1.4.1.3.2.010 FF, 1.4.1.3.1.005 FF | resources SSH-Construction Manhours [157500 h]; Crane [300 h]; Trailer [300 h]; Fork-Lifter [300 h] → SSH-Construction Manhours [4718.48 h]; Truck Crane [300 ea]; Trailer [300 h]; Fork-Lifter [300 h] |

| ID | Task | Start | Finish | Duration | Complete | Total float | Predecessors | Other |
| --- | --- | --- | --- | --- | --- | --- | --- | --- |
| 2 | **Patrol Road works** |  | 2011-10-18 → 2012-10-16 (+364d) |  |  |  |  |  |
| 1.4.2.5.2.010 | Install 200mm thk compacted Patrol Roads for Zone 1 | 2011-07-06 A | 2011-08-03 → 2012-10-08 (+432d) |  | 0% → 84% | 112.5d → -122.06d |  | resources SSH-Construction Manhours [125000 h]; Grader [250 h]; Compactor [250 h] → SSH-Construction Manhours [1179.99 h]; Grader [250 h]; Compactor [250 h] |
| 1.4.2.5.2.030 | Install 200mm thk compacted Patrol Roads for Zone 3 | 2011-07-14 A | 2011-09-04 A |  | 0% → 100% | 122.5d → none | 1.4.1.3.3.010 FS+37.5d → 1.4.1.3.3.010 SS, 1.3.2.19.030 SS, 1.3.2.21.030 SS | resources SSH-Construction Manhours [315000 h]; Grader [450 h]; Compactor [450 h] → SSH-Construction Manhours [7652.17 h]; Grader [450 h]; Compactor [450 h] |
| 1.4.2.5.2.020 | Install 200mm thk compacted Patrol Roads for Zone 2 | 2011-08-28 A | 2011-10-18 A |  | 0% → 100% | 50d → none | 1.4.1.3.2.010 FS+37.5d → 1.4.1.3.2.010 SS | resources SSH-Construction Manhours [247500 h]; Grader [450 h]; Compactor [450 h] → SSH-Construction Manhours [6376.68 h]; Grader [450 h]; Compactor [450 h] |
| 1.4.2.5.2.040 | Install 200mm thk compacted Patrol Roads for Zone 4 | 2011-09-14 A | 2011-10-06 → 2012-10-16 (+376d) |  | 0% → 48% | 93.75d → -172.25d | 1.4.1.3.4.010 FS+56.25d → 1.4.2.5.2.020 SS | resources SSH-Construction Manhours [60000 h]; Grader [200 h]; Compactor [200 h] → SSH-Construction Manhours [1402.81 h]; Grader [200 h]; Compactor [200 h] |
| 3 | **Asphalt Road Works A/B/C/D** |  | 2012-12-17 → 2013-04-29 (+133d) |  |  |  |  |  |
| 1.4.2.5.3.010 | Site grading/clearing/grubbing | 2012-04-05 A | 2012-05-09 A |  | 0% → 100% | 0d → none | 1.4.2.7.3.050 SS, 1.3.1.6.030 → 1.4.2.5.2.040 SS | resources SSH-Construction Manhours [45000 h]; Grader [600 h]; Dump Truck [600 h] → SSH-Construction Manhours [2168.25 h]; Grader [600 h]; Dump Truck [600 h] |
| 1.4.2.5.3.020 | Cut/fill of existing grade | 2012-04-29 A | 2012-06-19 → 2012-10-07 (+110d) |  | 0% → 95% | 75d → -148.81d | 1.4.2.5.3.010 SS+25d → 1.4.2.5.3.010 FF+10d, 1.4.2.5.3.010 SS | resources SSH-Construction Manhours [45000 h]; Grader [600 h]; Dump Truck [600 h] → SSH-Construction Manhours [5873.3 h]; Grader [600 h]; Dump Truck [600 h] |
| 1.4.2.5.3.040 | Laying of geogrid | 2012-04-29 → 2012-05-09 A (+10d) | 2012-07-07 → 2012-11-28 (+144d) |  | 0% → 21% | 0d → -200.42d | 1.4.2.5.3.010 SS+25d, 1.3.1.6.030 → 1.4.2.5.3.010 FF+150d, 1.3.1.3.030, 1.4.2.5.3.020 FF+5d | resources SSH-Construction Manhours [60000 h] → SSH-Construction Manhours [2208.22 h] |
| 1.4.2.5.3.050 | backfill with aggregate crushed stone | 2012-06-03 → 2012-10-08 (+127d) | 2012-08-11 → 2012-12-17 (+128d) |  |  | 0d → -129.92d | 1.4.2.5.3.040 SS+37.5d → 1.4.2.5.3.040 FF+20d | resources SSH-Construction Manhours [60000 h]; Dump Truck [600 h]; Grader [600 h]; Compactor [600 h] → SSH-Construction Manhours [11745.9 h]; Dump Truck [600 h]; Grader [600 h]; Compactor [600 h] |
| 1.4.2.5.3.060 | laying of Alyaf geotextile | 2012-07-08 → 2012-10-27 (+111d) | 2012-09-15 → 2013-01-05 (+112d) |  |  | 0d → -129.92d | 1.4.2.5.3.050 SS+37.5d → 1.4.2.5.3.050 FF+20d | was named Supp & laying of Alyaf geotextile; resources SSH-Construction Manhours [60000 h] → SSH-Construction Manhours [1174.81 h] |
| 1.4.2.5.3.070 | lay aggregate base course typeA | 2012-08-06 → 2012-11-14 (+100d) | 2012-10-14 → 2013-01-23 (+101d) |  |  | 0d → -129.92d | 1.4.2.5.3.060 SS+31.25d, 1.4.2.7.2.090 SS, 1.4.2.5.3.020 SS+31.25d, 1.3.1.16.020 → 1.4.2.5.3.060 FF+20d, 1.3.1.16.020 SS | was named Supp & lay aggregate base course typeA; resources SSH-Construction Manhours [60000 h]; Grader [600 h]; Dump Truck [600 h]; Compactor [600 h] → SSH-Construction Manhours [5852.57 h]; Grader [600 h]; Dump Truck [600 h]; Compactor [600 h] |
| 1.4.2.5.3.080 | Install MC70 asphalt prime coat | 2012-09-04 → 2012-12-13 (+100d) | 2012-11-12 → 2013-02-21 (+101d) |  |  | 0d → -129.92d |  | resources SSH-Construction Manhours [120000 h]; Asphalt Machine [600 h] → SSH-Construction Manhours [644.77 h]; Asphalt Machine [600 h] |
| 1.4.2.5.3.090 | Install asphalt concret binder class A | 2012-09-04 → 2012-12-13 (+100d) | 2012-11-12 → 2013-02-21 (+101d) |  |  | 0d → -129.92d |  | resources SSH-Construction Manhours [120000 h]; Asphalt Machine [600 h] → SSH-Construction Manhours [2232.65 h]; Asphalt Machine [600 h] |
| 1.4.2.5.3.100 | Install RC 250 asphalt tack coat | 2012-10-03 → 2013-01-12 (+101d) | 2012-11-24 → 2013-03-23 (+119d) | 56.25d → 75d |  | 0d → -129.92d |  | resources SSH-Construction Manhours [90000 h]; Asphalt Machine [450 h] → SSH-Construction Manhours [13850.4 h]; Asphalt Machine [450 h] |
| 1.4.2.5.3.110 | Install asphalt concrt wear course class B | 2012-11-01 → 2013-02-18 (+109d) | 2012-12-17 → 2013-04-29 (+133d) | 50d → 75d |  | 0d → -129.92d | 1.4.2.5.3.100 SS+31.25d → 1.4.2.5.3.100 FF+40d | resources SSH-Construction Manhours [80000 h]; Asphalt Machine [400 h] → SSH-Construction Manhours [13117.6 h]; Asphalt Machine [400 h] |
| 1.4.2.5.4.010 | Install curb & gutter Zone3 - A3-1 | 2012-05-10 → 2012-11-14 (+188d) | 2012-07-01 → 2013-01-09 (+192d) | 56.25d → 60d |  | 6.25d → -117.42d | 1.4.2.5.3.010 SS+37.5d, 1.3.1.7.030 → 1.4.2.5.3.070 SS, 1.3.1.6.030 | was named Install curb & gutter & walkways Zone3 - A3-1; resources SSH-Construction Manhours [22500 h] → SSH-Construction Manhours [1850.67 h] |
| 1.4.2.5.4.020 | Install curb & gutter Zone3 - A3-2 | 2012-07-02 → 2012-12-08 (+159d) | 2012-08-16 → 2013-02-02 (+170d) | 50d → 60d |  | 6.25d → -117.42d | 1.4.2.5.4.010 → 1.4.2.5.4.010 FF+25d | was named Install curb & gutter & walkways Zone3 - A3-2; resources SSH-Construction Manhours [20000 h] → SSH-Construction Manhours [1850.67 h] |
| 1.4.2.5.4.030 | Install curb & gutter Zone3 - A3-3 | 2012-08-18 → 2012-12-31 (+135d) | 2012-10-08 → 2013-02-25 (+140d) | 56.25d → 60d |  | 6.25d → -117.42d | 1.4.2.5.4.020 → 1.4.2.5.4.020 FF+25d | was named Install curb & gutter & walkways Zone3 - A3-3; resources SSH-Construction Manhours [22500 h] → SSH-Construction Manhours [1850.67 h] |
| 1.4.2.5.4.040 | Install curb & gutter Zone2 - A2-1 | 2012-10-09 → 2013-01-23 (+106d) | 2012-11-06 → 2013-03-20 (+134d) | 31.25d → 60d |  | 6.25d → -117.42d | 1.4.2.5.4.030 → 1.4.2.5.4.030 FF+25d | was named Install curb & gutter & walkways Zone2 - A2-1; resources SSH-Construction Manhours [15000 h] → SSH-Construction Manhours [675.87 h] |
| 1.4.2.5.4.050 | Install curb & gutter Zone2 - A2-2 | 2012-11-07 → 2013-02-20 (+105d) | 2012-12-11 → 2013-04-17 (+127d) | 37.5d → 60d |  | 6.25d → -117.42d | 1.4.2.5.4.040 → 1.4.2.5.4.040 FF+30d | was named Install curb & gutter & walkways Zone2 - A2-2; resources SSH-Construction Manhours [75000 h] → SSH-Construction Manhours [1850.67 h] |
| 5 | **Traffic Signage** | 2012-09-04 → 2012-12-23 (+110d) | 2012-12-11 → 2013-04-07 (+117d) |  |  |  |  |  |
| 1.4.2.5.6.010A | Install road markings Zone 3 - A3-1 | 2012-09-04 → 2012-12-23 (+110d) | 2012-09-20 → 2013-01-20 (+122d) | 18.75d → 30d |  | 6.25d → -106.67d | 1.4.2.5.3.090 SS, 1.3.1.17.020 → 1.4.2.5.3.090 SS+10d, 1.3.1.17.020 | resources SSH-Construction Manhours [12000 h] → SSH-Construction Manhours [421.95 h] |
| 1.4.2.5.6.010B | Install road markings Zone 3 - A3-2 | 2012-09-22 → 2013-01-06 (+106d) | 2012-10-14 → 2013-02-03 (+112d) | 25d → 30d |  | 12.5d → -88.17d | 1.4.2.5.6.010A → 1.4.2.5.6.010A FF+15d | resources SSH-Construction Manhours [16000 h] → SSH-Construction Manhours [421.95 h] |
| 1.4.2.5.6.020A | Install road signage with GI pipe post Zone3 - A3-1 | 2012-09-22 → 2013-01-13 (+113d) | 2012-10-11 → 2013-02-10 (+122d) | 22.5d → 30d |  | 6.25d → -106.67d | 1.4.2.5.6.010A → 1.4.2.5.6.010A FF+23d | resources SSH-Construction Manhours [18000 h] → SSH-Construction Manhours [96.24 h] |
| 1.4.2.5.6.010C | Install road markings Zone 3 - A3-3 | 2012-10-15 → 2013-01-24 (+101d) | 2012-11-12 → 2013-02-21 (+101d) | 31.25d → 30d |  | 12.5d → -88.17d | 1.4.2.5.6.010B → 1.4.2.5.6.010B FF+20d | resources SSH-Construction Manhours [20000 h] → SSH-Construction Manhours [421.95 h] |
| 1.4.2.5.6.020B | Install road signage with GI pipe post Zone3 - A3-2 | 2012-10-13 → 2013-01-31 (+110d) | 2012-11-04 → 2013-02-28 (+116d) | 25d → 30d |  | 6.25d → -106.67d | 1.4.2.5.6.020A → 1.4.2.5.6.020A FF+20d | resources SSH-Construction Manhours [12000 h] → SSH-Construction Manhours [96.24 h] |
| 1.4.2.5.6.020C | Install road signage with GI pipe post Zone3 - A3-3 | 2012-11-05 → 2013-02-19 (+106d) | 2012-12-03 → 2013-03-19 (+106d) | 31.25d → 30d |  | 6.25d → -106.67d | 1.4.2.5.6.020B → 1.4.2.5.6.020B FF+20d | resources SSH-Construction Manhours [37500 h] → SSH-Construction Manhours [96.24 h] |
| 1.4.2.5.6.010D | Install road markings Zone 2 | 2012-11-13 → 2013-02-21 (+100d) | 2012-12-05 → 2013-03-21 (+106d) | 25d → 30d |  | 12.5d → -88.17d |  | resources SSH-Construction Manhours [70000 h] → SSH-Construction Manhours [421.95 h] |
| 1.4.2.5.6.020D | Install road signage with GI pipe post Zone2 | 2012-11-25 → 2013-03-10 (+105d) | 2012-12-11 → 2013-04-07 (+117d) | 18.75d → 30d |  | 6.25d → -106.67d | 1.4.2.5.6.020C SS+21.25d → 1.4.2.5.6.020C FF+20d | resources SSH-Construction Manhours [60000 h] → SSH-Construction Manhours [96.24 h] |
| 1.4.2.6.1.010 | Site grading/clearing/grubbing | 2012-04-05 → 2011-12-05 A (-122d) | 2012-06-13 → 2011-12-28 A (-168d) | 75d → 20d | 0% → 100% | 10d → none | 1.4.2.5.3.010 SS, 1.3.3.13.030 → 1.4.2.5.2.040 SS | resources SSH-Construction Manhours [30000 h]; Grader [600 h]; Dump Truck [600 h] → SSH-Construction Manhours [740.62 h]; Grader [600 h]; Dump Truck [600 h] |
| 6 | **Power Distribution** |  | 2012-10-13 → 2013-06-15 (+245d) |  |  |  |  |  |
| 01 | **MV Cables** | 2011-12-06 → 2011-12-03 (-3d) | 2012-05-17 → 2013-01-30 (+258d) |  |  |  |  |  |
| 1.4.2.7.1.010 | Excavation of trench for Ductbanks | 2011-12-06 → 2011-12-28 A (+22d) | 2012-01-04 → 2012-04-02 A (+89d) | 31.25d → 90d | 0% → 100% | 37.75d → none | 1.3.2.16.030, 1.3.2.3.030, Z3.2180 SS, 1.3.3.12.030 → Z3.2180 SS | was named Excavation of trench for MV cables & Ductbanks; resources SSH-Construction Manhours [17500 h]; Excavator [250 h]; Dump Truck [250 h] → SSH-Construction Manhours [4281.07 h]; Excavator [250 h]; Dump Truck [250 h] |
| 1.4.2.7.1.050 | Construction of ductbanks | 2012-04-12 → 2012-01-17 A (-86d) | 2012-05-17 → 2012-04-09 A (-38d) | 37.5d → 90d | 0% → 100% | 42.75d → none | 1.4.2.7.1.070, 1.4.2.7.510 → 1.4.2.7.1.010 FF+10d, 1.3.2.18.030 SS | was named Install red tiles/cable markers; resources SSH-Construction Manhours [24000 h] → SSH-Construction Manhours [3011.51 h] |
| 1.4.2.7.1.060 | Splice/hi-pot/termintaion of MV cables | 2012-02-26 → 2012-06-04 A (+99d) | 2012-03-20 → 2012-11-06 (+231d) |  | 0% → 75% | 37.75d → -15.05d |  | was named Splic/hi-pot/termintaion of MV cables; resources SSH-Construction Manhours [12000.7 h] → SSH-Construction Manhours [1505.75 h] |
| 1.4.2.7.1.080 | Backfilling of MV cables | 2012-04-12 → 2012-10-04 (+175d) | 2012-05-17 → 2012-12-26 (+223d) | 37.5d → 90d |  | 42.75d → -75d | 1.4.2.7.1.050 SS → 1.4.2.7.1.050 FF+35d | resources SSH-Construction Manhours [18000 h]; Dump Truck [300 h] → SSH-Construction Manhours [2258.63 h]; Dump Truck [300 h] |
| 1.4.2.7.1.070 | Testing & Pre-commissioning of MV cables | 2012-03-20 → 2013-01-08 (+294d) | 2012-04-12 → 2013-01-30 (+293d) |  |  | 37.75d → -97.5d | 1.4.2.7.1.060, 1.4.2.7.1.130, 1.4.2.7.230, 1.4.2.7.330, 1.4.2.7.510 → 1.4.2.7.1.060 FF+10d, 1.4.2.7.1.130, 1.4.2.7.230, 1.4.2.7.330, 1.4.2.7.510, 1.4.2.7.1.080 FF+15d | resources SSH-Construction Manhours [10000 h] → SSH-Construction Manhours [1254.8 h] |
| 2 | **Zone 3 - A3-1 & 4** | 2011-12-06 → 2012-10-04 (+303d) | 2012-01-19 → 2013-01-07 (+354d) |  |  |  |  |  |
| 1.4.2.7.1.100 | Excavation of MV cable trench | 2011-12-06 → 2012-10-04 (+303d) | 2011-12-15 → 2012-10-13 (+303d) |  |  | 102.75d → -97.5d | 1.4.2.7.1.010 SS → Z3.1020 SS | resources SSH-Construction Manhours [3000 h]; Excavator [80 h]; Dump Truck [80 h] → SSH-Construction Manhours [3739.78 h]; Excavator [80 h]; Dump Truck [80 h] |
| 1.4.2.7.1.110 | Install MV cable A | 2011-12-15 → 2012-10-04 (+294d) | 2011-12-27 → 2012-10-15 (+293d) |  |  | 102.75d → -97.5d | 1.4.2.7.1.010 SS, 1.4.2.7.1.100 → 1.4.2.7.1.100 SS, 1.3.2.5.030 SS | resources SSH-Construction Manhours [15000 h]; Cable Puller [100 h] → SSH-Construction Manhours [1882.69 h]; Cable Puller [100 h] |
| 1.4.2.7.1.120 | Install MV cable B | 2011-12-27 → 2012-10-16 (+294d) | 2012-01-08 → 2012-11-26 (+323d) | 12.5d → 45d |  | 102.75d → -97.5d |  | resources SSH-Construction Manhours [15000 h]; Cable Puller [100 h] → SSH-Construction Manhours [1882.69 h]; Cable Puller [100 h] |
| 1.4.2.7.1.130 | Install MV cable C | 2012-01-08 → 2012-11-27 (+324d) | 2012-01-19 → 2013-01-07 (+354d) | 12.5d → 45d |  | 102.75d → -97.5d |  | resources SSH-Construction Manhours [15000 h]; Cable Puller [100 h] → SSH-Construction Manhours [1882.69 h]; Cable Puller [100 h] |
| 3 | **Zone 3 - A3-2** |  | 2012-01-29 → 2012-10-30 (+275d) |  |  |  |  |  |
| 1.4.2.7.200 | Excavation of MV cable trench | 2011-12-15 A | 2011-12-25 A |  | 0% → 100% | 92.75d → none | 1.4.2.7.1.010 SS+10d → 1.4.2.7.1.110 SS | resources SSH-Construction Manhours [3000 h]; Excavator [80 h]; Dump Truck [80 h] → SSH-Construction Manhours [3149.29 h]; Excavator [80 h]; Dump Truck [80 h] |
| 1.4.2.7.210 | Install MV cable A | 2011-12-25 → 2012-02-23 A (+60d) | 2012-01-05 → 2012-10-13 (+282d) | 12.5d → 30d | 0% → 69% | 92.75d → -22.9d |  | resources SSH-Construction Manhours [15000 h]; Cable Puller [100 h] → SSH-Construction Manhours [1882.69 h]; Cable Puller [100 h] |
| 1.4.2.7.220 | Install MV cable B | 2012-01-05 → 2012-03-22 A (+77d) | 2012-01-17 → 2012-10-21 (+278d) | 12.5d → 30d | 0% → 69% | 92.75d → -22.9d |  | resources SSH-Construction Manhours [15000 h]; Cable Puller [100 h] → SSH-Construction Manhours [1882.69 h]; Cable Puller [100 h] |
| 1.4.2.7.230 | Install MV cable C | 2012-01-17 → 2012-04-19 A (+93d) | 2012-01-29 → 2012-10-30 (+275d) | 12.5d → 30d | 0% → 69% | 92.75d → -22.9d |  | resources SSH-Construction Manhours [15000 h]; Cable Puller [100 h] → SSH-Construction Manhours [1882.69 h]; Cable Puller [100 h] |
| 4 | **Zone 3 - A3-3** | 2011-12-18 → 2012-02-18 (+62d) | 2012-01-31 → 2012-10-30 (+273d) |  |  |  |  |  |
| 1.4.2.7.300 | Excavation of MV cable trench | 2011-12-18 → 2012-02-18 A (+62d) | 2011-12-27 → 2012-03-11 A (+75d) | 10d → 25d | 0% → 100% | 90.25d → none |  | resources SSH-Construction Manhours [3000 h]; Excavator [80 h]; Dump Truck [80 h] → SSH-Construction Manhours [2755.63 h]; Excavator [80 h]; Dump Truck [80 h] |
| 1.4.2.7.310 | Install MV cable A | 2011-12-27 → 2012-03-12 A (+76d) | 2012-01-08 → 2012-10-13 (+279d) | 12.5d → 30d | 0% → 69% | 90.25d → -22.9d |  | resources SSH-Construction Manhours [15000 h]; Cable Puller [100 h] → SSH-Construction Manhours [1882.69 h]; Cable Puller [100 h] |
| 1.4.2.7.320 | Install MV cable B | 2012-01-08 → 2012-04-09 A (+92d) | 2012-01-19 → 2012-10-21 (+276d) | 12.5d → 30d | 0% → 69% | 90.25d → -22.9d |  | resources SSH-Construction Manhours [15000 h]; Cable Puller [100 h] → SSH-Construction Manhours [1882.69 h]; Cable Puller [100 h] |
| 1.4.2.7.330 | Install MV cable C | 2012-01-19 → 2012-05-07 A (+109d) | 2012-01-31 → 2012-10-30 (+273d) | 12.5d → 30d | 0% → 69% | 90.25d → -22.9d |  | resources SSH-Construction Manhours [15000 h]; Cable Puller [100 h] → SSH-Construction Manhours [1882.69 h]; Cable Puller [100 h] |
| 5 | **Zone 3 - A3-4** | 2011-12-20 → 2012-02-18 (+60d) | 2012-01-08 → 2012-10-22 (+288d) |  |  |  |  |  |
| 1.4.2.7.400 | Excavation of MV cable trench | 2011-12-20 → 2012-02-18 A (+60d) | 2011-12-25 → 2012-03-11 A (+77d) | 5d → 25d | 0% → 100% | 82.75d → none |  | resources SSH-Construction Manhours [3000 h]; Excavator [40 h]; Dump Truck [40 h] → SSH-Construction Manhours [2558.8 h]; Excavator [40 h]; Dump Truck [40 h] |
| 1.4.2.7.410 | Install MV cable A | 2011-12-25 → 2012-03-12 A (+78d) | 2012-01-01 → 2012-10-13 (+286d) | 7.5d → 30d | 0% → 68% | 82.75d → -23.8d |  | resources SSH-Construction Manhours [25000 h]; Cable Puller [60 h] → SSH-Construction Manhours [3137.48 h]; Cable Puller [60 h] |
| 1.4.2.7.420 | Install MV cable B | 2012-01-01 → 2012-04-09 A (+99d) | 2012-01-08 → 2012-10-22 (+288d) | 7.5d → 30d | 0% → 68% | 82.75d → -23.8d |  | resources SSH-Construction Manhours [25000 h]; Cable Puller [60 h] → SSH-Construction Manhours [3137.48 h]; Cable Puller [60 h] |
| 6 | **Zone 3 - A3-5** | 2012-02-14 → 2012-03-07 (+22d) | 2012-02-26 → 2012-10-31 (+248d) |  |  |  |  |  |
| 1.4.2.7.500 | Excavation of MV cable trench | 2012-02-14 → 2012-03-07 A (+22d) | 2012-02-19 → 2012-03-29 A (+39d) | 5d → 25d | 0% → 100% | 37.75d → none |  | resources SSH-Construction Manhours [2000 h]; Excavator [40 h]; Dump Truck [40 h] → SSH-Construction Manhours [1771.48 h]; Excavator [40 h]; Dump Truck [40 h] |
| 1.4.2.7.510 | Install MV cable A | 2012-02-19 → 2012-05-07 A (+78d) | 2012-02-26 → 2012-10-31 (+248d) | 7.5d → 30d | 0% → 68% | 37.75d → -23.8d |  | resources SSH-Construction Manhours [15000 h]; Cable Puller [60 h] → SSH-Construction Manhours [1882.69 h]; Cable Puller [60 h] |
| 7 | **Zone 2 & 1** | none → 2011-12-03 | none → 2012-12-31 |  |  |  |  |  |
| 1.4.2.7.2.010 | Excavation of trench for lighting power cables | 2011-12-18 → 2012-05-23 A (+157d) | 2012-02-08 → 2013-01-23 (+350d) | 56.25d → 120d | 0% → 90% | 41.5d → -200.42d | 1.4.2.7.1.010 SS+12.5d → 1.4.2.5.3.040 FF+60d | resources SSH-Construction Manhours [11035.1 h]; Excavator [450 h]; Dump Truck [450 h] → SSH-Construction Manhours [1385.69 h]; Excavator [450 h]; Dump Truck [450 h] |
| 1.4.2.7.2.030 | Install lighting power cables (For lighting poles + CCTV Camera network) | 2012-02-23 → 2012-08-01 A (+160d) | 2012-05-02 → 2013-02-20 (+294d) |  | 0% → 10% | 25d → -142.42d | 1.4.2.7.2.010 SS+18.75d, 1.3.4.9.030 → 1.4.2.7.2.010 FF+30d, 1.3.2.24.030 | was named Install lighting power cables; resources SSH-Construction Manhours [60000 h]; Cable Puller [600 h] → SSH-Construction Manhours [7528.77 h]; Cable Puller [600 h] |
| 1.4.2.7.2.080 | Install lighting poles | 2012-06-07 → 2012-08-15 A (+69d) | 2012-08-15 → 2013-04-17 (+245d) | 75d → 120d | 0% → 1% | 25d → -142.42d | 1.4.2.7.2.070, 1.3.4.7.030, 1.3.4.8.030 → 1.3.2.20.030, 1.3.2.22.030, 1.4.2.7.2.070 FF+30d | resources SSH-Construction Manhours [50000 h]; Crane [600 h] → SSH-Construction Manhours [5289.83 h]; Truck Crane [600 ea] |
| 1.4.2.7.2.050 | Install red tiles/cable markers for lighting cables | 2012-04-16 → 2012-09-12 A (+149d) | 2012-05-20 → 2013-03-02 (+286d) | 37.5d → 40d | 0% → 50% | 25d → -142.42d | 1.4.2.7.2.030 SS+56.25d → 1.4.2.7.2.030 FF+10d | resources SSH-Construction Manhours [12000 h] → SSH-Construction Manhours [1505.75 h] |
| 1.4.2.7.2.070 | Testing & commissioning of lighting cables | 2012-05-03 → 2013-02-11 (+284d) | 2012-06-06 → 2013-03-20 (+287d) | 37.5d → 40d |  | 25d → -142.42d | 1.4.2.7.2.050 SS+18.75d → 1.4.2.7.2.050 FF+20d | resources SSH-Construction Manhours [12000 h] → SSH-Construction Manhours [1505.75 h] |
| 1.4.2.7.2.090 | Install lighting pole fixture | 2012-07-14 → 2013-02-20 (+221d) | 2012-09-20 → 2013-04-17 (+209d) | 75d → 60d |  | 25d → -127.42d | 1.4.2.7.2.080 SS+38.75d, 1.4.2.5.2.030 SS → 1.4.2.7.2.080 FF, 1.4.2.5.2.030 SS | resources SSH-Construction Manhours [36000 h] → SSH-Construction Manhours [3533.11 h] |
| 03 | **LV Cables (For Patrol Roads)** |  | 2011-12-10 → 2012-11-08 (+334d) |  |  |  |  |  |
| 1.4.2.7.2.110 | Install LV cables & Lightings in Zone1 | 2011-08-14 A | 2011-08-31 A |  | 0% → 100% | 101.5d → none | 1.3.4.4.030, 1.3.4.5.030, 1.3.4.6.030, 1.4.2.5.2.010 → 1.4.2.5.2.010 SS, 1.3.2.23.030 SS | resources SSH-Construction Manhours [60000 h]; Cable Puller [150 h] → SSH-Construction Manhours [7528.77 h]; Cable Puller [150 h] |
| 1.4.2.7.2.150 | Install LV cables & Lightings in Zone3 | 2011-09-05 A | 2011-10-03 → 2012-10-04 (+367d) |  | 0% → 98% | 122.5d → 23.29d | 1.4.2.5.2.030 → 1.4.2.7.2.110 SS | resources SSH-Construction Manhours [125000 h]; Cable Puller [250 h] → SSH-Construction Manhours [1907.29 h]; Cable Puller [250 h] |

| ID | Task | Start | Finish | Duration | Complete | Total float | Predecessors | Other |
| --- | --- | --- | --- | --- | --- | --- | --- | --- |
| 1.4.2.7.2.130 | Install LV cables & Lightings in Zone2 | 2011-10-19 A | 2011-11-16 → 2012-10-08 (+327d) |  | 0% → 87% | 50d → -122.06d | 1.4.2.5.2.020, 1.4.2.7.2.110 → 1.4.2.7.2.110 SS | resources SSH-Construction Manhours [125000 h]; Cable Puller [250 h] → SSH-Construction Manhours [15685.4 h]; Cable Puller [250 h] |
| 1.4.2.7.2.170 | Install LV cables & Lightings in Zone4 | 2011-11-17 → 2012-10-16 (+334d) | 2011-12-10 → 2012-11-08 (+334d) |  |  | 50d → -131d |  | resources SSH-Construction Manhours [60000 h]; Cable Puller [200 h] → SSH-Construction Manhours [7528.77 h]; Cable Puller [200 h] |
| 04 | **Irrigation Cables** | 2011-12-18 → 2013-01-12 (+391d) | 2012-05-29 → 2013-06-15 (+382d) |  |  |  |  |  |
| 1.4.2.7.3.010 | Excavation of trench for irrigation cables | 2011-12-18 → 2013-01-12 (+391d) | 2012-02-08 → 2013-03-05 (+391d) |  |  | 41.5d → -200.42d | 1.4.2.7.2.010 SS, 1.4.2.7.2.150, 1.4.2.7.2.170 → 1.4.2.7.2.010 SS, 1.4.2.7.2.170 | resources SSH-Construction Manhours [13500 h]; Excavator [450 h]; Dump Truck [450 h] → SSH-Construction Manhours [1693.73 h]; Excavator [450 h]; Dump Truck [450 h] |
| 1.4.2.7.3.030 | Install irrigation cables | 2011-12-29 → 2013-01-23 (+391d) | 2012-02-26 → 2013-03-23 (+391d) |  |  | 41.5d → -200.42d |  | resources SSH-Construction Manhours [36000 h]; Cable Puller [500 h] → SSH-Construction Manhours [4517.26 h]; Cable Puller [500 h] |
| 1.4.2.7.3.040 | Install solar powered irrigation controller | 2012-03-20 → 2013-03-23 (+368d) | 2012-05-29 → 2013-05-18 (+354d) | 75d → 60d |  | 141.5d → -200.42d | 1.4.2.7.3.050 SS+25d → 1.4.2.7.3.030 | resources SSH-Construction Manhours [72000 h] → SSH-Construction Manhours [9034.53 h] |
| 1.4.2.7.3.050 | Testing & commissioning of irrigation system | 2012-02-26 → 2013-05-16 (+445d) | 2012-03-26 → 2013-06-15 (+446d) |  |  | 41.5d → -200.42d | 1.4.2.7.3.030 → 1.4.2.7.3.030, 1.4.2.7.3.040 FF+30d | was named Testing & commissioning of irrigation cables; resources SSH-Construction Manhours [28800 h] → SSH-Construction Manhours [3613.81 h] |
| 1.4.2.7.4.030 | Construction of package substation foundations | 2011-11-23 → 2012-05-23 A (+182d) | 2012-03-13 → 2013-05-01 (+414d) |  | 0% → 3% | 116.75d → -160.42d | 1.4.3.1.1.040 → 1.4.2.7.2.010 SS | resources SSH-Construction Manhours [96000 h] → SSH-Construction Manhours [12046 h] |
| 1.4.2.7.4.050 | Install package substation zone3 | 2012-04-28 → 2013-03-16 (+322d) | 2012-05-05 → 2013-05-01 (+361d) | 7.5d → 50d |  | 37.75d → -160.42d | Install switchgear SS5 SS+5d, 1.3.2.3.020, Testing & commissioning of switchgears → 1.3.2.3.020, 1.4.2.7.4.030 FF | was named Install package substation SS5; resources SSH-Construction Manhours [4800 h] → SSH-Construction Manhours [602.3 h] |
| 1.4.2.7.4.040 | Install package substation zone2 | 2012-04-28 → 2013-04-03 (+340d) | 2012-05-05 → 2013-05-01 (+361d) | 7.5d → 30d |  | 38.25d → -160.42d | 1.3.2.3.020, 1.4.2.7.4.030 SS+90d, 1.3.2.2.030, Testing & commissioning of switchgears → 1.3.2.3.020, 1.4.2.7.4.030 FF, 1.3.2.3.030 | was named Install package substation SS4; resources SSH-Construction Manhours [4800 h] → SSH-Construction Manhours [602.3 h] |
| 1.4.2.7.4.045 | Testing & commissioning of package substation | 2012-05-05 → 2013-04-10 (+340d) | 2012-05-08 → 2013-05-08 (+365d) | 3.75d → 30d |  | 38.25d → -139.92d | 1.4.2.7.4.040 SS+7d → 1.4.2.7.4.040 FF+8d | was named Testing & commissioning of package substations; resources SSH-Construction Manhours [2000 h] → SSH-Construction Manhours [250.96 h] |
| 1.4.2.7.4.055 | Testing & commissioning of package substation | 2012-05-05 → 2013-04-10 (+340d) | 2012-05-08 → 2013-05-08 (+365d) | 3.75d → 30d |  | 37.75d → -139.92d | 1.4.2.7.4.050 → 1.4.2.7.4.050 FF+8d | was named Testing & commissioning of package substations; resources SSH-Construction Manhours [2000 h] → SSH-Construction Manhours [250.96 h] |
| 1.4.2.7.4.060 | Constrcution of RMU foundations | 2011-11-23 → 2012-05-23 A (+182d) | 2012-04-10 → 2013-04-04 (+359d) | 150d → 120d | 0% → 26% | 122.5d → -132.22d |  | resources SSH-Construction Manhours [120000 h] → SSH-Construction Manhours [15057.5 h] |
| 1.4.2.7.4.072 | Install RMU-zone3 | 2012-05-08 → 2013-02-07 (+275d) | 2012-05-26 → 2013-04-04 (+313d) | 18.75d → 60d |  | 37.75d → -132.22d | 1.4.2.7.4.050 SS, 1.4.2.7.4.070 SS, 1.3.2.4.020, 1.4.2.7.4.055 → 1.4.2.7.4.070 FF, 1.3.2.4.020 | was named Install RMU-SS5; resources SSH-Construction Manhours [10500 h] → SSH-Construction Manhours [1317.78 h] |
| 1.4.2.7.4.070 | Install RMU-zone2 | 2012-05-08 → 2013-02-17 (+285d) | 2012-05-26 → 2013-04-04 (+313d) | 18.75d → 50d |  | 38.25d → -132.22d | 1.4.2.7.4.040 SS, 1.3.2.4.020, 1.4.2.7.4.060 SS+60d, 1.3.2.5.030, 1.4.2.7.4.045 → 1.3.2.4.020 SS, 1.4.2.7.4.060 FF, 1.3.2.4.030 FF | was named Install RMU-SS4; resources SSH-Construction Manhours [10500 h] → SSH-Construction Manhours [1317.78 h] |
| 1.4.2.7.4.074 | Install RMU-zone4 | 2012-06-07 → 2013-03-07 (+273d) | 2012-08-29 → 2013-04-04 (+218d) | 90d → 30d |  | 195d → -104.22d | 1.4.2.7.2.070 → 1.4.2.7.4.072 FF | was named Install RMU-road lighting; resources SSH-Construction Manhours [22070.2 h] → SSH-Construction Manhours [2769.41 h] |
| 1.4.2.7.4.075 | Testing & commissioning of road lighting RMU | 2012-08-02 → 2013-03-16 (+226d) | 2012-09-12 → 2013-04-13 (+213d) | 45d → 30d |  | 195d → -112.22d | 1.4.2.7.4.074 SS+60d, 1.4.2.7.4.073 → 1.4.2.7.4.074 FF, 1.4.2.7.4.073 FF | resources SSH-Construction Manhours [18000 h] → SSH-Construction Manhours [2258.63 h] |
| 1.4.2.7.4.071 | Testing & commissioning of RMU | 2012-05-26 → 2013-03-20 (+298d) | 2012-05-31 → 2013-04-13 (+317d) | 6.25d → 25d |  | 38.25d → -112.22d | 1.4.2.7.4.070 → 1.4.2.7.4.070 FF+8d | was named Testing & commissioning of RMU-SS4; resources SSH-Construction Manhours [3000 h] → SSH-Construction Manhours [376.93 h] |
| 1.4.2.7.4.073 | Testing & commissioning of RMU | 2012-05-26 → 2013-03-25 (+303d) | 2012-05-31 → 2013-04-13 (+317d) | 6.25d → 20d |  | 37.75d → -112.22d | 1.4.2.7.4.072 SS+18.75d → 1.4.2.7.4.072 FF+8d, 1.4.2.7.4.071 FF | was named Testing & commissioning of RMU-SS5; resources SSH-Construction Manhours [3000 h] → SSH-Construction Manhours [376.93 h] |
| 4 | **Generators** | 2011-12-21 → 2012-06-20 (+182d) | 2012-09-09 → 2013-04-29 (+232d) |  |  |  |  |  |
| 1.4.2.7.4.090 | Construction of generator foundations | 2011-12-21 → 2012-06-20 A (+182d) | 2012-03-13 → 2013-04-02 (+385d) |  | 0% → 5% | 122.5d → -80.42d |  | resources SSH-Construction Manhours [72000 h] → SSH-Construction Manhours [9034.53 h] |
| 1.4.2.7.4.101 | Install generator LS10 | 2012-08-14 → 2013-01-26 (+165d) | 2012-08-27 → 2013-02-09 (+166d) |  |  | 37.5d → -95d | 1.4.2.7.4.090 SS, 1.3.2.6.020, Install ATS-Fire Alarm System -LS10 SS+10d → 1.4.2.7.4.090 SS, 1.3.2.6.020, 1.4.2.3.6.155 | resources SSH-Construction Manhours [7200 h] → SSH-Construction Manhours [1304.99 h] |
| 1.4.2.7.4.107 | Install generator LS9 | 2012-07-23 → 2013-03-05 (+225d) | 2012-08-06 → 2013-03-18 (+224d) |  |  | 56d → -142.5d | Install ATS-Fire Alarm System LS9 → 1.4.2.3.5.155 FF | resources SSH-Construction Manhours [7200 h] → SSH-Construction Manhours [1204.6 h] |
| 1.4.2.7.4.103 | Install generator LS11 | 2012-08-22 → 2013-03-26 (+216d) | 2012-09-04 → 2013-04-08 (+216d) |  |  | 30d → -161d | Install ATS-Fire Alarm System LS11 SS → 1.4.2.3.7.155 | resources SSH-Construction Manhours [7200 h] → SSH-Construction Manhours [1204.6 h] |
| 1.4.2.7.4.105 | Install generator LS12 | 2012-08-06 → 2013-04-16 (+253d) | 2012-08-19 → 2013-04-29 (+253d) |  |  | 35d → -202.5d | Install ATS-Fire Alarm System LS12 SS+7.5d, 1.3.2.6.030 → 1.3.2.6.030, 1.4.2.3.8.155 | resources SSH-Construction Manhours [7200 h] → SSH-Construction Manhours [1204.6 h] |
| 5 | **Submersible Pumps** | 2012-06-27 → 2013-01-30 (+217d) | 2012-10-13 → 2013-05-08 (+207d) |  |  |  |  |  |
| 1.4.2.7.4.120 | Install submersible pumps - LS pumps LS10 | 2012-07-07 → 2013-01-30 (+207d) | 2012-08-27 → 2013-02-09 (+166d) | 56.25d → 10d |  | 37.5d → -95d | 1.3.4.4.020, 1.3.4.8.020, 1.3.4.9.020, 1.4.2.3.6.150 → 1.3.4.4.020, 1.3.4.8.020, 1.3.4.9.020, 1.4.2.3.6.150, 1.4.2.7.4.101 FF | resources SSH-Construction Manhours [13500 h] → SSH-Construction Manhours [2948.52 h] |
| 1.4.2.7.4.126 | Install submersible pumps - LS pumps LS9 | 2012-06-27 → 2013-03-05 (+251d) | 2012-08-19 → 2013-03-13 (+206d) | 56.25d → 10d |  | 56d → -142.5d | 1.4.2.3.5.150 → 1.4.2.3.5.150 SS, 1.4.2.7.4.107 SS | resources SSH-Construction Manhours [18000 h] → SSH-Construction Manhours [3199.48 h] |
| 1.4.2.7.4.122 | Install submersible pumps - LS pumps LS11 | 2012-07-07 → 2013-04-03 (+270d) | 2012-08-27 → 2013-04-13 (+229d) | 56.25d → 10d |  | 30d → -161d | 1.4.2.3.7.150, 1.3.2.4.030 → 1.4.2.3.7.150, 1.3.4.4.030, 1.4.2.7.4.103 FF+4d | resources SSH-Construction Manhours [13500 h] → SSH-Construction Manhours [2634.58 h] |
| 1.4.2.7.4.124 | Install submersible pumps - LS pumps LS12 | 2012-07-30 → 2013-04-30 (+274d) | 2012-09-19 → 2013-05-08 (+231d) | 56.25d → 10d |  | 35d → -202.5d | 1.4.2.3.8.150 → 1.4.2.3.8.150, 1.4.2.7.4.105 | resources SSH-Construction Manhours [24000 h] → SSH-Construction Manhours [3952.36 h] |
| 06 | **Grounding Cables** | 2011-12-21 → 2012-02-18 (+59d) | 2012-05-30 → 2012-12-25 (+209d) |  |  |  |  |  |
| 1.4.2.7.5.010 | Excavation of trench for grounding cables | 2011-12-21 → 2012-02-18 A (+59d) | 2012-02-28 → 2012-10-17 (+232d) | 75d → 45d | 0% → 69% | 122.5d → -80.55d | Constrcution of transformer foundations SS → 1.4.3.2.1.110 SS+5d | resources SSH-Construction Manhours [36000 h] → SSH-Construction Manhours [4025.19 h] |
| 1.4.2.7.5.030 | Install grounding cables | 2012-02-12 → 2012-04-14 A (+62d) | 2012-04-03 → 2012-11-05 (+216d) | 56.25d → 35d | 0% → 64% | 122.5d → -80.55d | 1.3.2.15.030, 1.4.2.7.5.010 SS+56.25d → 1.3.2.15.030, 1.4.2.7.5.010 FF+20d | resources SSH-Construction Manhours [64800 h] → SSH-Construction Manhours [8131.08 h] |
| 1.4.2.7.5.020 | backfilling/compaction of grounding cable trench | 2012-04-26 → 2012-06-18 A (+53d) | 2012-05-30 → 2012-12-25 (+209d) | 37.5d → 20d | 0% → 7% | 122.5d → -80.55d |  | was named Supply/backfilling/compaction of grounding cable trench; resources SSH-Construction Manhours [18000 h] → SSH-Construction Manhours [2258.63 h] |
| 1.4.2.7.5.040 | Testing & commissioning of grounding cables | 2012-03-29 → 2012-11-10 (+226d) | 2012-04-26 → 2012-11-24 (+212d) | 31.25d → 15d |  | 122.5d → -80.55d | 1.4.2.7.5.030 SS+50d → 1.4.2.7.5.030 FF+20d | resources SSH-Construction Manhours [10000 h] → SSH-Construction Manhours [1254.8 h] |
| 7 | **Communication Works & Duct Banks** | 2012-01-15 → 2012-02-20 (+36d) | 2012-09-20 → 2013-01-07 (+109d) |  |  |  |  |  |
| 1 | **Communication works & Ductbanks** | 2012-01-15 → 2012-02-20 (+36d) | 2012-09-20 → 2013-01-07 (+109d) |  |  |  |  |  |
| 1.4.2.8.1.040 | Construction of comm concrete ductbanks | 2012-01-15 → 2012-02-20 A (+36d) | 2012-03-25 → 2012-11-07 (+227d) | 75d → 90d | 0% → 59% | 188d → 23.29d | 1.4.2.8.1.010 SS → 1.4.2.7.2.150 SS | resources SSH-Construction Manhours [90000 h] → SSH-Construction Manhours [13428.9 h] |
| 1.4.2.8.1.010 | Excavation of telecomm ductbanks & trench Zone3 -A3-1 | 2012-01-15 → 2012-02-21 A (+37d) | 2012-02-01 → 2012-10-04 (+246d) | 18.75d → 35d | 0% → 100% | 88d → -10.5d | 1.3.2.23.030, 1.4.2.7.1.010 SS → 1.4.2.8.1.012 FF+20d | resources SSH-Construction Manhours [10500 h]; Excavator [150 h]; Dump Truck [150 h] → SSH-Construction Manhours [1990.66 h]; Excavator [150 h]; Dump Truck [150 h] |
| 1.4.2.8.1.012 | Excavation of telecomm ductbanks & trench Zone3 -A3-3 | 2012-02-25 A | 2012-03-19 → 2012-03-28 A (+9d) | 25d → 35d | 0% → 100% | 88d → none | 1.4.2.8.1.011 → 1.4.2.7.200 SS | resources SSH-Construction Manhours [20000 h]; Excavator [200 h]; Dump Truck [200 h] → SSH-Construction Manhours [3791.88 h]; Excavator [200 h]; Dump Truck [200 h] |
| 1.4.2.8.1.011 | Excavation of telecomm ductbanks & trench Zone3 -A3-2 | 2012-02-01 → 2012-03-06 A (+34d) | 2012-02-25 → 2012-04-08 A (+43d) | 25d → 35d | 0% → 100% | 88d → none | 1.4.2.8.1.010 → 1.4.2.8.1.010 FF+15d | resources SSH-Construction Manhours [10000 h]; Dump Truck [200 h]; Excavator [200 h] → SSH-Construction Manhours [1895.94 h]; Dump Truck [200 h]; Excavator [200 h] |
| 1.4.2.8.1.013 | Excavation of telecomm ductbanks & trench Zone3 -A3-4 | 2012-03-19 → 2012-03-20 A (+1d) | 2012-03-31 → 2012-04-22 A (+22d) | 12.5d → 35d | 0% → 100% | 126.75d → none | 1.4.2.8.1.012 → 1.4.2.8.1.011 FF+15d | resources SSH-Construction Manhours [10000 h]; Dump Truck [100 h]; Excavator [100 h] → SSH-Construction Manhours [1895.94 h]; Dump Truck [100 h]; Excavator [100 h] |
| 1.4.2.8.1.014 | Excavation of telecomm ductbanks & trench Zone3 -A3-5 | 2012-03-31 → 2012-04-03 A (+3d) | 2012-04-11 → 2012-05-06 A (+25d) | 12.5d → 35d | 0% → 100% | 130.5d → none | 1.4.2.8.1.013 → 1.4.2.8.1.013 FF+15d | resources SSH-Construction Manhours [10000 h]; Excavator [100 h]; Dump Truck [100 h] → SSH-Construction Manhours [1895.94 h]; Excavator [100 h]; Dump Truck [100 h] |
| 1.4.2.8.1.021 | Install comm conduits & fittings-Zone 3 - A3-2 | 2012-02-25 → 2012-04-08 A (+43d) | 2012-03-21 → 2012-05-03 A (+43d) |  | 0% → 100% | 93d → none | 1.4.2.8.1.011 → 1.4.2.8.1.011, 1.3.3.5.030 | resources SSH-Construction Manhours [22000 h] → SSH-Construction Manhours [4170.76 h] |
| 1.4.2.8.1.015 | Excavation of telecomm ductbanks & trench Zone2 | 2012-04-11 → 2012-04-17 A (+6d) | 2012-04-23 → 2012-10-20 (+180d) | 12.5d → 35d | 0% → 50% | 130.5d → 17d | 1.4.2.8.1.014 → 1.4.2.8.1.014 FF+15d | resources SSH-Construction Manhours [10000 h]; Dump Truck [100 h]; Excavator [100 h] → SSH-Construction Manhours [1895.94 h]; Dump Truck [100 h]; Excavator [100 h] |
| 1.4.2.8.1.031 | Install comm manholes-Zone 3 - A3-2 (5) | 2012-03-21 → 2012-04-19 A (+29d) | 2012-04-08 → 2012-10-17 (+192d) | 18.75d → 25d | 0% → 49% | 93d → -6.75d | 1.4.2.8.1.021 → 1.4.2.8.1.021 FF+10d | resources SSH-Construction Manhours [15000 h] → SSH-Construction Manhours [2849.26 h] |
| 1.4.2.8.1.023 | Install comm conduits & fittings-Zone 3 - A3-4 | 2012-03-31 → 2012-04-22 A (+22d) | 2012-04-14 → 2012-05-15 A (+31d) | 15d → 25d | 0% → 100% | 126.75d → none |  | resources SSH-Construction Manhours [12000 h] → SSH-Construction Manhours [2274.82 h] |
| 1.4.2.8.1.022 | Install comm conduits & fittings-Zone 3 - A3-3 | 2012-03-19 → 2012-05-03 A (+45d) | 2012-04-14 → 2012-05-29 A (+45d) |  | 0% → 100% | 88d → none | 1.4.2.8.1.012 → 1.4.2.8.1.021 | resources SSH-Construction Manhours [22000 h] → SSH-Construction Manhours [4170.76 h] |
| 1.4.2.8.1.024 | Install comm conduits & fittings-Zone 3 - A3-5 | 2012-04-11 → 2012-05-06 A (+25d) | 2012-04-25 → 2012-05-29 A (+34d) | 15d → 25d | 0% → 100% | 138d → none |  | resources SSH-Construction Manhours [12000 h] → SSH-Construction Manhours [2274.82 h] |
| 1.4.2.8.1.032 | Install comm manholes-Zone 3 - A3-3 (7) | 2012-04-14 → 2012-05-15 A (+31d) | 2012-05-08 → 2012-10-17 (+162d) | 26.25d → 25d | 0% → 68% | 88d → 20.75d | 1.4.2.8.1.022 → 1.4.2.8.1.022 FF+10d | resources SSH-Construction Manhours [21000 h] → SSH-Construction Manhours [3981.32 h] |
| 1.4.2.8.1.025 | Install comm conduits & fittings-Zone 2 | 2012-04-23 → 2012-05-20 A (+27d) | 2012-05-07 → 2012-10-31 (+177d) | 15d → 25d | 0% → 50% | 130.5d → 17d |  | resources SSH-Construction Manhours [9600 h] → SSH-Construction Manhours [1819.55 h] |
| 1.4.2.8.1.035 | Install comm manholes-Zone 2 (4) | 2012-05-07 → 2012-05-24 A (+17d) | 2012-05-21 → 2012-11-05 (+168d) | 15d → 25d | 0% → 12% | 130.5d → 17d | 1.4.2.8.1.025 → 1.4.2.8.1.025 FF+5d | resources SSH-Construction Manhours [12000 h] → SSH-Construction Manhours [2276.35 h] |
| 1.4.2.8.1.020 | Install comm conduits & fittings-Zone 3 - A3-1 | 2012-02-19 → 2012-05-29 A (+100d) | 2012-03-11 → 2012-06-19 A (+100d) |  | 0% → 100% | 95.5d → none | 1.4.2.8.1.010, 1.3.3.7.030, 1.3.3.8.030 → 1.4.2.8.1.010, 1.3.3.11.030, 1.3.3.12.030 | resources SSH-Construction Manhours [22500 h] → SSH-Construction Manhours [4265.48 h] |
| 1.4.2.8.1.030 | Install comm manholes-Zone 3 - A3-1(5) | 2012-03-01 → 2012-06-10 A (+101d) | 2012-03-19 → 2012-10-16 (+211d) | 18.75d → 25d | 0% → 49% | 95.5d → -10.5d | 1.4.2.8.1.020 SS+12.5d, 1.3.3.11.030 → 1.4.2.8.1.020 SS+12.5d, 1.3.3.13.030 | resources SSH-Construction Manhours [15000 h] → SSH-Construction Manhours [2844.67 h] |
| 1.4.2.8.1.060 | backfilling/compaction of comm trench | 2012-03-25 → 2012-07-07 A (+104d) | 2012-05-05 → 2012-11-28 (+207d) | 43.75d → 60d | 0% → 22% | 188d → 32d | 1.4.2.8.1.050 → 1.4.2.8.1.050 FF | was named Supp/backfilling/compaction of comm trench; resources SSH-Construction Manhours [15021 h] → SSH-Construction Manhours [2847.73 h] |
| 1.4.2.8.1.110 | Complete Teleecomm siteworks | 2012-09-04 → 2012-09-20 A (+16d) | 2012-09-20 → 2012-09-23 A (+3d) | 17.5d → 2d | 0% → 100% | 56.75d → none | 1.4.2.8.1.082 SS+31.25d, 1.4.2.8.1.100, 1.4.2.8.1.088, 1.4.2.8.1.080, 1.4.2.8.1.060, 1.4.2.8.1.055 → 1.4.2.8.1.082, 1.4.2.8.1.100, 1.4.2.8.1.088, 1.4.2.8.1.080, 1.4.2.8.1.060 FF, 1.4.2.8.1.055, 1.4.2.8.1.086, 1.4.2.8.1.130, 1.4.2.8.1.150 | was named Testing/commissioning of comm system; resources SSH-Construction Manhours [21000 h] → SSH-Construction Manhours |
| 1.4.2.8.1.016 | Excavation of telecomm ductbanks & trench Zone4 | 2012-04-23 → 2012-10-04 (+164d) | 2012-04-30 → 2012-11-05 (+189d) | 7.5d → 35d |  | 158d → 14.5d | 1.4.2.8.1.015 → 1.4.2.8.1.015 FF+15d | resources SSH-Construction Manhours [6000 h]; Excavator [60 h]; Dump Truck [60 h] → SSH-Construction Manhours [1138.17 h]; Excavator [60 h]; Dump Truck [60 h] |
| 1.4.2.8.1.033 | Install comm manholes-Zone 3 - A3-4 (5) | 2012-04-14 → 2012-10-04 (+173d) | 2012-05-01 → 2012-10-27 (+179d) | 18.75d → 25d |  | 126.75d → 42d | 1.4.2.8.1.023 → 1.4.2.8.1.023 FF+15d | resources SSH-Construction Manhours [15000 h] → SSH-Construction Manhours [2849.26 h] |
| 1.4.2.8.1.034 | Install comm manholes-Zone 3 - A3-5 (2) | 2012-04-25 → 2012-10-04 (+162d) | 2012-05-02 → 2012-10-27 (+178d) | 7.5d → 25d |  | 138d → 54.5d | 1.4.2.8.1.024 → 1.4.2.8.1.024 FF+5d | resources SSH-Construction Manhours [6000 h] → SSH-Construction Manhours [1138.17 h] |
| 1.4.2.8.1.050 | Install Comm Code Blue system & accs | 2012-01-15 → 2012-10-04 (+263d) | 2012-03-25 → 2012-11-28 (+248d) | 75d → 60d |  | 188d → 10d | 1.4.2.8.1.040 SS → 1.4.2.8.1.040 FF+10d, 1.3.3.16.020, 1.3.3.16.030, 1.3.3.17.030 | was named Install copper cable manholes; resources SSH-Construction Manhours [19171.6 h] → SSH-Construction Manhours [3636.05 h] |
| 1.4.2.8.1.082 | Install FOC [Fiber Optic Cable] Zone3 - A3-1 | 2012-04-22 → 2012-10-04 (+165d) | 2012-05-09 → 2012-10-21 (+165d) |  |  | 59.25d → -10.5d | 1.4.2.8.1.030, 1.3.2.19.030 → 1.4.2.8.1.030 SS, 1.3.3.1.030 | resources SSH-Construction Manhours [32000 h]; Cable Puller [150 h] → SSH-Construction Manhours [6065.17 h]; Cable Puller [150 h] |
| 1.4.2.8.1.090 | Install comm grounding system | 2012-06-25 → 2012-10-04 (+101d) | 2012-07-30 → 2012-11-07 (+100d) |  |  | 150.5d → 55d | 1.4.2.8.1.040 SS+90d, 1.3.2.26.030 → 1.3.3.10.030 | resources SSH-Construction Manhours [18000 h]; Cable Puller [300 h] → SSH-Construction Manhours [3413 h]; Cable Puller [300 h] |
| 1.4.2.8.1.055 | Install comm copper cables closure | 2012-07-19 → 2012-10-18 (+91d) | 2012-08-23 → 2012-11-21 (+90d) |  |  | 69.25d → 29.5d | 1.4.2.8.1.050 SS+45d, 1.3.2.25.030, 1.3.2.21.030 → 1.4.2.8.1.050 SS+15d, 1.3.3.9.030, 1.3.3.3.030 | resources SSH-Construction Manhours [9585.81 h] → SSH-Construction Manhours [1818.02 h] |
| 1.4.2.8.1.100 | Install red tiles /cable markers | 2012-01-29 → 2012-10-18 (+263d) | 2012-03-27 → 2012-12-12 (+260d) | 62.5d → 60d |  | 229.25d → 17d |  | resources SSH-Construction Manhours [20000 h] → SSH-Construction Manhours [3791.88 h] |
| 1.4.2.8.1.083 | Install FOC [Fiber Optic Cable] Zone3 - A3-2 | 2012-05-09 → 2012-10-22 (+166d) | 2012-06-04 → 2012-11-15 (+164d) |  |  | 59.25d → -10.5d |  | resources SSH-Construction Manhours [22000 h]; Cable Puller [220 h] → SSH-Construction Manhours [4170.76 h]; Cable Puller [220 h] |
| 1.4.2.8.1.070 | Install comm subduct materials | 2012-02-13 → 2012-10-28 (+258d) | 2012-03-31 → 2012-12-12 (+256d) |  |  | 200.5d → 12d | 1.4.2.8.1.050 SS+31.25d → 1.4.2.8.1.050 FF+15d | resources SSH-Construction Manhours [30906.1 h]; Cable Puller [400 h] → SSH-Construction Manhours [5860.45 h]; Cable Puller [400 h] |
| 1.4.2.8.1.026 | Install comm conduits & fittings-Zone 4 | 2012-04-30 → 2012-11-06 (+190d) | 2012-05-14 → 2012-11-28 (+198d) | 15d → 25d |  | 158d → 14.5d |  | resources SSH-Construction Manhours [9600 h] → SSH-Construction Manhours [1819.55 h] |
| 1.4.2.8.1.080 | Install comm copper cables | 2012-07-19 → 2012-11-06 (+110d) | 2012-09-04 → 2012-12-17 (+104d) | 50d → 45d |  | 56.75d → 12d | 1.4.2.8.1.070 SS+25d, 1.3.2.22.030 → 1.4.2.8.1.070 SS+10d, 1.3.3.4.030 | resources SSH-Construction Manhours [19939.5 h] → SSH-Construction Manhours [3781.18 h] |
| 1.4.2.8.1.087 | Install FOC [Fiber Optic Cable] Zone2 | 2012-07-26 → 2012-11-06 (+103d) | 2012-08-21 → 2012-12-01 (+102d) |  |  | 59.25d → 17d | 1.4.2.8.1.035, 1.4.2.8.1.086 → 1.4.2.8.1.035, 1.4.2.8.1.082 | resources SSH-Construction Manhours [17600 h]; Cable Puller [220 h] → SSH-Construction Manhours [3338.14 h]; Cable Puller [220 h] |
| 1.4.2.8.1.036 | Install comm manholes-Zone 4 (2) | 2012-05-14 → 2012-11-11 (+181d) | 2012-05-21 → 2012-12-03 (+196d) | 7.5d → 25d |  | 158d → 14.5d | 1.4.2.8.1.026 → 1.4.2.8.1.026 FF+5d | resources SSH-Construction Manhours [6000 h] → SSH-Construction Manhours [1138.17 h] |

| ID | Task | Start | Finish | Duration | Complete | Total float | Predecessors | Other |
| --- | --- | --- | --- | --- | --- | --- | --- | --- |
| 1.4.2.8.1.084 | Install FOC [Fiber Optic Cable] Zone3 - A3-3 | 2012-06-04 → 2012-11-17 (+166d) | 2012-07-03 → 2012-12-15 (+165d) |  |  | 59.25d → -10.5d |  | resources SSH-Construction Manhours [25000 h]; Cable Puller [250 h] → SSH-Construction Manhours [4740.61 h]; Cable Puller [250 h] |
| 1.4.2.8.1.088 | Install FOC [Fiber Optic Cable] Zone4 | 2012-08-21 → 2012-12-04 (+105d) | 2012-09-02 → 2012-12-15 (+104d) |  |  | 59.25d → 14.5d |  | resources SSH-Construction Manhours [10000 h]; Cable Puller [100 h] → SSH-Construction Manhours [1895.94 h]; Cable Puller [100 h] |
| 1.4.2.8.1.085 | Install FOC [Fiber Optic Cable] Zone3 - A3-4 | 2012-07-03 → 2012-12-16 (+166d) | 2012-07-15 → 2012-12-26 (+164d) |  |  | 59.25d → -10.5d |  | resources SSH-Construction Manhours [6000 h]; Cable Puller [100 h] → SSH-Construction Manhours [1138.17 h]; Cable Puller [100 h] |
| 1.4.2.8.1.086 | Install FOC [Fiber Optic Cable] Zone3 - A3-5 | 2012-07-15 → 2012-12-27 (+165d) | 2012-07-26 → 2013-01-07 (+165d) |  |  | 59.25d → -10.5d |  | resources SSH-Construction Manhours [6000 h]; Cable Puller [100 h] → SSH-Construction Manhours [1138.17 h]; Cable Puller [100 h] |
| 3 | **BUILDING WORKS** | 2011-07-26 → 2011-10-02 (+68d) | 2012-11-20 → 2013-05-07 (+168d) |  |  |  |  |  |
| 1 | **Substations** | 2011-08-08 → 2011-10-08 (+61d) | 2012-08-21 → 2013-01-23 (+155d) |  |  |  |  |  |
| 1 | **Substation # 4** | 2011-08-08 → 2011-10-10 (+63d) | 2012-08-21 → 2013-01-23 (+155d) |  |  |  |  |  |
| 1 | **Civil Works** | 2011-08-08 → 2011-10-10 (+63d) |  |  |  |  |  |  |
| 1.4.3.1.1.010 | Excavation leveling & cpmpactionfor SS4 fdns | 2011-08-08 → 2011-10-10 A (+63d) | 2011-09-04 → 2011-11-03 A (+60d) |  | 0% → 100% | 40.25d → none | 1.2.6.200 → 1.2.6.200, 1.4.1.3.4.010 SS | resources SSH-Construction Manhours [9585.81 h]; Excavator [240 h]; Dump Truck [240 h] → SSH-Construction Manhours [281.8 h]; Excavator [240 h]; Dump Truck [240 h] |
| 1.4.3.1.1.060 | backfill/compaction | 2011-12-17 A | 2012-01-08 A |  | 0% → 100% | 263.75d → none | 1.4.3.1.1.050 → 1.4.3.1.1.020 SS | resources SSH-Construction Manhours [7988.18 h]; Dump Truck [200 h]; Compactor [200 h] → SSH-Construction Manhours [234.44 h]; Dump Truck [200 h]; Compactor [200 h] |
| 2 | **Structural Works** | 2011-08-22 → 2011-10-31 (+70d) | 2012-02-15 → 2012-10-30 (+258d) |  |  |  |  |  |
| 1.4.3.1.1.050 | Install RSB/FW/concrete for SS4 columns | 2011-10-31 A | 2011-12-15 A |  | 0% → 100% | 40.25d → none | 1.4.3.1.1.040 SS+25d → 1.4.3.1.1.060 SS, 1.4.3.1.1.030 | resources SSH-Construction Manhours [100000 h] → SSH-Construction Manhours [2935.51 h] |
| 1.4.3.1.1.020 | Install RSB/FW/concrete fdns | 2011-08-22 → 2011-11-04 A (+74d) | 2011-10-06 → 2011-11-26 A (+51d) |  | 0% → 100% | 40.25d → none | 1.4.3.1.1.010 SS+15d → 1.3.1.1.030 SS | resources SSH-Construction Manhours [100000 h] → SSH-Construction Manhours [2935.51 h] |
| 1.4.3.1.1.030 | Install RSB/FW/concrete for ground beams | 2011-09-14 → 2011-11-30 A (+77d) | 2011-10-30 → 2011-12-20 A (+51d) |  | 0% → 100% | 40.25d → none | 1.4.3.1.1.020 SS+25d → 1.4.3.1.1.020 SS | resources SSH-Construction Manhours [100000 h] → SSH-Construction Manhours [2935.51 h] |
| 1.4.3.1.1.070 | Install RSB/FW/concrete for roof beams | 2011-11-23 → 2012-02-18 A (+87d) | 2012-01-08 → 2012-04-03 A (+86d) |  | 0% → 100% | 40.25d → none | 1.4.3.1.1.050 SS+25d → 1.4.3.1.1.050 FF+25d | resources SSH-Construction Manhours [100000 h] → SSH-Construction Manhours [2935.51 h] |
| 1.4.3.1.1.080 | Install RSB/FW/concrete for SS4 roof slab | 2011-11-23 → 2012-03-07 A (+105d) | 2012-01-08 → 2012-10-30 (+296d) | 50d → 40d | 0% → 30% | 40.25d → -68.75d | 1.4.3.1.1.070 SS → 1.4.3.1.1.070 SS+20d | resources SSH-Construction Manhours [100000 h] → SSH-Construction Manhours [2935.51 h] |
| 1.4.3.1.1.090 | Install CMU blocks | 2012-01-10 → 2012-04-14 A (+95d) | 2012-02-15 → 2012-05-10 A (+85d) | 40d → 30d | 0% → 100% | 39d → none | 1.4.3.1.1.080 SS+50d, 1.3.1.3.030, 1.2.5.030 → 1.4.3.1.1.080 SS+20d, 1.3.1.5.030, 1.2.5.030 | resources SSH-Construction Manhours [38400 h] → SSH-Construction Manhours [1127.2 h] |
| 1.4.3.1.1.040 | Install RSB/FW/concrete for equipment fdns | 2011-10-08 → 2012-05-12 A (+217d) | 2011-11-22 → 2012-10-20 (+333d) |  | 0% → 65% | 40.25d → -32.5d | 1.4.3.1.1.030 SS+25d → 1.3.1.2.030, 1.4.3.1.1.090 | resources SSH-Construction Manhours [69123.4 h] → SSH-Construction Manhours [2029.31 h] |
| 3 | **Architectural Works** | 2012-01-24 → 2012-04-28 (+95d) | 2012-04-08 → 2012-12-10 (+246d) |  |  |  |  |  |
| 1.4.3.1.1.100 | Install Plastering work | 2012-01-24 → 2012-04-28 A (+95d) | 2012-02-29 → 2012-10-04 (+218d) | 40d → 25d | 0% → 95% | 39d → -68.75d |  | resources SSH-Construction Manhours [25600 h] → SSH-Construction Manhours [751.27 h] |
| 1.4.3.1.1.110 | Install floor finishing works - [Tiling] | 2012-02-07 → 2012-10-04 (+240d) | 2012-03-05 → 2012-10-31 (+240d) |  |  | 39d → -68.75d | 1.4.3.1.1.100 SS+15d, 1.3.1.2.030 → 1.4.3.1.1.100 SS+12.5d, 1.3.1.4.030 | resources SSH-Construction Manhours [19200 h] → SSH-Construction Manhours [563.6 h] |
| 1.4.3.1.1.130 | Install roof water proofing system | 2012-03-01 → 2012-10-04 (+217d) | 2012-03-24 → 2012-10-27 (+217d) |  |  | 39d → -38.75d | 1.4.3.1.1.120 SS+10d → 1.4.3.1.1.100 SS | resources SSH-Construction Manhours [7500.44 h] → SSH-Construction Manhours [219.83 h] |
| 1.4.3.1.1.120 | Install wall finishing works | 2012-02-21 → 2012-10-18 (+240d) | 2012-03-19 → 2012-11-14 (+240d) |  |  | 39d → -68.75d | 1.4.3.1.1.110 SS+15d, 1.3.1.2.030, 1.3.1.19.020 → 1.4.3.1.1.110 SS+15d, 1.3.1.4.030, 1.3.1.19.020 | resources SSH-Construction Manhours [19200 h] → SSH-Construction Manhours [563.6 h] |
| 1.4.3.1.1.125 | Install Ceiling finishing work | 2012-03-03 → 2012-10-30 (+241d) | 2012-03-29 → 2012-11-26 (+242d) |  |  | 206.25d → -36.25d | 1.4.3.1.1.120 SS, 1.3.1.20.020 → 1.4.3.1.1.120 SS+12.5d, 1.3.1.20.020 | resources SSH-Construction Manhours [14400 h] → SSH-Construction Manhours [422.7 h] |
| 1.4.3.1.1.140 | Install painting works | 2012-03-15 → 2012-11-15 (+245d) | 2012-03-28 → 2012-11-28 (+245d) |  |  | 39d → -68.75d | 1.4.3.1.1.130 SS+15d → 1.4.3.1.1.130 SS+15d, 1.4.3.1.1.120 | resources SSH-Construction Manhours [9585.81 h] → SSH-Construction Manhours [281.8 h] |
| 1.4.3.1.1.150 | Install doors & windows with frames | 2012-03-28 → 2012-11-29 (+246d) | 2012-04-08 → 2012-12-10 (+246d) |  |  | 178.75d → -68.75d | 1.4.3.1.1.140 SS, 1.4.3.1.1.125 SS, 1.4.3.1.1.060, 1.3.1.4.030, 1.3.1.8.030, 1.3.1.21.020, 1.3.1.22.020 → 1.4.3.1.1.140, 1.4.3.1.1.125 SS, 1.3.1.7.030, 1.3.1.8.030, 1.3.1.18.020, 1.3.1.21.020 | resources SSH-Construction Manhours [4800 h] → SSH-Construction Manhours [140.9 h] |
| 4 | **Plumbing Works** | 2012-01-31 → 2012-05-19 (+109d) | 2012-03-29 → 2012-10-30 (+215d) |  |  |  |  |  |
| 1.4.3.1.1.210 | Install plumbing works | 2012-01-31 → 2012-05-19 A (+109d) | 2012-03-27 → 2012-10-30 (+217d) | 60d → 31.25d | 0% → 10% | 38d → -36.12d | 1.4.3.1.1.100 SS, 1.3.3.14.030 → 1.4.3.1.1.100 SS, 1.3.4.7.030, M1.09 | resources SSH-Construction Manhours [48000 h] → SSH-Construction Manhours [1409 h] |
| 1.4.3.1.1.220 | Install eye wash & shower | 2012-03-13 → 2012-10-04 (+205d) | 2012-03-29 → 2012-10-21 (+206d) |  |  | 188.75d → -1d | 1.4.3.1.1.210 SS+45d → 1.4.3.1.1.210 SS+12.5d | was named Install eye wahs & shower; resources SSH-Construction Manhours [7200 h] → SSH-Construction Manhours [211.64 h] |
| 5 | **Mechanical / HVAC Works** | 2012-01-31 → 2012-10-04 (+247d) | 2012-04-26 → 2012-12-02 (+220d) |  |  |  |  |  |
| 1.4.3.1.1.330 | Install ducting works & DDC | 2012-01-31 → 2012-10-04 (+247d) | 2012-03-13 → 2012-11-14 (+246d) |  |  | 38d → -33d |  | resources SSH-Construction Manhours [54000 h] → SSH-Construction Manhours [1584.98 h] |
| 1.4.3.1.1.340 | Install air inlet & outlet accs | 2012-02-19 → 2012-10-23 (+247d) | 2012-03-18 → 2012-11-19 (+246d) |  |  | 158.75d → -33d |  | resources SSH-Construction Manhours [9000.53 h] → SSH-Construction Manhours [264.26 h] |
| 1.4.3.1.1.310 | Install ACCU [Air cooled condencing unit] equipments | 2012-03-26 → 2012-10-30 (+218d) | 2012-04-08 → 2012-11-13 (+219d) |  |  | 158.75d → -36.12d | 1.4.3.1.1.370 SS+8d → 1.4.3.1.1.210 | resources SSH-Construction Manhours [12000 h] → SSH-Construction Manhours [351.96 h] |
| 1.4.3.1.1.350 | Install fire & volume dampers | 2012-02-28 → 2012-11-01 (+247d) | 2012-03-18 → 2012-11-19 (+246d) |  |  | 158.75d → -33d | 1.4.3.1.1.340 SS+10d → 1.4.3.1.1.340 SS+10d, 1.3.2.25.030 | resources SSH-Construction Manhours [6400 h] → SSH-Construction Manhours [187.67 h] |
| 1.4.3.1.1.320 | Install AHU [Air Handling Unit] equipments with DDC panel | 2012-04-04 → 2012-11-08 (+218d) | 2012-04-17 → 2012-11-22 (+219d) |  |  | 158.75d → -36.12d |  | resources SSH-Construction Manhours [12000 h] → SSH-Construction Manhours [351.96 h] |
| 1.4.3.1.1.360 | Install sandtrap louvers | 2012-03-08 → 2012-11-11 (+248d) | 2012-03-27 → 2012-11-28 (+246d) |  |  | 158.75d → -33d |  | resources SSH-Construction Manhours [6400 h] → SSH-Construction Manhours [187.67 h] |
| 1.4.3.1.1.390 | Testing & balancing of HVAC system | 2012-04-14 → 2012-11-18 (+218d) | 2012-04-26 → 2012-12-02 (+220d) |  |  | 158.75d → -36.12d | 1.4.3.1.1.320 SS+10d → 1.4.3.1.1.320 SS+10d, 1.4.3.1.1.380 FF | resources SSH-Construction Manhours [7200 h] → SSH-Construction Manhours [211.64 h] |
| 1.4.3.1.1.370 | Install exhaust fan | 2012-03-18 → 2012-11-20 (+247d) | 2012-03-27 → 2012-11-28 (+246d) |  |  | 158.75d → -33d |  | resources SSH-Construction Manhours [4800 h] → SSH-Construction Manhours [140.9 h] |
| 1.4.3.1.1.380 | Install fire extinguishers | 2012-03-18 → 2012-11-20 (+247d) | 2012-03-27 → 2012-11-28 (+246d) |  |  | 191.75d → -33d | 1.4.3.1.1.370 SS → 1.4.3.1.1.370 SS, 1.4.3.1.1.220 | resources SSH-Construction Manhours [4800 h] → SSH-Construction Manhours [140.9 h] |
| 6 | **Electrical Works** | 2012-01-31 → 2012-05-12 (+102d) | 2012-08-21 → 2013-01-23 (+155d) |  |  |  |  |  |
| 1.4.3.1.1.410 | Install electrical conduits & fittings | 2012-01-31 → 2012-05-12 A (+102d) | 2012-03-13 → 2012-11-06 (+238d) |  | 0% → 20% | 38d → -67.5d | 1.4.3.1.1.330 SS → 1.4.3.1.1.090, 1.3.2.16.030 | resources SSH-Construction Manhours [25200 h] → SSH-Construction Manhours [739.58 h] |
| 1.4.3.1.1.500 | Install grounding system | 2012-03-20 → 2012-06-09 A (+81d) | 2012-04-12 → 2012-07-01 A (+80d) |  | 0% → 100% | 43d → none | 1.4.3.1.1.480 SS+47.5d → 1.4.3.1.1.480 SS+25d | resources SSH-Construction Manhours [7988.18 h] → SSH-Construction Manhours [234.44 h] |
| 1.4.3.1.1.550 | Install batterybank & battery charger | 2012-07-28 → 2012-08-01 A (+4d) | 2012-08-04 → 2012-12-22 (+140d) |  | 0% → 100% | 38d → -68.75d | 1.4.3.1.1.540 FS+3.75d → 1.4.3.1.1.540 SS+3.75d, 1.3.2.13.030 | was named Install batterybank; resources SSH-Construction Manhours [4800 h] → SSH-Construction Manhours [140.9 h] |
| 1.4.3.1.1.480 | Install cables trays | 2012-02-05 → 2012-10-04 (+242d) | 2012-04-01 → 2012-11-28 (+241d) |  |  | 38d → -67.5d |  | resources SSH-Construction Manhours [38343.2 h] → SSH-Construction Manhours [1125.45 h] |
| 1.4.3.1.1.490 | Install FAS-Fire Alarm system & FACP | 2012-06-12 → 2012-10-04 (+114d) | 2012-06-30 → 2012-10-21 (+113d) |  |  | 38d → 3.75d | 1.4.3.1.1.470, 1.3.2.17.030 → 1.3.2.17.030 | resources SSH-Construction Manhours [15000 h] → SSH-Construction Manhours [440.24 h] |
| 1.4.3.1.1.420 | Install cables & wires | 2012-02-19 → 2012-10-18 (+242d) | 2012-03-25 → 2012-11-21 (+241d) |  |  | 38d → -67.5d |  | resources SSH-Construction Manhours [19200 h] → SSH-Construction Manhours [563.6 h] |
| 1.4.3.1.1.430 | Install lighting fixtures | 2012-03-13 → 2012-11-11 (+243d) | 2012-04-17 → 2012-11-21 (+218d) | 37.5d → 12.5d |  | 38d → -67.5d |  | resources SSH-Construction Manhours [14378.7 h] → SSH-Construction Manhours [422.7 h] |
| 1.4.3.1.1.440 | Install Switchgear | 2012-04-17 → 2012-11-22 (+219d) | 2012-04-24 → 2012-11-28 (+218d) |  |  | 38d → -67.5d | 1.4.3.1.1.430, 1.4.3.1.1.500 → 1.4.3.1.1.430, 1.4.3.1.1.500, 1.3.2.1.030, 1.4.3.1.1.040 | resources SSH-Construction Manhours [9585.81 h] → SSH-Construction Manhours [281.8 h] |
| 1.4.3.1.1.450 | Install Package substation | 2012-04-28 → 2012-12-03 (+219d) | 2012-05-05 → 2012-12-09 (+218d) |  |  | 38d → -67.5d |  | resources SSH-Construction Manhours [9585.81 h] → SSH-Construction Manhours [281.8 h] |
| 1.4.3.1.1.460 | Install RMU | 2012-05-08 → 2012-12-10 (+216d) | 2012-05-26 → 2012-12-20 (+208d) | 18.75d → 12.5d |  | 38d → -67.5d | 1.4.3.1.1.450 FS+3.75d → 1.4.3.1.1.450 | resources SSH-Construction Manhours [11200 h] → SSH-Construction Manhours [329.16 h] |
| 1.4.3.1.1.470 | Install Transformer | 2012-05-31 → 2012-12-11 (+194d) | 2012-06-12 → 2012-12-22 (+193d) |  |  | 38d → -68.75d | 1.4.3.1.1.460 FS+6.25d → 1.4.3.1.1.460 SS, 1.3.2.7.030, 1.4.3.1.1.150 | resources SSH-Construction Manhours [6390.54 h] → SSH-Construction Manhours [187.67 h] |
| 1.4.3.1.1.510 | Install switchboard | 2012-06-16 → 2012-12-11 (+178d) | 2012-06-23 → 2012-12-17 (+177d) |  |  | 38d → -68.75d | 1.4.3.1.1.470 FS+3.75d, 1.4.3.1.1.490 SS+3.75d → 1.4.3.1.1.470 SS, 1.4.3.1.1.490 SS, 1.3.2.10.030 | resources SSH-Construction Manhours [9585.81 h] → SSH-Construction Manhours [281.8 h] |
| 1.4.3.1.1.520 | Install main distribution panel board | 2012-06-26 → 2012-12-13 (+170d) | 2012-07-03 → 2012-12-19 (+169d) |  |  | 38d → -68.75d | 1.4.3.1.1.510 FS+3.75d, 1.3.1.24.030 → 1.4.3.1.1.510 SS+2.5d, 1.3.2.2.030, 1.3.2.11.030 | resources SSH-Construction Manhours [9585.81 h] → SSH-Construction Manhours [281.8 h] |
| 1.4.3.1.1.530 | Install circuit breaker | 2012-07-07 → 2012-12-16 (+162d) | 2012-07-14 → 2012-12-22 (+161d) |  |  | 38d → -68.75d | 1.4.3.1.1.520 FS+3.75d → 1.4.3.1.1.520 SS+2.5d, 1.3.2.8.030 | resources SSH-Construction Manhours [4800 h] → SSH-Construction Manhours [140.9 h] |
| 1.4.3.1.1.540 | Install annunciator panel | 2012-07-17 → 2012-12-18 (+154d) | 2012-07-24 → 2012-12-24 (+153d) |  |  | 38d → -68.75d | 1.4.3.1.1.530 FS+3.75d → 1.4.3.1.1.530 SS+2.5d, 1.3.2.12.030 | resources SSH-Construction Manhours [4800 h] → SSH-Construction Manhours [140.9 h] |
| 1.4.3.1.1.560 | Testing /commissioning of electrical system | 2012-08-04 → 2013-01-10 (+159d) | 2012-08-18 → 2013-01-21 (+156d) | 15d → 12d |  | 38d → -90d | 1.4.3.1.1.550, Testing & commissioning of battery system SS4 SS, 1.2.8.020, 1.4.3.1.1.510 → 1.4.3.1.1.550, 1.2.8.020, 1.4.3.1.1.510 | resources SSH-Construction Manhours [9585.81 h] → SSH-Construction Manhours [281.8 h] |
| 1.4.3.1.1.570 | Energize Substation 4 | 2012-08-18 → 2013-01-21 (+156d) | 2012-08-21 → 2013-01-23 (+155d) | 3.75d → 3d |  | 38d → -90d | 1.4.3.1.1.560, 1.4.3.1.1.380, 1.4.3.1.1.390, 1.4.3.1.1.220, 1.4.3.1.1.150, 1.4.3.1.1.640, 1.4.4.2.010, 1.4.3.1.1.510, 1.4.2.7.5.020 → 1.4.3.1.1.560, 1.4.3.1.1.390, 1.4.3.1.1.640, 1.4.3.1.1.510 | resources SSH-Construction Manhours [1500.09 h] → SSH-Construction Manhours [43.85 h] |
| 7 | **Communication Works** | 2012-02-09 → 2012-05-21 (+102d) | 2012-07-19 → 2013-01-13 (+178d) |  |  |  |  |  |
| 1.4.3.1.1.610 | Install comm conduits & fittings | 2012-02-09 → 2012-05-21 A (+102d) | 2012-03-22 → 2012-10-24 (+216d) |  | 0% → 50% | 181.75d → -3d |  | resources SSH-Construction Manhours [28800 h] → SSH-Construction Manhours [845.4 h] |
| 1.4.3.1.1.620 | Install comm cabinet & accs & Data interworks | 2012-03-08 → 2012-10-04 (+210d) | 2012-03-22 → 2012-10-17 (+209d) |  |  | 181.75d → -3d |  | resources SSH-Construction Manhours [4800 h] → SSH-Construction Manhours [140.9 h] |
| 1.4.3.1.1.630 | Install comm equipments & accs | 2012-07-01 → 2012-12-25 (+177d) | 2012-07-15 → 2013-01-08 (+177d) |  |  | 69.25d → -80.55d | 1.4.3.1.1.620 SS+10d, 1.3.2.20.030 → 1.4.3.1.1.620 SS+10d, 1.3.3.2.030, 1.4.2.7.5.020 | resources SSH-Construction Manhours [4800 h] → SSH-Construction Manhours [140.9 h] |
| 1.4.3.1.1.640 | Install comm outlet & accs | 2012-07-10 → 2013-01-03 (+177d) | 2012-07-19 → 2013-01-13 (+178d) |  |  | 69.25d → -80.55d |  | resources SSH-Construction Manhours [3200 h] → SSH-Construction Manhours [94.13 h] |
| 8 | **Pavement / Parking / Signs / Markings** | 2012-01-24 → 2012-10-04 (+254d) | 2012-04-02 → 2012-12-12 (+254d) |  |  |  |  |  |
| 1.4.3.1.1.710 | Install gravel pavement | 2012-01-24 → 2012-10-04 (+254d) | 2012-02-29 → 2012-11-10 (+255d) |  |  | 277.5d → 17d |  | resources SSH-Construction Manhours [28757.4 h] → SSH-Construction Manhours [844.23 h] |
| 1.4.3.1.1.720 | Install 150mm thick concrete pavement | 2012-02-02 → 2012-10-14 (+255d) | 2012-02-29 → 2012-11-10 (+255d) |  |  | 277.5d → 17d |  | resources SSH-Construction Manhours [24000 h] → SSH-Construction Manhours [705.08 h] |
| 1.4.3.1.1.730 | Install 500mm thick general fill | 2012-02-12 → 2012-10-23 (+254d) | 2012-03-10 → 2012-11-19 (+254d) |  |  | 277.5d → 17d |  | resources SSH-Construction Manhours [24000 h] → SSH-Construction Manhours [705.08 h] |
| 1.4.3.1.1.740 | Install 200mm thk aggregate base coarse | 2012-02-21 → 2012-11-01 (+254d) | 2012-03-19 → 2012-11-28 (+254d) |  |  | 277.5d → 17d |  | resources SSH-Construction Manhours [24000 h] → SSH-Construction Manhours [705.08 h] |
| 1.4.3.1.1.750 | Install 120mm thk asphalt cncrt pavement | 2012-03-01 → 2012-11-11 (+255d) | 2012-03-19 → 2012-11-28 (+254d) |  |  | 277.5d → 17d |  | resources SSH-Construction Manhours [16000 h] → SSH-Construction Manhours [469.47 h] |
| 1.4.3.1.1.760 | Install shaded parking space | 2012-03-11 → 2012-11-20 (+254d) | 2012-03-27 → 2012-12-06 (+254d) |  |  | 277.5d → 17d |  | resources SSH-Construction Manhours [5760 h] → SSH-Construction Manhours [169.55 h] |
| 1.4.3.1.1.770 | Install road / park markings | 2012-03-20 → 2012-11-29 (+254d) | 2012-03-28 → 2012-12-08 (+255d) |  |  | 277.5d → 17d |  | resources SSH-Construction Manhours [3200 h] → SSH-Construction Manhours [94.13 h] |

| ID | Task | Start | Finish | Duration | Complete | Total float | Predecessors | Other |
| --- | --- | --- | --- | --- | --- | --- | --- | --- |
| 1.4.3.1.1.780 | Install road / parking signs | 2012-03-25 → 2012-12-04 (+254d) | 2012-04-02 → 2012-12-12 (+254d) |  |  | 277.5d → 17d |  | resources SSH-Construction Manhours [3195.27 h] → SSH-Construction Manhours [94.13 h] |
| 9 | **Perimeter Fence System** | 2012-03-01 → 2012-11-11 (+255d) | 2012-03-31 → 2012-12-10 (+254d) |  |  |  |  |  |
| 1.4.3.1.1.810 | Install perimeter fence type SSD-1 | 2012-03-01 → 2012-11-11 (+255d) | 2012-03-28 → 2012-12-08 (+255d) |  |  | 373d → 20d |  | resources SSH-Construction Manhours [14400 h] → SSH-Construction Manhours [422.7 h] |
| 1.4.3.1.1.820 | Install perimeter gate SSD-1 10.5m wide 2 leaf | 2012-03-21 → 2012-12-01 (+255d) | 2012-03-31 → 2012-12-10 (+254d) |  |  | 373d → 20d |  | resources SSH-Construction Manhours [6400 h] → SSH-Construction Manhours [187.67 h] |
| 2 | **Substation # 5** | 2011-08-08 → 2011-10-08 (+61d) | 2012-08-21 → 2013-01-06 (+138d) |  |  |  |  |  |
| 1 | **Civil Works** | 2011-08-08 → 2011-10-10 (+63d) |  |  |  |  |  |  |
| 1.4.3.1.2.010 | Excavation leveling & compactionfor SS5 fdns | 2011-08-08 → 2011-10-10 A (+63d) | 2011-09-04 → 2011-11-13 A (+70d) |  | 0% → 100% | 60d → none |  | resources SSH-Construction Manhours [9585.81 h]; Excavator [240 h]; Dump Truck [240 h] → SSH-Construction Manhours [281.8 h]; Excavator [240 h]; Dump Truck [240 h] |
| 1.4.3.1.2.060 | backfill/compaction | 2011-12-17 A | 2012-01-08 A |  | 0% → 100% | 261.25d → none | 1.4.3.1.2.050 → 1.4.3.1.2.030 SS | resources SSH-Construction Manhours [7988.18 h]; Dump Truck [200 h]; Compactor [200 h] → SSH-Construction Manhours [234.44 h]; Dump Truck [200 h]; Compactor [200 h] |
| 2 | **Structural Works** | 2011-08-22 → 2011-10-08 (+47d) | 2012-02-09 → 2012-11-05 (+270d) |  |  |  |  |  |
| 1.4.3.1.2.040 | Install RSB/FW/concrete for equipment fdns | 2011-10-08 A | 2011-11-22 → 2012-10-31 (+344d) |  | 0% → 40% | 60d → -71.25d | 1.4.3.1.2.030 SS+25d → 1.4.3.1.2.060 FF | resources SSH-Construction Manhours [100000 h] → SSH-Construction Manhours [2936.1 h] |
| 1.4.3.1.2.020 | Install RSB/FW/concrete fdns | 2011-08-22 → 2011-11-22 A (+92d) | 2011-10-06 → 2012-01-07 A (+93d) |  | 0% → 100% | 60d → none |  | resources SSH-Construction Manhours [100000 h] → SSH-Construction Manhours [2933.17 h] |
| 1.4.3.1.2.030 | Install RSB/FW/concrete for ground beams | 2011-09-14 → 2011-12-10 A (+87d) | 2011-10-30 → 2012-01-15 A (+77d) |  | 0% → 100% | 60d → none |  | resources SSH-Construction Manhours [100000 h] → SSH-Construction Manhours [2941.94 h] |
| 1.4.3.1.2.050 | Install RSB/FW/concrete for SS5 columns | 2011-10-31 → 2012-02-18 A (+110d) | 2011-12-15 → 2012-04-03 A (+110d) |  | 0% → 100% | 60d → none | 1.4.3.1.2.040 SS+25d → 1.4.3.1.2.040 SS+10d | resources SSH-Construction Manhours [100000 h] → SSH-Construction Manhours [2936.1 h] |
| 1.4.3.1.2.070 | Install RSB/FW/concrete for roof beams | 2011-10-31 → 2012-02-27 A (+119d) | 2011-12-15 → 2012-04-12 A (+119d) |  | 0% → 100% | 60d → none | 1.4.3.1.2.050 SS → 1.4.3.1.2.050 SS+10d | resources SSH-Construction Manhours [100000 h] → SSH-Construction Manhours [2936.1 h] |
| 1.4.3.1.2.080 | Install RSB/FW/concrete for SS5 roof slab | 2011-11-23 → 2012-03-07 A (+105d) | 2012-01-08 → 2012-11-05 (+302d) |  | 0% → 30% | 60d → -71.25d | 1.4.3.1.2.070 SS+25d → 1.4.3.1.2.070 SS+10d | resources SSH-Construction Manhours [100000 h] → SSH-Construction Manhours [2936.1 h] |
| 1.4.3.1.2.090 | Install CMU blocks | 2012-01-04 → 2012-04-18 A (+105d) | 2012-02-09 → 2012-05-24 A (+105d) |  | 0% → 100% | 60d → none |  | resources SSH-Construction Manhours [38400 h] → SSH-Construction Manhours [1127.78 h] |
| 3 | **Architectural Works** | 2012-01-18 → 2012-05-02 (+105d) | 2012-03-18 → 2012-11-10 (+237d) |  |  |  |  |  |
| 1.4.3.1.2.100 | Install Plastering work | 2012-01-18 → 2012-05-02 A (+105d) | 2012-02-23 → 2012-10-11 (+231d) |  | 0% → 81% | 60d → -57d |  | resources SSH-Construction Manhours [32000 h] → SSH-Construction Manhours [939.53 h] |
| 1.4.3.1.2.110 | Install finishing finishing works - [Tiling] | 2012-02-01 → 2012-05-16 A (+105d) | 2012-02-28 → 2012-10-31 (+246d) |  |  | 201.25d → -12d |  | resources SSH-Construction Manhours [19200 h] → SSH-Construction Manhours [563.6 h] |
| 1.4.3.1.2.120 | Install wall finishing works | 2012-02-11 → 2012-10-04 (+236d) | 2012-03-08 → 2012-10-31 (+237d) |  |  | 201.25d → -12d |  | resources SSH-Construction Manhours [19200 h] → SSH-Construction Manhours [563.6 h] |
| 1.4.3.1.2.125 | Install ceiling finishing works | 2012-02-11 → 2012-10-04 (+236d) | 2012-03-08 → 2012-10-31 (+237d) |  |  | 226.25d → 13d |  | resources SSH-Construction Manhours [14378.7 h] → SSH-Construction Manhours [422.7 h] |
| 1.4.3.1.2.130 | Install roof water proofing system | 2012-02-20 → 2012-10-14 (+237d) | 2012-03-11 → 2012-11-03 (+237d) |  |  | 201.25d → -12d |  | resources SSH-Construction Manhours [7200 h] → SSH-Construction Manhours [211.64 h] |
| 1.4.3.1.2.140 | Install painting works | 2012-02-29 → 2012-10-23 (+237d) | 2012-03-13 → 2012-11-05 (+237d) |  |  | 201.25d → -12d |  | resources SSH-Construction Manhours [6000 h] → SSH-Construction Manhours [175.98 h] |
| 1.4.3.1.2.150 | Install doors & windows with frames | 2012-03-05 → 2012-10-28 (+237d) | 2012-03-18 → 2012-11-10 (+237d) |  |  | 201.25d → -12d | 1.4.3.1.2.140 SS+5d, 1.4.3.1.2.125 SS, 1.4.3.1.2.060 → 1.4.3.1.2.140 SS+5d, 1.4.3.1.2.125 SS | resources SSH-Construction Manhours [4800 h] → SSH-Construction Manhours [140.9 h] |
| 4 | **Plumbing Works** | 2012-01-31 → 2012-05-19 (+109d) | 2012-03-22 → 2012-11-04 (+227d) |  |  |  |  |  |
| 1.4.3.1.2.210 | Install plumbing works | 2012-01-31 → 2012-05-19 A (+109d) | 2012-03-06 → 2012-11-04 (+243d) |  | 0% → 10% | 45.5d → -71.25d | 1.4.3.1.2.100 SS, 1.3.3.14.030 → 1.4.3.1.2.090 SS+15d, 1.3.4.7.030 | resources SSH-Construction Manhours [22366.9 h] → SSH-Construction Manhours [657.14 h] |
| 1.4.3.1.2.220 | Install eye wash & shower | 2012-02-23 → 2012-10-04 (+224d) | 2012-03-22 → 2012-10-31 (+223d) |  |  | 196.75d → -2d |  | resources SSH-Construction Manhours [14378.7 h] → SSH-Construction Manhours [422.7 h] |
| 5 | **Mechanical / HVAC Works** | 2012-01-31 → 2012-10-04 (+247d) | 2012-05-06 → 2013-01-03 (+242d) |  |  |  |  |  |
| 1.4.3.1.2.330 | Install ducting works | 2012-01-31 → 2012-10-04 (+247d) | 2012-03-13 → 2012-11-14 (+246d) |  |  | 45.5d → -71.25d |  | resources SSH-Construction Manhours [38343.2 h] → SSH-Construction Manhours [1125.45 h] |
| 1.4.3.1.2.340 | Install air inlet & outlet accs | 2012-02-23 → 2012-10-28 (+248d) | 2012-03-13 → 2012-11-14 (+246d) |  |  | 148.75d → -70d |  | resources SSH-Construction Manhours [16000 h] → SSH-Construction Manhours [469.47 h] |
| 1.4.3.1.2.350 | Install fire & volume dampers | 2012-03-04 → 2012-11-06 (+247d) | 2012-03-22 → 2012-11-24 (+247d) |  |  | 148.75d → -70d |  | resources SSH-Construction Manhours [9600 h] → SSH-Construction Manhours [281.8 h] |
| 1.4.3.1.2.360 | Install sandtrap louvers | 2012-03-13 → 2012-11-15 (+247d) | 2012-03-29 → 2012-12-01 (+247d) |  |  | 148.75d → -70d |  | resources SSH-Construction Manhours [7000 h] → SSH-Construction Manhours [205.21 h] |
| 1.4.3.1.2.370 | Install exhaust fan | 2012-03-22 → 2012-11-25 (+248d) | 2012-04-01 → 2012-12-03 (+246d) |  |  | 148.75d → -70d |  | resources SSH-Construction Manhours [4000 h] → SSH-Construction Manhours [117.51 h] |
| 1.4.3.1.2.380 | Install fire extinguishers | 2012-03-22 → 2012-11-25 (+248d) | 2012-04-05 → 2012-12-08 (+247d) |  |  | 181.75d → -42d |  | resources SSH-Construction Manhours [9585.81 h] → SSH-Construction Manhours [281.8 h] |
| 1.4.3.1.2.310 | Install ACCU equipments | 2012-03-31 → 2012-11-28 (+242d) | 2012-04-12 → 2012-12-12 (+244d) |  |  | 148.75d → -70d | 1.4.3.1.2.370 SS+8d → 1.4.3.1.2.370 SS+4d | resources SSH-Construction Manhours [12000 h] → SSH-Construction Manhours [351.96 h] |
| 1.4.3.1.2.320 | Install AHU equipments with DDC Panel | 2012-04-14 → 2012-12-12 (+242d) | 2012-04-26 → 2012-12-26 (+244d) |  |  | 148.75d → -70d |  | resources SSH-Construction Manhours [12000 h] → SSH-Construction Manhours [351.96 h] |
| 1.4.3.1.2.390 | Testing & balancing of HVAC system | 2012-04-23 → 2012-12-20 (+241d) | 2012-05-06 → 2013-01-03 (+242d) |  |  | 148.75d → -70d | 1.4.3.1.2.320 SS+10d → 1.4.3.1.2.320 SS+9d | resources SSH-Construction Manhours [9000.53 h] → SSH-Construction Manhours [264.26 h] |
| 6 | **Electrical Works** | 2012-01-31 → 2012-05-19 (+109d) | 2012-08-21 → 2013-01-06 (+138d) |  |  |  |  |  |
| 1.4.3.1.2.410 | Install electrical conduits & fititings | 2012-01-31 → 2012-05-19 A (+109d) | 2012-03-13 → 2012-11-08 (+240d) |  | 0% → 15% | 45.5d → -71.25d |  | resources SSH-Construction Manhours [28800 h] → SSH-Construction Manhours [845.4 h] |
| 1.4.3.1.2.500 | Install grounding system | 2012-03-20 → 2012-07-02 A (+104d) | 2012-04-12 → 2012-07-25 A (+104d) |  | 0% → 100% | 69.5d → none |  | resources SSH-Construction Manhours [9585.81 h] → SSH-Construction Manhours [281.8 h] |
| 1.4.3.1.2.480 | Install cables trays | 2012-02-05 → 2012-10-04 (+242d) | 2012-04-01 → 2012-11-28 (+241d) |  |  | 45.5d → -71.25d | 1.4.3.1.2.410 SS+5d → 1.4.3.1.2.410 SS | resources SSH-Construction Manhours [19171.6 h] → SSH-Construction Manhours [563.01 h] |
| 1.4.3.1.2.420 | Install cables & wires | 2012-02-19 → 2012-10-30 (+254d) | 2012-03-25 → 2012-12-03 (+253d) |  |  | 45.5d → -71.25d | 1.4.3.1.2.480 SS+15d → 1.4.3.1.2.480 FF+5d | resources SSH-Construction Manhours [19200 h] → SSH-Construction Manhours [563.6 h] |
| 1.4.3.1.2.430 | Install lighting fixtures | 2012-03-13 → 2012-11-04 (+236d) | 2012-04-17 → 2012-12-08 (+235d) |  |  | 45.5d → -71.25d | 1.4.3.1.2.420 SS+25d → 1.4.3.1.2.420 FF+5d | resources SSH-Construction Manhours [10800 h] → SSH-Construction Manhours [317.46 h] |
| 1.4.3.1.2.460 | Install RMU | 2012-05-08 → 2012-11-29 (+205d) | 2012-05-26 → 2012-12-17 (+205d) |  |  | 45.5d → -71.25d | 1.4.3.1.2.450 FS+3.75d → 1.4.3.1.2.450 FF+3.75d | resources SSH-Construction Manhours [12781.1 h] → SSH-Construction Manhours [375.34 h] |
| 1.4.3.1.2.440 | Install switchgear | 2012-04-17 → 2012-12-04 (+231d) | 2012-04-24 → 2012-12-11 (+231d) |  |  | 45.5d → -71.25d | 1.4.3.1.2.430, 1.4.3.1.2.500 SS+6d → 1.4.3.1.2.430 FF+3d | resources SSH-Construction Manhours [9600 h] → SSH-Construction Manhours [281.8 h] |
| 1.4.3.1.2.490 | Install FAS-Fire Alarm System & FACP | 2012-06-12 → 2012-12-05 (+176d) | 2012-06-30 → 2012-12-23 (+176d) |  |  | 45.5d → -71.25d | 1.4.3.1.2.470 → 1.4.3.1.2.470 FF+3d | resources SSH-Construction Manhours [15000 h] → SSH-Construction Manhours [440.24 h] |
| 1.4.3.1.2.450 | Install package substation | 2012-04-28 → 2012-12-06 (+222d) | 2012-05-05 → 2012-12-13 (+222d) |  |  | 45.5d → -71.25d | 1.4.3.1.2.440 FS+3.75d → 1.4.3.1.2.440 FF+3d | resources SSH-Construction Manhours [12781.1 h] → SSH-Construction Manhours [375.34 h] |
| 1.4.3.1.2.470 | Install Transformer | 2012-05-31 → 2012-12-09 (+192d) | 2012-06-12 → 2012-12-20 (+191d) |  |  | 45.5d → -71.25d | 1.4.3.1.2.460 FS+6.25d → 1.4.3.1.2.460 FF+3d | resources SSH-Construction Manhours [12781.1 h] → SSH-Construction Manhours [375.34 h] |
| 1.4.3.1.2.510 | Install switchboard | 2012-06-16 → 2012-12-19 (+186d) | 2012-06-23 → 2012-12-25 (+185d) |  |  | 45.5d → -71.25d | 1.4.3.1.2.470 FS+3.75d, 1.4.3.1.2.490 SS+3.75d → 1.4.3.1.2.490 FF+3d | resources SSH-Construction Manhours [12781.1 h] → SSH-Construction Manhours [375.34 h] |
| 1.4.3.1.2.520 | Install Main distribution panel board | 2012-06-26 → 2012-12-20 (+177d) | 2012-07-03 → 2012-12-27 (+177d) |  |  | 45.5d → -71.25d | 1.4.3.1.2.510 FS+3.75d → 1.4.3.1.2.510 FF+2d | resources SSH-Construction Manhours [12781.1 h] → SSH-Construction Manhours [375.34 h] |
| 1.4.3.1.2.530 | Install circuit breaker | 2012-07-07 → 2012-12-23 (+169d) | 2012-07-14 → 2012-12-30 (+169d) |  |  | 45.5d → -71.25d | 1.4.3.1.2.520 FS+3.75d → 1.4.3.1.2.520 FF+2d | resources SSH-Construction Manhours [12781.1 h] → SSH-Construction Manhours [375.34 h] |
| 1.4.3.1.2.540 | Install annunciator panel | 2012-07-17 → 2012-12-24 (+160d) | 2012-07-24 → 2012-12-31 (+160d) |  |  | 45.5d → -71.25d | 1.4.3.1.2.530 FS+3.75d → 1.4.3.1.2.530 FF+2d | resources SSH-Construction Manhours [12781.1 h] → SSH-Construction Manhours [375.34 h] |
| 1.4.3.1.2.550 | Install batterybank & battery charger | 2012-07-28 → 2012-12-26 (+151d) | 2012-08-04 → 2013-01-02 (+151d) |  |  | 45.5d → -71.25d | 1.4.3.1.2.540 FS+3.75d → 1.4.3.1.2.540 FF+2d | was named Install batterybank; resources SSH-Construction Manhours [9585.81 h] → SSH-Construction Manhours [281.8 h] |
| 1.4.3.1.2.560 | Testing /commissioning of electrical system | 2012-08-04 → 2012-12-26 (+144d) | 2012-08-18 → 2013-01-05 (+140d) | 15d → 10d |  | 37.75d → -71.25d | 1.4.3.1.2.550 SS, Testing & commissioning of battery system SS5 SS, 1.4.3.1.2.540 SS → 1.4.3.1.2.550 SS, 1.4.3.1.2.540 SS | resources SSH-Construction Manhours [9000.53 h] → SSH-Construction Manhours [264.26 h] |
| 1.4.3.1.2.570 | Energize Substation 5 | 2012-08-18 → 2013-01-05 (+140d) | 2012-08-21 → 2013-01-06 (+138d) | 3.75d → 2d |  | 37.75d → -71.25d | 1.4.3.1.2.560, 1.4.3.1.2.380, 1.4.3.1.2.390, 1.4.3.1.2.640, 1.4.3.1.2.780, 1.4.3.1.2.150, 1.4.3.1.2.220 → 1.4.3.1.2.560, 1.4.3.1.2.380, 1.4.3.1.2.390, 1.4.3.1.2.640, 1.4.3.1.2.780, 1.4.3.1.2.150, 1.4.3.1.2.220, 1.4.3.1.2.500 | resources SSH-Construction Manhours [2400.14 h] → SSH-Construction Manhours [70.16 h] |
| 7 | **Communication Works** | 2012-01-31 → 2012-05-19 (+109d) | 2012-04-15 → 2012-12-22 (+251d) |  |  |  |  |  |
| 1.4.3.1.2.610 | Install comm conduits & fittings | 2012-01-31 → 2012-05-19 A (+109d) | 2012-03-18 → 2012-10-27 (+223d) |  | 0% → 50% | 171.75d → -12d |  | resources SSH-Construction Manhours [19171.6 h] → SSH-Construction Manhours [563.01 h] |
| 1.4.3.1.2.620 | Install comm cabinet & accs & data interworks | 2012-03-08 → 2012-10-04 (+210d) | 2012-03-27 → 2012-10-22 (+209d) |  |  | 171.75d → -12d |  | resources SSH-Construction Manhours [9600 h] → SSH-Construction Manhours [281.8 h] |
| 1.4.3.1.2.630 | Install comm equipments & accs | 2012-03-22 → 2012-10-18 (+210d) | 2012-04-10 → 2012-11-05 (+209d) |  |  | 171.75d → -12d |  | resources SSH-Construction Manhours [19171.6 h] → SSH-Construction Manhours [563.01 h] |
| 1.4.3.1.2.640 | Install comm outlet & accs | 2012-04-05 → 2012-12-13 (+252d) | 2012-04-15 → 2012-12-22 (+251d) |  |  | 171.75d → -57d |  | resources SSH-Construction Manhours [8000 h] → SSH-Construction Manhours [235.03 h] |
| 8 | **Pavement / Parking / Signs / Markings** | 2012-01-18 → 2012-10-04 (+260d) | 2012-03-22 → 2012-12-08 (+261d) |  |  |  |  |  |
| 1.4.3.1.2.710 | Install gravel pavement | 2012-01-18 → 2012-10-04 (+260d) | 2012-02-23 → 2012-11-10 (+261d) |  |  | 181.25d → -57d |  | resources SSH-Construction Manhours [35200 h] → SSH-Construction Manhours [1033.07 h] |
| 1.4.3.1.2.720 | Install 150mm thick concrete pavement | 2012-01-28 → 2012-10-23 (+269d) | 2012-02-23 → 2012-11-19 (+270d) |  |  | 197.25d → -41d | 1.4.3.1.2.710 SS+10d → 1.4.3.1.2.710 FF+10d | resources SSH-Construction Manhours [24000 h] → SSH-Construction Manhours [705.08 h] |
| 1.4.3.1.2.730 | Install 500mm thick general fill | 2012-02-06 → 2012-10-23 (+260d) | 2012-03-04 → 2012-11-19 (+260d) |  |  | 197.25d → -41d | 1.4.3.1.2.720 SS+10d → 1.4.3.1.2.720 FF | resources SSH-Construction Manhours [21568.1 h] → SSH-Construction Manhours [633.17 h] |
| 1.4.3.1.2.740 | Install 200mm thk aggregate base coarse | 2012-02-15 → 2012-11-01 (+260d) | 2012-03-08 → 2012-11-24 (+261d) |  |  | 197.25d → -41d |  | resources SSH-Construction Manhours [21568.1 h] → SSH-Construction Manhours [633.17 h] |
| 1.4.3.1.2.750 | Install 120mm thk asphalt cncrt pavement | 2012-02-25 → 2012-11-11 (+260d) | 2012-03-13 → 2012-11-28 (+260d) |  |  | 197.25d → -41d |  | resources SSH-Construction Manhours [8000 h] → SSH-Construction Manhours [235.03 h] |
| 1.4.3.1.2.760 | Install shaded parking space | 2012-02-29 → 2012-11-15 (+260d) | 2012-03-17 → 2012-12-02 (+260d) |  |  | 197.25d → -41d |  | resources SSH-Construction Manhours [9000 h] → SSH-Construction Manhours [264.26 h] |
| 1.4.3.1.2.770 | Install road / park markings | 2012-03-05 → 2012-11-20 (+260d) | 2012-03-19 → 2012-12-04 (+260d) |  |  | 197.25d → -41d |  | resources SSH-Construction Manhours [7200 h] → SSH-Construction Manhours [211.64 h] |
| 1.4.3.1.2.780 | Install road / parking signs | 2012-03-08 → 2012-11-24 (+261d) | 2012-03-22 → 2012-12-08 (+261d) |  |  | 197.25d → -41d |  | resources SSH-Construction Manhours [7200 h] → SSH-Construction Manhours [211.64 h] |
| 9 | **Perimeter Fence System** | 2012-02-11 → 2012-10-28 (+260d) | 2012-03-27 → 2012-12-12 (+260d) |  |  |  |  |  |

| ID | Task | Start | Finish | Duration | Complete | Total float | Predecessors | Other |
| --- | --- | --- | --- | --- | --- | --- | --- | --- |
| 1.4.3.1.2.810 | Install perimeter fence type SSD-1 | 2012-02-11 → 2012-10-28 (+260d) | 2012-03-22 → 2012-12-08 (+261d) |  |  | 181.25d → -57d |  | resources SSH-Construction Manhours [18000 h] → SSH-Construction Manhours [527.94 h] |
| 1.4.3.1.2.820 | Install periemter gate SSD-1 10.5m wide 2 leaf | 2012-03-10 → 2012-11-25 (+260d) | 2012-03-27 → 2012-12-12 (+260d) |  |  | 181.25d → -57d |  | resources SSH-Construction Manhours [8000 h] → SSH-Construction Manhours [235.03 h] |
| 2 | **Exchange Building** | 2011-07-26 → 2011-10-02 (+68d) | 2012-10-04 → 2013-03-05 (+152d) |  |  |  |  |  |
| 1 | **Civil Works** | 2011-07-26 → 2011-10-02 (+68d) |  |  |  |  |  |  |
| 1.4.3.2.1.010 | Site clearing / grubbing | 2011-07-26 → 2011-10-02 A (+68d) | 2011-08-08 → 2011-10-29 A (+82d) |  | 0% → 100% | 51.5d → none | 1.2.6.200 SS+18.75d → 1.2.6.200 SS+18.75d, 1.4.1.3.4.010 SS | resources SSH-Construction Manhours [4800 h]; Grader [120 h]; Dump Truck [120 h] → SSH-Construction Manhours [305 h]; Grader [120 h]; Dump Truck [120 h] |
| 1.4.3.2.1.020 | Excavation leveling & compactionfor exchange bldg 1 fdns | 2011-07-31 → 2011-10-31 A (+92d) | 2011-08-14 → 2011-11-28 A (+106d) |  | 0% → 100% | 51.5d → none |  | resources SSH-Construction Manhours [7200 h]; Excavator [120 h]; Dump Truck [120 h] → SSH-Construction Manhours [623.91 h]; Excavator [120 h]; Dump Truck [120 h] |
| 1.4.3.2.1.030 | Backfill/compaction of exchange bldg fdns | 2011-12-15 → 2011-12-05 A (-10d) | 2012-01-02 A |  | 0% → 100% | 229.25d → none | 1.4.3.2.1.150 → 1.4.3.2.1.110 FF | resources SSH-Construction Manhours [10000 h]; Dump Truck [150 h]; Compactor [150 h] → SSH-Construction Manhours [449.53 h]; Dump Truck [150 h]; Compactor [150 h] |
| 2 | **Structural Works** | 2011-08-14 → 2011-12-26 (+134d) | 2012-05-02 → 2013-01-17 (+260d) |  |  |  |  |  |
| 1.4.3.2.1.110 | Install RSB/FW/concrete for fdns | 2011-08-14 → 2011-12-26 A (+134d) | 2011-09-18 → 2012-01-17 A (+121d) | 37.5d → 30d | 0% → 100% | 51.5d → none |  | resources SSH-Construction Manhours [112500 h] → SSH-Construction Manhours [7016.98 h] |
| 1.4.3.2.1.120 | Install RSB/FW/concrete for ground beams | 2011-08-14 → 2012-01-15 A (+154d) | 2011-10-09 → 2012-02-11 A (+125d) | 60d → 30d | 0% → 100% | 51.5d → none | 1.4.3.2.1.110 SS → 1.4.3.2.1.030 FF | resources SSH-Construction Manhours [120000 h] → SSH-Construction Manhours [7484.26 h] |
| 1.4.3.2.1.170 | Install RSB/FW/cncrt for cable vault, SOG | 2011-12-05 → 2012-01-15 A (+41d) | 2012-01-30 → 2012-02-11 A (+12d) | 60d → 30d | 0% → 100% | 51.5d → none | 1.4.3.2.1.160 SS+18.75d → 1.4.3.2.1.120 SS | resources SSH-Construction Manhours [72004.2 h] → SSH-Construction Manhours [4491.08 h] |
| 1.4.3.2.1.130 | Install RSB/FW/concrete for equipment fdns | 2011-09-11 → 2012-02-18 A (+160d) | 2011-11-06 → 2012-10-17 (+346d) | 60d → 30d | 0% → 52% | 51.5d → -69.8d | 1.4.3.2.1.120 SS+30d → 1.4.3.2.1.120 FF+5d | resources SSH-Construction Manhours [120000 h] → SSH-Construction Manhours [7484.26 h] |
| 1.4.3.2.1.140 | Install RSB/FW/concrete for columns | 2011-10-09 → 2012-03-07 A (+150d) | 2011-12-04 → 2012-04-03 A (+121d) | 60d → 30d | 0% → 100% | 51.5d → none | 1.4.3.2.1.130 SS+30d → 1.4.3.2.1.130 FF+20d | resources SSH-Construction Manhours [120000 h] → SSH-Construction Manhours [7484.26 h] |
| 1.4.3.2.1.230 | Install embedded structural steel, anchor bolts,plates,angles | 2011-10-09 → 2012-03-17 A (+160d) | 2012-01-29 → 2013-01-17 (+354d) |  | 0% → 6% | 167d → -69.8d |  | resources SSH-Construction Manhours [82948.1 h] → SSH-Construction Manhours [5172.94 h] |
| 1.4.3.2.1.190 | Install 150mm thk prefabricated wall panel | 2012-01-30 → 2012-03-18 A (+48d) | 2012-02-27 → 2012-11-14 (+261d) | 30d → 25d | 0% → 15% | 51.5d → -129.5d | 1.4.3.2.1.170 → 1.4.3.2.1.170 FF+15d, 1.4.3.2.1.180 FF+15d | resources SSH-Construction Manhours [41474.1 h] → SSH-Construction Manhours [2585.95 h] |
| 1.4.3.2.1.150 | Install RSB/FW/concrete for side walls | 2011-10-20 → 2012-03-21 A (+153d) | 2011-12-15 → 2012-04-17 A (+124d) | 60d → 30d | 0% → 100% | 51.5d → none | 1.4.3.2.1.140 SS+12.5d → 1.4.3.2.1.140 FF+15d | resources SSH-Construction Manhours [96000 h] → SSH-Construction Manhours [5986.88 h] |
| 1.4.3.2.1.155 | Install structural steel structures | 2011-10-20 → 2012-03-21 A (+153d) | 2011-12-15 → 2012-12-02 (+353d) | 60d → 30d | 0% → 3% | 81.5d → -31.9d |  | resources SSH-Construction Manhours [72004.2 h] → SSH-Construction Manhours [4491.08 h] |
| 1.4.3.2.1.200 | Install 250mm thk prefabricated wall panel | 2012-02-22 → 2012-03-27 A (+34d) | 2012-03-21 → 2012-11-24 (+248d) | 30d → 25d | 0% → 15% | 95.75d → -103d | 1.4.3.2.1.190 SS+25d → 1.4.3.2.1.190 FF+10d | resources SSH-Construction Manhours [24000 h] → SSH-Construction Manhours [1497.37 h] |
| 1.4.3.2.1.160 | Install RSB/FW/cncrt for suspended slab | 2011-11-17 → 2012-04-04 A (+139d) | 2012-01-12 → 2012-11-19 (+312d) | 60d → 30d | 0% → 50% | 51.5d → -31.9d | 1.4.3.2.1.150 SS+30d, 1.4.3.2.1.155 SS → 1.4.3.2.1.150 FF+15d, 1.4.3.2.1.155 SS | resources SSH-Construction Manhours [96000 h] → SSH-Construction Manhours [5986.88 h] |
| 1.4.3.2.1.210 | Install 250mm thk prefabricated wall panel, 150mm thkx650mm | 2012-03-17 → 2012-04-05 A (+19d) | 2012-04-14 → 2012-12-08 (+238d) |  | 0% → 15% | 95.75d → -103d | 1.4.3.2.1.200 SS+25d → 1.4.3.2.1.200 FF+15d | resources SSH-Construction Manhours [24000 h] → SSH-Construction Manhours [1497.37 h] |
| 1.4.3.2.1.220 | Install expanded wire mesh on frame as per SSD/20 | 2012-04-04 → 2012-06-09 A (+66d) | 2012-05-02 → 2013-01-17 (+260d) |  | 0% → 15% | 95.75d → -69.8d | 1.4.3.2.1.210 SS+20d, 1.4.3.2.1.230 → 1.4.3.2.1.210 FF, 1.4.3.2.1.230 FF, 1.4.3.2.1.160 | resources SSH-Construction Manhours [41474.1 h] → SSH-Construction Manhours [2585.95 h] |
| 1.4.3.2.1.180 | Install RSB/FW/cncrt for grade slab | 2012-01-02 → 2012-10-04 (+276d) | 2012-02-13 → 2012-10-31 (+261d) | 45d → 30d |  | 150.75d → -129.5d | 1.4.3.2.1.170 SS+30d → 1.4.3.2.1.170 FF+15d | resources SSH-Construction Manhours [54003.2 h] → SSH-Construction Manhours [3367.52 h] |
| 3 | **Architectural Works** | 2012-01-30 → 2012-03-18 (+48d) | 2012-08-14 → 2013-03-04 (+202d) |  |  |  |  |  |
| 1 | **Masonry work** | 2012-01-30 → 2012-03-18 (+48d) | 2012-04-02 → 2012-11-04 (+216d) |  |  |  |  |  |
| 1.4.3.2.1.310 | Install 200mm thk CMU blocks | 2012-01-30 → 2012-03-18 A (+48d) | 2012-03-05 → 2012-04-22 A (+48d) |  | 0% → 100% | 51.5d → none |  | resources SSH-Construction Manhours [38343.2 h] → SSH-Construction Manhours [2391.2 h] |
| 1.4.3.2.1.320 | Install 50mm thk morter plastering work | 2012-02-27 → 2012-03-22 A (+24d) | 2012-04-02 → 2012-11-04 (+216d) |  | 0% → 12% | 169.25d → -138.75d | 1.4.3.2.1.310 SS+30d → 1.4.3.2.1.310 FF+5d | resources SSH-Construction Manhours [28757.4 h] → SSH-Construction Manhours [1793.92 h] |
| 2 | **Floor Finishing work** | 2012-05-02 → 2012-12-24 (+236d) | 2012-06-19 → 2013-01-26 (+221d) |  |  |  |  |  |
| 1.4.3.2.1.330 | Install ceramic tiling works | 2012-05-02 → 2012-12-24 (+236d) | 2012-05-20 → 2013-01-12 (+237d) |  |  | 66.75d → -69.8d |  | resources SSH-Construction Manhours [14400 h] → SSH-Construction Manhours [898.53 h] |
| 1.4.3.2.1.340 | Install cement toping works | 2012-05-12 → 2012-12-29 (+231d) | 2012-05-29 → 2013-01-16 (+232d) |  |  | 66.75d → -69.8d | 1.4.3.2.1.330 SS+10d → 1.4.3.2.1.330 FF+5d | resources SSH-Construction Manhours [14400 h] → SSH-Construction Manhours [898.53 h] |
| 1.4.3.2.1.350 | Install vinyl tiling works | 2012-05-21 → 2013-01-02 (+226d) | 2012-06-07 → 2013-01-21 (+228d) |  |  | 66.75d → -69.8d | 1.4.3.2.1.340 SS+10d → 1.4.3.2.1.340 FF+5d | resources SSH-Construction Manhours [14400 h] → SSH-Construction Manhours [898.53 h] |
| 1.4.3.2.1.360 | Install APCS-12 painting works | 2012-05-30 → 2013-01-07 (+222d) | 2012-06-17 → 2013-01-26 (+223d) |  |  | 66.75d → -69.8d | 1.4.3.2.1.350 SS+10d → 1.4.3.2.1.350 FF+5d | resources SSH-Construction Manhours [12800 h] → SSH-Construction Manhours [798.29 h] |
| 1.4.3.2.1.370 | Install accs floor system | 2012-06-09 → 2013-01-15 (+220d) | 2012-06-19 → 2013-01-26 (+221d) |  |  | 66.75d → -69.8d | 1.4.3.2.1.360 SS+10d → 1.4.3.2.1.360 FF | resources SSH-Construction Manhours [7680 h] → SSH-Construction Manhours [479.28 h] |
| 3 | **Wall Finishing work** | 2012-05-02 → 2012-12-24 (+236d) | 2012-06-12 → 2013-01-26 (+228d) |  |  |  |  |  |
| 1.4.3.2.1.380 | Install dry wall partition works | 2012-05-02 → 2012-12-24 (+236d) | 2012-05-24 → 2013-01-16 (+237d) |  |  | 66.75d → -69.8d | 1.4.3.2.1.180, 1.4.3.2.1.220 SS, 1.3.1.13.030, 1.3.1.12.030 → 1.4.3.2.1.220 SS, 1.3.1.13.030, 1.3.1.12.030 | resources SSH-Construction Manhours [18000 h] → SSH-Construction Manhours [1121.99 h] |
| 1.4.3.2.1.390 | Install ceramic wall tiling works | 2012-05-12 → 2012-12-29 (+231d) | 2012-06-03 → 2013-01-21 (+232d) |  |  | 98.75d → -44.8d | 1.4.3.2.1.380 SS+10d → 1.4.3.2.1.380 FF+5d | resources SSH-Construction Manhours [18000 h] → SSH-Construction Manhours [1121.99 h] |
| 1.4.3.2.1.400 | Install wall painting works | 2012-05-21 → 2013-01-02 (+226d) | 2012-06-12 → 2013-01-26 (+228d) |  |  | 98.75d → -44.8d | 1.4.3.2.1.390 SS+10d → 1.4.3.2.1.390 FF+5d | resources SSH-Construction Manhours [16000 h] → SSH-Construction Manhours [997.73 h] |
| 4 | **Ceiling Finishing work** | 2012-06-19 → 2013-01-26 (+221d) | 2012-07-31 → 2013-02-27 (+211d) |  |  |  |  |  |
| 1.4.3.2.1.410 | Install acoustical celing works | 2012-06-19 → 2013-01-26 (+221d) | 2012-07-12 → 2013-02-18 (+221d) |  |  | 66.75d → -69.8d |  | resources SSH-Construction Manhours [16000 h] → SSH-Construction Manhours [997.73 h] |
| 1.4.3.2.1.420 | Install gypsum board celing works | 2012-06-28 → 2013-01-30 (+216d) | 2012-07-22 → 2013-02-23 (+216d) |  |  | 81.75d → -54.8d | 1.4.3.2.1.410 SS+10d → 1.4.3.2.1.410 FF+5d | resources SSH-Construction Manhours [12000 h] → SSH-Construction Manhours [748.16 h] |
| 1.4.3.2.1.430 | Install ceiling painting works | 2012-07-08 → 2013-02-04 (+211d) | 2012-07-31 → 2013-02-27 (+211d) |  |  | 81.75d → -54.8d | 1.4.3.2.1.420 SS+10d, 1.4.3.2.1.400 → 1.4.3.2.1.420 FF+5d, 1.4.3.2.1.400 | resources SSH-Construction Manhours [12000 h] → SSH-Construction Manhours [748.16 h] |
| 5 | **Roof Finishing work** | 2012-07-03 → 2013-02-09 (+221d) | 2012-08-09 → 2013-03-04 (+207d) |  |  |  |  |  |
| 1.4.3.2.1.440 | Install roof water proofing system | 2012-07-03 → 2013-02-09 (+221d) | 2012-07-26 → 2013-02-23 (+212d) | 25d → 15d |  | 66.75d → -69.8d |  | resources SSH-Construction Manhours [10000 h] → SSH-Construction Manhours [623.91 h] |
| 1.4.3.2.1.450 | Install roof painting works | 2012-07-22 → 2013-02-18 (+211d) | 2012-08-09 → 2013-03-04 (+207d) | 20d → 15d |  | 66.75d → -69.8d | 1.4.3.2.1.440 SS+20d → 1.4.3.2.1.440 FF+10d | resources SSH-Construction Manhours [8000 h] → SSH-Construction Manhours [499.65 h] |
| 6 | **Doors & Windows** | 2012-07-22 → 2013-02-18 (+211d) | 2012-08-14 → 2013-03-04 (+202d) |  |  |  |  |  |
| 1.4.3.2.1.460 | Install doors & windows with frames | 2012-07-22 → 2013-02-18 (+211d) | 2012-08-14 → 2013-03-04 (+202d) | 25d → 15d |  | 66.75d → -69.8d |  | resources SSH-Construction Manhours [10000 h] → SSH-Construction Manhours [623.91 h] |
| 4 | **Plumbing Works** | 2012-04-14 → 2012-11-06 (+206d) | 2012-06-09 → 2012-12-26 (+200d) |  |  |  |  |  |
| 1.4.3.2.1.510 | Install plumbing system & fittings | 2012-04-14 → 2012-11-06 (+206d) | 2012-05-16 → 2012-12-08 (+206d) |  |  | 144d → -103d | 1.4.3.2.1.210 → 1.4.3.2.1.210 FF | was named Install plumbing conduits & fittings; resources SSH-Construction Manhours [16800 h] → SSH-Construction Manhours [1047.85 h] |
| 1.4.3.2.1.520 | Install plumbing fixtures | 2012-05-02 → 2012-12-04 (+216d) | 2012-05-30 → 2012-12-17 (+201d) | 30d → 15d |  | 144d → -16.25d | 1.4.3.2.1.510 SS+20d → 1.4.3.2.1.510 FF+10d | resources SSH-Construction Manhours [14400 h] → SSH-Construction Manhours [898.53 h] |
| 1.4.3.2.1.530 | Install countertop w/built in lavatory | 2012-05-21 → 2012-12-13 (+206d) | 2012-06-09 → 2012-12-26 (+200d) | 20d → 15d |  | 144d → -16.25d | 1.4.3.2.1.520 SS+20d → 1.4.3.2.1.520 FF+10d | resources SSH-Construction Manhours [12800 h] → SSH-Construction Manhours [798.29 h] |
| 5 | **Mechanical / HVAC Works** | 2012-04-23 → 2012-10-28 (+188d) | 2012-08-28 → 2013-03-04 (+188d) |  |  |  |  |  |
| 1.4.3.2.1.630 | Install ducting system | 2012-04-23 → 2012-10-28 (+188d) | 2012-06-03 → 2012-12-08 (+188d) |  |  | 77.25d → -103d | 1.4.3.2.1.310, 1.3.4.11.030, 1.3.4.12.030, 1.3.4.10.030 → 1.4.3.2.1.310 FF, 1.3.4.15.030, 1.4.3.2.1.510 FF | resources SSH-Construction Manhours [28757.4 h] → SSH-Construction Manhours [1798.62 h] |
| 1.4.3.2.1.640 | Install air & outlets accs | 2012-05-21 → 2012-11-25 (+188d) | 2012-06-12 → 2012-12-17 (+188d) |  |  | 77.25d → -39.25d | 1.4.3.2.1.630 SS+30d → 1.4.3.2.1.630 FF+10d | resources SSH-Construction Manhours [16000 h] → SSH-Construction Manhours [997.73 h] |
| 1.4.3.2.1.650 | Install fire / volume dampers | 2012-05-30 → 2012-12-04 (+188d) | 2012-06-21 → 2012-12-26 (+188d) |  |  | 77.25d → -39.25d | 1.4.3.2.1.640 SS+10d → 1.4.3.2.1.640 FF+10d | resources SSH-Construction Manhours [16000 h] → SSH-Construction Manhours [997.73 h] |
| 1.4.3.2.1.610 | Install ACCU equipments | 2012-07-01 → 2012-12-16 (+168d) | 2012-07-24 → 2013-01-08 (+168d) |  |  | 77.25d → -39.25d | 1.4.3.2.1.680 SS+6d → 1.4.3.2.1.680 FF+4d | resources SSH-Construction Manhours [18000 h] → SSH-Construction Manhours [1121.99 h] |
| 1.4.3.2.1.660 | Install sandtrap louvers | 2012-06-10 → 2012-12-18 (+191d) | 2012-06-24 → 2012-12-31 (+190d) |  |  | 77.25d → -39.25d | 1.4.3.2.1.650 SS+12d → 1.4.3.2.1.650 FF+5d | resources SSH-Construction Manhours [9600 h] → SSH-Construction Manhours [598.85 h] |
| 1.4.3.2.1.620 | Install AHU equipments | 2012-07-18 → 2012-12-25 (+160d) | 2012-08-11 → 2013-01-17 (+159d) |  |  | 77.25d → -39.25d | 1.4.3.2.1.610 SS+18.75d → 1.4.3.2.1.610 FF+10d | resources SSH-Construction Manhours [18000 h] → SSH-Construction Manhours [1121.99 h] |
| 1.4.3.2.1.670 | Install exhaust fan | 2012-06-19 → 2012-12-29 (+193d) | 2012-06-28 → 2013-01-02 (+188d) | 10d → 5d |  | 77.25d → -39.25d | 1.4.3.2.1.660 SS+10d, 1.3.4.13.030 → 1.4.3.2.1.660 FF+2d, 1.3.4.16.030 | resources SSH-Construction Manhours [4800 h] → SSH-Construction Manhours [300.21 h] |
| 1.4.3.2.1.680 | Install fire protection system | 2012-06-25 → 2012-12-31 (+189d) | 2012-07-04 → 2013-01-05 (+185d) | 10d → 5d |  | 77.25d → -39.25d | 1.4.3.2.1.670 SS+6d → 1.4.3.2.1.670 FF+2d | resources SSH-Construction Manhours [3200 h] → SSH-Construction Manhours [199.44 h] |
| 1.4.3.2.1.685 | Install fire extinguishers | 2012-07-02 → 2013-01-01 (+183d) | 2012-07-11 → 2013-01-06 (+179d) | 10d → 5d |  | 109d → -8.5d | 1.4.3.2.1.680 SS+8d → 1.4.3.2.1.680 FF+2d | resources SSH-Construction Manhours [3200 h] → SSH-Construction Manhours [199.44 h] |
| 1.4.3.2.1.690 | Testing & balancing of HVAC system | 2012-08-11 → 2013-02-14 (+187d) | 2012-08-28 → 2013-03-04 (+188d) |  |  | 77.25d → -69.8d | 1.4.3.2.1.620, 1.4.3.2.1.685 SS+10d, 1.4.3.2.1.530 → 1.4.3.2.1.620, 1.4.3.2.1.685 FF, 1.4.3.2.1.530, 1.4.3.2.1.460 FF | resources SSH-Construction Manhours [9000 h] → SSH-Construction Manhours [561.78 h] |
| 6 | **Electrical Works** | 2012-03-17 → 2012-05-09 (+53d) | 2012-07-26 → 2013-02-17 (+206d) |  |  |  |  |  |
| 1.4.3.2.1.710 | Install electrical conduits / fittings | 2012-03-17 → 2012-05-09 A (+53d) | 2012-04-14 → 2012-12-08 (+238d) |  | 0% → 10% | 51.5d → -103d | 1.4.3.2.1.310 FS+12.5d, 1.3.1.23.030 → 1.4.3.2.1.630 FF | resources SSH-Construction Manhours [19171.6 h] → SSH-Construction Manhours [1196.12 h] |
| 1.4.3.2.1.720 | Install cables / wires | 2012-03-26 → 2012-11-13 (+232d) | 2012-04-18 → 2012-12-06 (+232d) |  |  | 121.75d → -86d |  | resources SSH-Construction Manhours [16000 h] → SSH-Construction Manhours [997.73 h] |
| 1.4.3.2.1.730 | Install lighting fixtures | 2012-04-09 → 2012-11-27 (+232d) | 2012-05-02 → 2012-12-20 (+232d) |  |  | 121.75d → -86d |  | resources SSH-Construction Manhours [10000 h] → SSH-Construction Manhours [623.91 h] |
| 1.4.3.2.1.740 | Install panelboards | 2012-04-23 → 2012-12-11 (+232d) | 2012-05-02 → 2012-12-20 (+232d) |  |  | 121.75d → -86d | 1.4.3.2.1.730 SS+15d → 1.4.3.2.1.730 FF | resources SSH-Construction Manhours [4000 h] → SSH-Construction Manhours [249.56 h] |
| 1.4.3.2.1.750 | Install lighting control panel | 2012-04-28 → 2012-12-15 (+231d) | 2012-05-07 → 2012-12-24 (+231d) |  |  | 121.75d → -86d | 1.4.3.2.1.740 SS+5d → 1.4.3.2.1.740 FF+4d | resources SSH-Construction Manhours [4000 h] → SSH-Construction Manhours [249.56 h] |
| 1.4.3.2.1.760 | Install annunciator DC distribution panel | 2012-05-02 → 2012-12-15 (+227d) | 2012-05-16 → 2012-12-29 (+227d) |  |  | 121.75d → -86d | 1.4.3.2.1.750 SS+5d → 1.4.3.2.1.750 FF+5d | resources SSH-Construction Manhours [8400 h] → SSH-Construction Manhours [523.66 h] |
| 1.4.3.2.1.770 | Install battery bank / battery charger/UPS | 2012-05-07 → 2012-12-18 (+225d) | 2012-05-21 → 2013-01-01 (+225d) |  |  | 121.75d → -86d | 1.4.3.2.1.760 SS+5d, 1.3.2.14.030 → 1.4.3.2.1.760 FF+4d, 1.3.2.14.030 | resources SSH-Construction Manhours [8400 h] → SSH-Construction Manhours [523.66 h] |
| 1.4.3.2.1.780 | Install inventor | 2012-05-12 → 2012-12-27 (+229d) | 2012-05-21 → 2013-01-05 (+229d) |  |  | 121.75d → -86d | 1.4.3.2.1.770 SS+5d → 1.4.3.2.1.770 FF+4d, 1.3.2.26.030 | resources SSH-Construction Manhours [4800 h] → SSH-Construction Manhours [300.21 h] |
| 1.4.3.2.1.800 | Install disconnect switches | 2012-05-21 → 2012-12-30 (+223d) | 2012-06-04 → 2013-01-13 (+223d) |  |  | 121.75d → -86d | 1.4.3.2.1.790 SS+5d → 1.4.3.2.1.790 FF+4d | resources SSH-Construction Manhours [7200 h] → SSH-Construction Manhours [449.53 h] |

| ID | Task | Start | Finish | Duration | Complete | Total float | Predecessors | Other |
| --- | --- | --- | --- | --- | --- | --- | --- | --- |
| 1.4.3.2.1.790 | Install inventor distribution panel | 2012-05-16 → 2012-12-31 (+229d) | 2012-05-26 → 2013-01-09 (+228d) |  |  | 121.75d → -86d | 1.4.3.2.1.780 SS+5d → 1.4.3.2.1.780 FF+4d | resources SSH-Construction Manhours [4800 h] → SSH-Construction Manhours [300.21 h] |
| 1.4.3.2.1.810 | Install FAS-Fire alarm system & FACP with detection sytem | 2012-05-26 → 2013-01-02 (+221d) | 2012-06-09 → 2013-01-16 (+221d) |  |  | 121.75d → -86d | 1.4.3.2.1.800 SS+5d → 1.4.3.2.1.800 FF+4d | resources SSH-Construction Manhours [7200 h] → SSH-Construction Manhours [449.53 h] |
| 1.4.3.2.1.820 | Install grounding system | 2012-05-30 → 2013-01-06 (+221d) | 2012-06-13 → 2013-01-20 (+221d) |  |  | 121.75d → -86d | 1.4.3.2.1.810 SS+5d → 1.4.3.2.1.810 FF+4d | resources SSH-Construction Manhours [7200 h] → SSH-Construction Manhours [449.53 h] |
| 1.4.3.2.1.830 | Install circuit breaker | 2012-06-04 → 2013-01-10 (+220d) | 2012-06-18 → 2013-01-23 (+219d) |  |  | 121.75d → -86d | 1.4.3.2.1.820 SS+5d → 1.4.3.2.1.820 FF+4d | resources SSH-Construction Manhours [7200 h] → SSH-Construction Manhours [449.53 h] |
| 1.4.3.2.1.840 | Install ATS | 2012-06-09 → 2013-01-14 (+219d) | 2012-06-23 → 2013-01-28 (+219d) |  |  | 121.75d → -86d | 1.4.3.2.1.830 SS+5d → 1.4.3.2.1.830 FF+4d, 1.3.2.9.030 | resources SSH-Construction Manhours [7200 h] → SSH-Construction Manhours [449.53 h] |
| 1.4.3.2.1.850 | Install moduler rectifier | 2012-06-13 → 2013-01-17 (+218d) | 2012-06-27 → 2013-01-31 (+218d) |  |  | 121.75d → -86d | 1.4.3.2.1.840 SS+5d → 1.4.3.2.1.840 FF+4d, 1.3.2.26.030 | was named Install rectifier; resources SSH-Construction Manhours [7200 h] → SSH-Construction Manhours [449.53 h] |
| 1.4.3.2.1.860 | Install 500kva generator | 2012-06-18 → 2013-01-21 (+217d) | 2012-07-02 → 2013-02-04 (+217d) |  |  | 121.75d → -86d | 1.4.3.2.1.850 SS+5d → 1.4.3.2.1.850 FF+4d | resources SSH-Construction Manhours [7200 h] → SSH-Construction Manhours [449.53 h] |
| 1.4.3.2.1.870 | Install 300kva, 13.8kv XFR | 2012-06-23 → 2013-01-24 (+215d) | 2012-07-07 → 2013-02-07 (+215d) |  |  | 121.75d → -86d | 1.4.3.2.1.860 SS+5d → 1.4.3.2.1.860 FF+4d | resources SSH-Construction Manhours [6000 h] → SSH-Construction Manhours [373.82 h] |
| 1.4.3.2.1.880 | Install switchboards | 2012-06-27 → 2013-01-29 (+216d) | 2012-07-11 → 2013-02-11 (+215d) |  |  | 121.75d → -86d | 1.4.3.2.1.870 SS+5d → 1.4.3.2.1.870 FF+4d | resources SSH-Construction Manhours [4800 h] → SSH-Construction Manhours [300.21 h] |
| 1.4.3.2.1.890 | Testing/commissioning electrical system | 2012-07-03 → 2013-02-03 (+215d) | 2012-07-26 → 2013-02-17 (+206d) | 25d → 15d |  | 121.75d → -86d |  | resources SSH-Construction Manhours [6000 h] → SSH-Construction Manhours [373.82 h] |
| 1.4.3.2.1.910 | Install comm cable vault & accs | 2012-04-14 → 2012-12-09 (+239d) | 2012-05-26 → 2013-01-19 (+238d) |  |  | 51.5d → -103d | 1.4.3.2.1.710, 1.3.2.24.030 → 1.4.3.2.1.710, 1.3.3.6.030, 1.3.3.7.030, 1.3.3.18.030 | was named Install comm conduits / fittings; resources SSH-Construction Manhours [28757.4 h] → SSH-Construction Manhours [1798.62 h] |
| 1.4.3.2.1.920 | Install comm MDF | 2012-05-12 → 2013-01-06 (+239d) | 2012-06-04 → 2013-01-28 (+238d) |  |  | 51.5d → -103d |  | was named Install comm vault / accs; resources SSH-Construction Manhours [24000 h] → SSH-Construction Manhours [1499.98 h] |
| 1.4.3.2.1.930 | Install comm equipments / accs | 2012-05-26 → 2013-01-20 (+239d) | 2012-06-18 → 2013-02-11 (+238d) |  |  | 51.5d → -103d | 1.4.3.2.1.920 SS+15d, 1.3.2.18.030 → 1.4.3.2.1.920 SS+15d, 1.3.3.8.030 | resources SSH-Construction Manhours [16000 h] → SSH-Construction Manhours [1003.99 h] |
| 1.4.3.2.1.940 | Install comm outlets / accs | 2012-06-04 → 2013-01-29 (+239d) | 2012-06-27 → 2013-02-20 (+238d) |  |  | 51.5d → -103d |  | resources SSH-Construction Manhours [20000 h] → SSH-Construction Manhours [1248.86 h] |
| 8 | **Communication Works at Exch Bldg #1 with existing network** | 2012-06-27 → 2012-12-13 (+169d) | 2012-09-05 → 2013-02-20 (+168d) |  |  |  |  |  |
| 1.4.3.2.1.1010 | Install comm equip to connect with existing exch bldg | 2012-06-27 → 2012-12-13 (+169d) | 2012-09-05 → 2013-02-20 (+168d) |  |  | 51.5d → -103d | 1.4.3.2.1.940, 1.3.3.3.030 → 1.4.3.2.1.940 FF, 1.3.3.14.030 FF | resources SSH-Construction Manhours [28800 h] → SSH-Construction Manhours [1804.37 h] |
| 9 | **Communication Works at Exch Bldg #1 with security HQ bldg** | 2012-07-09 → 2012-12-10 (+154d) | 2012-09-20 → 2013-02-20 (+153d) |  |  |  |  |  |
| 1.4.3.2.1.1110 | Install comm equip to connect with security HQ | 2012-07-09 → 2012-12-10 (+154d) | 2012-09-20 → 2013-02-20 (+153d) |  |  | 51.5d → -103d | 1.4.3.2.1.1010 SS+12.5d → 1.4.3.2.1.1010 FF | resources SSH-Construction Manhours [28800 h] → SSH-Construction Manhours [1804.37 h] |
| 10 | **Communication Works at Exch Bldg #1 with exst bsns data center** | 2012-08-14 → 2012-12-27 (+135d) | 2012-09-06 → 2013-02-20 (+167d) |  |  |  |  |  |
| 1.4.3.2.1.1210 | Install comm equip to connect with exst business center | 2012-08-14 → 2012-12-27 (+135d) | 2012-09-06 → 2013-02-20 (+167d) | 25d → 60d |  | 66.75d → -57.5d | 1.4.3.2.1.1110 SS+10d, 1.4.3.2.1.460 → 1.4.3.2.1.1110 FF | resources SSH-Construction Manhours [8000 h] → SSH-Construction Manhours [537.76 h] |
| 11 | **SACS System** | 2012-08-14 → 2012-12-09 (+117d) | 2012-10-04 → 2013-03-05 (+152d) |  |  |  |  |  |
| 1.4.3.2.1.1310 | Install SACS System & access | 2012-08-14 → 2012-12-09 (+117d) | 2012-09-25 → 2013-02-02 (+130d) | 45d → 60d |  | 69d → -83d | 1.4.3.2.1.1010 SS, 1.3.3.1.030 → 1.3.3.15.030 FF, 1.4.3.2.1.910 SS | was named Install access switches; resources SSH-Construction Manhours [27649.4 h] → SSH-Construction Manhours [1724.49 h] |
| 1.4.3.2.1.1320 | Install miscellaneous items | 2012-08-23 → 2012-12-09 (+108d) | 2012-10-04 → 2013-02-02 (+121d) | 45d → 60d |  | 69d → -83d | 1.4.3.2.1.1310 SS+10d, 1.4.3.2.1.1480, 1.4.3.2.1.1520 → 1.4.3.2.1.1310 FF | resources SSH-Construction Manhours [27649.4 h] → SSH-Construction Manhours [1724.49 h] |
| 1.4.3.2.1.1330 | Testing / commissioning SACS system | 2012-09-20 → 2013-01-27 (+129d) | 2012-09-30 → 2013-02-24 (+147d) | 10d → 30d |  | 51.5d → -103d | 1.4.3.2.1.1320 SS+12.5d, 1.4.2.8.1.110 SS+12.5d, 1.4.3.2.1.1010, 1.4.3.2.1.1110 → 1.4.3.2.1.1320 FF+3d, 1.4.3.2.1.1010 FF+3d, 1.4.3.2.1.1110 FF+3d | was named Testing / commissioning & Energize SACS system; resources SSH-Construction Manhours [2400 h] → SSH-Construction Manhours [149.32 h] |
| 1.4.3.2.1.1340 | Energize SACS System & Communication Bldg | 2012-09-20 → 2013-02-24 (+157d) | 2012-09-30 → 2013-03-05 (+156d) |  |  | 51.5d → -103d | 1.4.3.2.1.1330 SS, 1.4.3.2.1.1010, 1.4.3.2.1.1110, 1.4.3.2.1.1210, 1.4.3.2.1.690, 1.4.3.1.1.570, M2.10 → 1.4.3.2.1.1330 | resources SSH-Construction Manhours [2400 h] → SSH-Construction Manhours [149.32 h] |
| 12 | **Pavement / Parking / Signs / Markings** | 2012-02-27 → 2012-12-02 (+279d) | 2012-04-30 → 2013-02-02 (+278d) |  |  |  |  |  |
| 1.4.3.2.1.1410 | Install gravel pavement | 2012-02-27 → 2012-12-02 (+279d) | 2012-03-26 → 2012-12-30 (+279d) |  |  | 169.25d → -138.75d | 1.4.3.2.1.320 SS, 1.4.3.2.1.030 → 1.4.3.2.1.320 FS+30d, 1.4.3.2.1.030 | resources SSH-Construction Manhours [12000.7 h] → SSH-Construction Manhours [748.16 h] |
| 1.4.3.2.1.1420 | Install 150mm thk concrete pavement | 2012-03-06 → 2012-12-09 (+278d) | 2012-04-03 → 2013-01-06 (+278d) |  |  | 169.25d → -94.75d |  | resources SSH-Construction Manhours [16800 h] → SSH-Construction Manhours [1047.85 h] |
| 1.4.3.2.1.1430 | Install 500mm thk general fill | 2012-03-13 → 2012-12-17 (+279d) | 2012-04-10 → 2013-01-14 (+279d) |  |  | 169.25d → -94.75d |  | resources SSH-Construction Manhours [12000 h] → SSH-Construction Manhours [748.16 h] |
| 1.4.3.2.1.1440 | Install 200mm thk aggregate base coarse | 2012-03-21 → 2012-12-24 (+278d) | 2012-04-17 → 2013-01-21 (+279d) |  |  | 169.25d → -94.75d |  | resources SSH-Construction Manhours [19200 h] → SSH-Construction Manhours [1207.09 h] |
| 1.4.3.2.1.1450 | Install 120mm thk asphalt concrete pavement | 2012-03-28 → 2013-01-01 (+279d) | 2012-04-21 → 2013-01-23 (+277d) |  |  | 169.25d → -94.75d |  | resources SSH-Construction Manhours [16000 h] → SSH-Construction Manhours [997.73 h] |
| 1.4.3.2.1.1460 | Install shaded parking space | 2012-04-04 → 2013-01-08 (+279d) | 2012-04-28 → 2013-01-31 (+278d) |  |  | 193.5d → -94.75d |  | resources SSH-Construction Manhours [12800 h] → SSH-Construction Manhours [798.29 h] |
| 1.4.3.2.1.1470 | Install road / park markings | 2012-04-04 → 2013-01-08 (+279d) | 2012-04-23 → 2013-01-27 (+279d) |  |  | 193.5d → -94.75d |  | resources SSH-Construction Manhours [12800 h] → SSH-Construction Manhours [798.29 h] |
| 1.4.3.2.1.1480 | Install road / park signs | 2012-04-12 → 2013-01-15 (+278d) | 2012-04-30 → 2013-02-02 (+278d) |  |  | 193.5d → -94.75d |  | resources SSH-Construction Manhours [7680 h] → SSH-Construction Manhours [489.73 h] |
| 13 | **Perimeter Fence System** | 2012-04-01 → 2013-01-05 (+279d) | 2012-05-22 → 2013-02-25 (+279d) |  |  |  |  |  |
| 1.4.3.2.1.1510 | Install perimeter fence type SSD-1 | 2012-04-01 → 2013-01-05 (+279d) | 2012-05-13 → 2013-02-16 (+279d) |  |  | 169.25d → -94d |  | resources SSH-Construction Manhours [36000 h] → SSH-Construction Manhours [2246.58 h] |
| 1.4.3.2.1.1520 | Install perimeter gate SSD-1, 10.5m widex2 leaf | 2012-04-29 → 2013-02-02 (+279d) | 2012-05-22 → 2013-02-25 (+279d) |  |  | 169.25d → -94.75d | 1.4.3.2.1.1510 SS+30d → 1.4.3.2.1.1510 SS+30d, 1.4.3.2.1.1480 | resources SSH-Construction Manhours [20000 h] → SSH-Construction Manhours [1248.86 h] |
| 3 | **Toilet Facilities (3 nos)** | 2012-03-17 → 2012-05-22 (+66d) | 2012-11-20 → 2013-05-07 (+168d) |  |  |  |  |  |
| 1 | **Toilet # 1** | 2012-03-17 → 2012-05-22 (+66d) | 2012-11-04 → 2013-04-14 (+161d) |  |  |  |  |  |
| 1 | **Civil works** | 2012-03-17 → 2012-05-24 (+68d) | 2012-08-14 → 2013-01-29 (+168d) |  |  |  |  |  |
| 1.4.3.3.1.1.010 | Excavation leveling & compaction for toilet # 1 bldg fdns | 2012-03-17 → 2012-05-24 A (+68d) | 2012-03-25 → 2012-06-03 A (+70d) |  | 0% → 100% | 37.75d → none | 1.2.6.200 FS+237.5d, 1.4.3.1.1.140 SS → 1.2.6.200 FS+100d, 1.4.3.2.1.1410 SS | resources SSH-Construction Manhours [4800 h]; Excavator [80 h]; Dump Truck [80 h] → SSH-Construction Manhours [206.84 h]; Excavator [80 h]; Dump Truck [80 h] |
| 1.4.3.3.1.1.020 | Backfilling/compation | 2012-08-02 → 2013-01-17 (+168d) | 2012-08-14 → 2013-01-29 (+168d) |  |  | 207.75d → -52.25d |  | resources SSH-Construction Manhours [3000 h]; Dump Truck [100 h]; Compactor [100 h] → SSH-Construction Manhours [132.77 h]; Dump Truck [100 h]; Compactor [100 h] |
| 2 | **Structural works** | 2012-03-21 → 2012-05-22 (+62d) | 2012-08-13 → 2013-01-28 (+168d) |  |  |  |  |  |
| 1.4.3.3.1.1.030 | Install lean concrete for reinforced fdns for toilet bldg | 2012-03-21 → 2012-05-22 A (+62d) | 2012-04-08 → 2012-06-09 A (+62d) |  | 0% → 100% | 122d → none | 1.4.3.3.1.1.010 SS+6d → 1.4.3.3.1.1.010 FF+6d | resources SSH-Construction Manhours [10500 h] → SSH-Construction Manhours [380.14 h] |
| 1.4.3.3.1.1.040 | Install reinforced fdns for toilet bldg | 2012-04-19 → 2012-06-20 A (+62d) | 2012-05-19 → 2012-07-19 A (+61d) |  | 0% → 100% | 139.75d → none |  | resources SSH-Construction Manhours [17500 h] → SSH-Construction Manhours [633.79 h] |
| 1.4.3.3.1.1.050 | Install reinforced columns | 2012-05-19 → 2012-07-14 A (+56d) | 2012-06-30 → 2012-12-08 (+161d) |  | 0% → 85% | 139.75d → -114d | 1.4.3.3.1.1.040 SS+31.25d → 1.4.3.3.1.1.040 SS+25d | resources SSH-Construction Manhours [21600 h] → SSH-Construction Manhours [768.66 h] |
| 1.4.3.3.1.1.060 | Install reinforced roof beams | 2012-06-17 → 2012-12-02 (+168d) | 2012-07-29 → 2013-01-13 (+168d) |  |  | 139.75d → -114d | 1.4.3.3.1.1.050 SS+31.25d → 1.4.3.3.1.1.050 SS+30d | resources SSH-Construction Manhours [21600 h] → SSH-Construction Manhours [768.66 h] |
| 1.4.3.3.1.1.070 | Install reinforced roof slab /paraphet | 2012-07-01 → 2012-12-16 (+168d) | 2012-08-02 → 2013-01-17 (+168d) |  |  | 139.75d → -114d |  | resources SSH-Construction Manhours [16800 h] → SSH-Construction Manhours [768.66 h] |
| 1.4.3.3.1.1.080 | Install reinforced slab on grade | 2012-07-15 → 2012-12-30 (+168d) | 2012-08-13 → 2013-01-28 (+168d) |  |  | 172.5d → -87.5d |  | resources SSH-Construction Manhours [20000 h] → SSH-Construction Manhours [723.94 h] |
| 3 | **Architectural works** | 2012-08-02 → 2012-09-26 (+55d) | 2012-11-04 → 2013-04-14 (+161d) |  |  |  |  |  |
| 1 | **Masonry** | 2012-08-02 → 2012-09-26 (+55d) | 2012-09-10 → 2013-02-17 (+160d) |  |  |  |  |  |
| 1.4.3.3.1.1.090 | Install 200mm thk CMU blocks | 2012-08-02 → 2012-09-26 A (+55d) | 2012-09-01 → 2013-02-10 (+162d) |  | 0% → 20% | 139.75d → -114d |  | resources SSH-Construction Manhours [24000 h] → SSH-Construction Manhours [559.02 h] |
| 1.4.3.3.1.1.100 | Install 50 mm thk mortar plastering work | 2012-08-12 → 2013-01-19 (+160d) | 2012-09-10 → 2013-02-17 (+160d) |  |  | 142.5d → -109.25d |  | resources SSH-Construction Manhours [22500 h] → SSH-Construction Manhours [419.27 h] |
| 2 | **Floor Finishing** | 2012-09-24 → 2013-03-03 (+160d) | 2012-10-31 → 2013-04-09 (+160d) |  |  |  |  |  |
| 1.4.3.3.1.1.110 | Install cement toping work | 2012-09-24 → 2013-03-03 (+160d) | 2012-10-22 → 2013-03-31 (+160d) |  |  | 142.5d → -109.25d |  | resources SSH-Construction Manhours [15000 h] → SSH-Construction Manhours [542.95 h] |
| 1.4.3.3.1.1.120 | Install cermaic tiling work | 2012-10-03 → 2013-03-12 (+160d) | 2012-10-31 → 2013-04-09 (+160d) |  |  | 142.5d → -109.25d |  | resources SSH-Construction Manhours [15000 h] → SSH-Construction Manhours [542.95 h] |
| 3 | **Wall Finishing** | 2012-09-17 → 2013-02-24 (+160d) | 2012-10-29 → 2013-04-07 (+160d) |  |  |  |  |  |
| 1.4.3.3.1.1.130 | Install phenolic toilet partition | 2012-09-17 → 2013-02-24 (+160d) | 2012-10-16 → 2013-03-25 (+160d) |  |  | 142.5d → -109.25d |  | resources SSH-Construction Manhours [10000 h] → SSH-Construction Manhours [361.97 h] |
| 1.4.3.3.1.1.140 | Install ceramic tiling work | 2012-09-24 → 2013-03-03 (+160d) | 2012-10-22 → 2013-03-31 (+160d) |  |  | 142.5d → -109.25d |  | resources SSH-Construction Manhours [10000 h] → SSH-Construction Manhours [361.97 h] |
| 1.4.3.3.1.1.150 | Install textured painted work on CMU wall | 2012-09-30 → 2013-03-09 (+160d) | 2012-10-29 → 2013-04-07 (+160d) |  |  | 145.5d → -106.25d |  | resources SSH-Construction Manhours [12500 h] → SSH-Construction Manhours [452.81 h] |
| 4 | **Ceiling Finihsing** | 2012-09-10 → 2013-02-17 (+160d) | 2012-10-16 → 2013-03-25 (+160d) |  |  |  |  |  |
| 1.4.3.3.1.1.160 | Install gypsum board ceiling system | 2012-09-10 → 2013-02-17 (+160d) | 2012-10-03 → 2013-03-12 (+160d) |  |  | 142.5d → -109.25d |  | resources SSH-Construction Manhours [10000 h] → SSH-Construction Manhours [361.97 h] |
| 1.4.3.3.1.1.170 | Install painting work | 2012-09-17 → 2013-02-24 (+160d) | 2012-10-10 → 2013-03-19 (+160d) |  |  | 142.5d → -109.25d |  | resources SSH-Construction Manhours [8000 h] → SSH-Construction Manhours [289.99 h] |
| 1.4.3.3.1.1.180 | Install roof water proofing system & scrupper | 2012-09-24 → 2013-03-03 (+160d) | 2012-10-16 → 2013-03-25 (+160d) |  |  | 158.75d → -93d |  | resources SSH-Construction Manhours [8000 h] → SSH-Construction Manhours [289.99 h] |
| 5 | **Doors / Windows / Toilet Accs** | 2012-10-02 → 2013-03-12 (+161d) | 2012-11-04 → 2013-04-14 (+161d) |  |  |  |  |  |
| 1.4.3.3.1.1.190 | Install doors & windows | 2012-10-02 → 2013-03-12 (+161d) | 2012-10-25 → 2013-04-04 (+161d) |  |  | 139.75d → -114d |  | resources SSH-Construction Manhours [6400 h] → SSH-Construction Manhours [231.99 h] |
| 1.4.3.3.1.1.200 | Install toilet fixtures & accs | 2012-10-07 → 2013-03-17 (+161d) | 2012-10-30 → 2013-04-09 (+161d) |  |  | 139.75d → -114d |  | resources SSH-Construction Manhours [6400 h] → SSH-Construction Manhours [231.99 h] |
| 1.4.3.3.1.1.210 | Install cabinet & counter top | 2012-10-11 → 2013-03-21 (+161d) | 2012-11-04 → 2013-04-14 (+161d) |  |  | 139.75d → -114d |  | resources SSH-Construction Manhours [6400 h] → SSH-Construction Manhours [231.99 h] |
| 4 | **Electrical works** | 2012-08-02 → 2013-01-17 (+168d) | 2012-09-09 → 2013-02-24 (+168d) |  |  |  |  |  |
| 1.4.3.3.1.1.220 | Install electric conduits / fittings | 2012-08-02 → 2013-01-17 (+168d) | 2012-08-26 → 2013-02-10 (+168d) |  |  | 174d → -86d |  | resources SSH-Construction Manhours [3840 h] → SSH-Construction Manhours [139.76 h] |

| ID | Task | Start | Finish | Duration | Complete | Total float | Predecessors | Other |
| --- | --- | --- | --- | --- | --- | --- | --- | --- |
| 1.4.3.3.1.1.230 | Install cables / wires | 2012-08-06 → 2013-01-20 (+167d) | 2012-08-29 → 2013-02-12 (+167d) |  |  | 174d → -86d |  | resources SSH-Construction Manhours [3840 h] → SSH-Construction Manhours [139.76 h] |
| 1.4.3.3.1.1.240 | Install lighting fixtures | 2012-08-08 → 2013-01-23 (+168d) | 2012-09-01 → 2013-02-16 (+168d) |  |  | 174d → -86d |  | resources SSH-Construction Manhours [3840 h] → SSH-Construction Manhours [139.76 h] |
| 1.4.3.3.1.1.250 | Install panelboards | 2012-08-12 → 2013-01-26 (+167d) | 2012-09-03 → 2013-02-18 (+168d) |  |  | 174d → -86d |  | resources SSH-Construction Manhours [4000 h] → SSH-Construction Manhours [144.65 h] |
| 1.4.3.3.1.1.255 | Install Lighting control panel | 2012-08-13 → 2013-01-28 (+168d) | 2012-09-05 → 2013-02-20 (+168d) |  |  | 174d → -86d |  | resources SSH-Construction Manhours [4000 h] → SSH-Construction Manhours [144.65 h] |
| 1.4.3.3.1.1.260 | Install disconnect switches | 2012-08-15 → 2013-01-29 (+167d) | 2012-09-08 → 2013-02-21 (+166d) |  |  | 174d → -86d |  | resources SSH-Construction Manhours [4000 h] → SSH-Construction Manhours [144.65 h] |
| 1.4.3.3.1.1.270 | Install grounding system | 2012-08-16 → 2013-01-31 (+168d) | 2012-09-09 → 2013-02-24 (+168d) |  |  | 174d → -86d |  | resources SSH-Construction Manhours [4000 h] → SSH-Construction Manhours [144.65 h] |
| 5 | **Water Supply System** | 2012-09-01 → 2013-02-10 (+162d) | 2012-09-24 → 2013-03-05 (+162d) |  |  |  |  |  |
| 1.4.3.3.1.1.280 | Install water supply system | 2012-09-01 → 2013-02-10 (+162d) | 2012-09-24 → 2013-03-05 (+162d) |  |  | 139.75d → -114d |  | resources SSH-Construction Manhours [6000 h] → SSH-Construction Manhours [217.32 h] |
| 6 | **Sewer System** | 2012-09-09 → 2013-02-17 (+161d) | 2012-10-02 → 2013-03-12 (+161d) |  |  |  |  |  |
| 1.4.3.3.1.1.290 | Install sewer system | 2012-09-09 → 2013-02-17 (+161d) | 2012-10-02 → 2013-03-12 (+161d) |  |  | 139.75d → -114d |  | resources SSH-Construction Manhours [6000 h] → SSH-Construction Manhours [217.32 h] |
| 7 | **HVAC System** | 2012-10-02 → 2013-03-12 (+161d) | 2012-10-25 → 2013-04-04 (+161d) |  |  |  |  |  |
| 1.4.3.3.1.1.300 | Install HVAC system | 2012-10-02 → 2013-03-12 (+161d) | 2012-10-25 → 2013-04-04 (+161d) |  |  | 149.75d → -104d |  | resources SSH-Construction Manhours [8000 h] → SSH-Construction Manhours [289.99 h] |
| 8 | **Toilet # 2** | 2012-04-04 → 2012-06-03 (+60d) | 2012-11-04 → 2013-05-07 (+184d) |  |  |  |  |  |
| 1 | **Civil works** | 2012-04-04 → 2012-06-03 (+60d) | 2012-08-06 → 2013-02-16 (+194d) |  |  |  |  |  |
| 1.4.3.3.1.2.010 | Excavation leveling & compaction for toilet # 2 bldg fdns | 2012-04-04 → 2012-06-03 A (+60d) | 2012-04-14 → 2012-06-12 A (+59d) |  | 0% → 100% | 122d → none | 1.4.3.3.1.1.030 SS+15d → 1.4.3.3.1.1.010 | resources SSH-Construction Manhours [15000 h]; Excavator [80 h]; Dump Truck [80 h] → SSH-Construction Manhours [542.95 h]; Excavator [80 h]; Dump Truck [80 h] |
| 1.4.3.3.1.2.020 | Backfilling/compation | 2012-07-25 → 2013-02-04 (+194d) | 2012-08-06 → 2013-02-16 (+194d) |  |  | 210.5d → -77.25d |  | resources SSH-Construction Manhours [9000 h]; Dump Truck [100 h]; Compactor [100 h] → SSH-Construction Manhours [325.63 h]; Dump Truck [100 h]; Compactor [100 h] |
| 2 | **Structural works** | 2012-04-10 → 2012-06-03 (+54d) | 2012-08-23 → 2013-03-05 (+194d) |  |  |  |  |  |
| 1.4.3.3.1.2.030 | Install lean concrete for reinforced fdns for toilet bldg | 2012-04-10 → 2012-06-03 A (+54d) | 2012-04-28 → 2012-06-20 A (+53d) |  | 0% → 100% | 122d → none | 1.4.3.3.1.2.010 SS+6d → 1.4.3.3.1.2.010 SS | resources SSH-Construction Manhours [12000 h] → SSH-Construction Manhours [434.64 h] |
| 1.4.3.3.1.2.040 | Install reinforced fdns for toilet bldg | 2012-04-24 → 2012-06-17 A (+54d) | 2012-05-23 → 2012-07-16 A (+54d) |  | 0% → 100% | 139d → none |  | resources SSH-Construction Manhours [17500 h] → SSH-Construction Manhours [633.79 h] |
| 1.4.3.3.1.2.050 | Install reinforced columns | 2012-05-08 → 2012-07-01 A (+54d) | 2012-06-19 → 2012-08-12 A (+54d) |  | 0% → 100% | 139d → none |  | resources SSH-Construction Manhours [21600 h] → SSH-Construction Manhours [768.66 h] |
| 1.4.3.3.1.2.060 | Install reinforced roof beams | 2012-05-22 → 2012-12-02 (+194d) | 2012-07-08 → 2013-01-17 (+193d) |  |  | 139d → -138.75d |  | resources SSH-Construction Manhours [24000 h] → SSH-Construction Manhours [768.66 h] |
| 1.4.3.3.1.2.070 | Install reinforced roof slab /paraphet | 2012-06-20 → 2012-12-31 (+194d) | 2012-07-25 → 2013-02-04 (+194d) |  |  | 139d → -138.75d |  | resources SSH-Construction Manhours [19171.6 h] → SSH-Construction Manhours [768.66 h] |
| 1.4.3.3.1.2.080 | Install reinforced slab on grade | 2012-07-19 → 2013-01-29 (+194d) | 2012-08-23 → 2013-03-05 (+194d) |  |  | 181.75d → -106d |  | resources SSH-Construction Manhours [12781.1 h] → SSH-Construction Manhours [462.59 h] |
| 3 | **Architectural works** | 2012-07-25 → 2012-09-17 (+54d) | 2012-11-04 → 2013-05-07 (+184d) |  |  |  |  |  |
| 1 | **Masonry** | 2012-07-25 → 2012-09-17 (+54d) | 2012-08-27 → 2013-02-27 (+184d) |  |  |  |  |  |
| 1.4.3.3.1.2.090 | Install 200mm thk CMU blocks | 2012-07-25 → 2012-09-17 A (+54d) | 2012-08-18 → 2013-02-23 (+189d) |  | 0% → 20% | 139d → -138.75d |  | resources SSH-Construction Manhours [16000 h] → SSH-Construction Manhours [579.99 h] |
| 1.4.3.3.1.2.100 | Install 50 mm thk mortar plastering work | 2012-08-04 → 2013-02-04 (+184d) | 2012-08-27 → 2013-02-27 (+184d) |  |  | 139d → -138.75d |  | resources SSH-Construction Manhours [12000 h] → SSH-Construction Manhours [436.74 h] |
| 2 | **Floor Finishing** | 2012-10-02 → 2013-04-04 (+184d) | 2012-11-04 → 2013-05-07 (+184d) |  |  |  |  |  |
| 1.4.3.3.1.2.110 | Install cement toping work | 2012-10-02 → 2013-04-04 (+184d) | 2012-10-25 → 2013-04-28 (+185d) |  |  | 139d → -138.75d |  | resources SSH-Construction Manhours [12000 h] → SSH-Construction Manhours [434.64 h] |
| 1.4.3.3.1.2.120 | Install cermaic tiling work | 2012-10-11 → 2013-04-14 (+185d) | 2012-11-04 → 2013-05-07 (+184d) |  |  | 139d → -138.75d |  | resources SSH-Construction Manhours [12000 h] → SSH-Construction Manhours [434.64 h] |
| 3 | **Wall Finishing** | 2012-09-26 → 2013-03-30 (+185d) | 2012-11-01 → 2013-05-05 (+185d) |  |  |  |  |  |
| 1.4.3.3.1.2.130 | Install phenolic toilet partition | 2012-09-26 → 2013-03-30 (+185d) | 2012-10-20 → 2013-04-21 (+183d) |  |  | 139d → -138.75d |  | resources SSH-Construction Manhours [9600 h] → SSH-Construction Manhours [347.29 h] |
| 1.4.3.3.1.2.140 | Install ceramic tiling work | 2012-10-02 → 2013-04-04 (+184d) | 2012-10-25 → 2013-04-28 (+185d) |  |  | 139d → -138.75d |  | resources SSH-Construction Manhours [9600 h] → SSH-Construction Manhours [347.29 h] |
| 1.4.3.3.1.2.150 | Install textured painted work on CMU wall | 2012-10-09 → 2013-04-11 (+184d) | 2012-11-01 → 2013-05-05 (+185d) |  |  | 142d → -135.75d |  | resources SSH-Construction Manhours [9600 h] → SSH-Construction Manhours [347.29 h] |
| 4 | **Ceiling Finihsing** | 2012-08-27 → 2013-02-27 (+184d) | 2012-10-02 → 2013-04-04 (+184d) |  |  |  |  |  |
| 1.4.3.3.1.2.160 | Install gypsum board ceiling system | 2012-08-27 → 2013-02-27 (+184d) | 2012-09-19 → 2013-03-23 (+185d) |  |  | 139d → -138.75d |  | resources SSH-Construction Manhours [9600 h] → SSH-Construction Manhours [347.29 h] |
| 1.4.3.3.1.2.170 | Install painting work | 2012-09-03 → 2013-03-06 (+184d) | 2012-09-26 → 2013-03-28 (+183d) |  |  | 139d → -138.75d |  | resources SSH-Construction Manhours [9600 h] → SSH-Construction Manhours [347.29 h] |
| 1.4.3.3.1.2.180 | Install roof water proofing system & scrupper | 2012-09-09 → 2013-03-12 (+184d) | 2012-10-02 → 2013-04-04 (+184d) |  |  | 174d → -103.75d |  | resources SSH-Construction Manhours [9600 h] → SSH-Construction Manhours [347.29 h] |
| 5 | **Doors / Windows / Toilet Accs** | 2012-09-18 → 2013-03-25 (+188d) | 2012-10-20 → 2013-04-27 (+189d) |  |  |  |  |  |
| 1.4.3.3.1.2.190 | Install doors & windows | 2012-09-18 → 2013-03-25 (+188d) | 2012-10-10 → 2013-04-17 (+189d) |  |  | 155d → -127.75d |  | resources SSH-Construction Manhours [4000 h] → SSH-Construction Manhours [144.65 h] |
| 1.4.3.3.1.2.200 | Install toilet fixtures & accs | 2012-09-23 → 2013-03-30 (+188d) | 2012-10-15 → 2013-04-22 (+189d) |  |  | 155d → -127.75d |  | resources SSH-Construction Manhours [4000 h] → SSH-Construction Manhours [144.65 h] |
| 1.4.3.3.1.2.210 | Install cabinet & counter top | 2012-09-27 → 2013-04-03 (+188d) | 2012-10-20 → 2013-04-27 (+189d) |  |  | 155d → -127.75d |  | resources SSH-Construction Manhours [4000 h] → SSH-Construction Manhours [144.65 h] |
| 4 | **Electrical works** | 2012-07-25 → 2013-02-04 (+194d) | 2012-09-01 → 2013-03-13 (+193d) |  |  |  |  |  |
| 1.4.3.3.1.2.220 | Install electric conduits / fittings | 2012-07-25 → 2013-02-04 (+194d) | 2012-08-18 → 2013-02-27 (+193d) |  |  | 183d → -104.75d |  | resources SSH-Construction Manhours [4000 h] → SSH-Construction Manhours [144.65 h] |
| 1.4.3.3.1.2.230 | Install cables / wires | 2012-07-29 → 2013-02-06 (+192d) | 2012-08-20 → 2013-03-02 (+194d) |  |  | 183d → -104.75d |  | resources SSH-Construction Manhours [4000 h] → SSH-Construction Manhours [144.65 h] |
| 1.4.3.3.1.2.240 | Install lighting fixtures | 2012-07-31 → 2013-02-10 (+194d) | 2012-08-23 → 2013-03-05 (+194d) |  |  | 183d → -104.75d |  | resources SSH-Construction Manhours [4000 h] → SSH-Construction Manhours [144.65 h] |
| 1.4.3.3.1.2.250 | Install panelboards | 2012-08-02 → 2013-02-12 (+194d) | 2012-08-26 → 2013-03-07 (+193d) |  |  | 183d → -104.75d |  | resources SSH-Construction Manhours [4000 h] → SSH-Construction Manhours [144.65 h] |
| 1.4.3.3.1.2.255 | Install lighting control panel | 2012-08-05 → 2013-02-14 (+193d) | 2012-08-28 → 2013-03-10 (+194d) |  |  | 183d → -104.75d |  | resources SSH-Construction Manhours [4000 h] → SSH-Construction Manhours [144.65 h] |
| 1.4.3.3.1.2.260 | Install disconnect switches | 2012-08-07 → 2013-02-16 (+193d) | 2012-08-29 → 2013-03-11 (+194d) |  |  | 183d → -104.75d |  | resources SSH-Construction Manhours [4000 h] → SSH-Construction Manhours [144.65 h] |
| 1.4.3.3.1.2.270 | Install grounding system | 2012-08-08 → 2013-02-18 (+194d) | 2012-09-01 → 2013-03-13 (+193d) |  |  | 183d → -104.75d |  | resources SSH-Construction Manhours [4000 h] → SSH-Construction Manhours [144.65 h] |
| 5 | **Water Supply System** | 2012-08-18 → 2013-02-23 (+189d) | 2012-09-10 → 2013-03-18 (+189d) |  |  |  |  |  |
| 1.4.3.3.1.2.280 | Install water supply system | 2012-08-18 → 2013-02-23 (+189d) | 2012-09-10 → 2013-03-18 (+189d) |  |  | 155d → -127.75d |  | resources SSH-Construction Manhours [4792.91 h] → SSH-Construction Manhours [173.3 h] |
| 6 | **Sewer System** | 2012-08-26 → 2013-03-02 (+188d) | 2012-09-17 → 2013-03-25 (+189d) |  |  |  |  |  |
| 1.4.3.3.1.2.290 | Install sewer system | 2012-08-26 → 2013-03-02 (+188d) | 2012-09-17 → 2013-03-25 (+189d) |  |  | 155d → -127.75d |  | resources SSH-Construction Manhours [4792.91 h] → SSH-Construction Manhours [173.3 h] |
| 7 | **HVAC System** | 2012-09-18 → 2013-03-25 (+188d) | 2012-10-10 → 2013-04-17 (+189d) |  |  |  |  |  |
| 1.4.3.3.1.2.300 | Install HVAC system | 2012-09-18 → 2013-03-25 (+188d) | 2012-10-10 → 2013-04-17 (+189d) |  |  | 165d → -117.75d |  | resources SSH-Construction Manhours [3195.27 h] → SSH-Construction Manhours [116 h] |
| 2 | **Toilet # 3** | 2012-04-28 → 2012-06-12 (+45d) | 2012-11-20 → 2013-04-21 (+152d) |  |  |  |  |  |
| 1 | **Civil works** | 2012-04-28 → 2012-06-12 (+45d) | 2012-08-26 → 2013-01-20 (+147d) |  |  |  |  |  |
| 1.4.3.3.1.3.010 | Excavation leveling & compaction for toilet # 3 bldg fdns | 2012-04-28 → 2012-06-12 A (+45d) | 2012-05-07 → 2012-06-21 A (+45d) |  | 0% → 100% | 122d → none | 1.4.3.3.1.2.030 → 1.4.3.3.1.2.010 | resources SSH-Construction Manhours [4800 h]; Excavator [80 h]; Dump Truck [80 h] → SSH-Construction Manhours [174.69 h]; Excavator [80 h]; Dump Truck [80 h] |
| 1.4.3.3.1.3.020 | Backfilling/compation | 2012-08-14 → 2013-01-08 (+147d) | 2012-08-26 → 2013-01-20 (+147d) |  |  | 189.5d → -48.5d |  | resources SSH-Construction Manhours [4000 h]; Dump Truck [100 h]; Compactor [100 h] → SSH-Construction Manhours [144.65 h]; Dump Truck [100 h]; Compactor [100 h] |
| 2 | **Structural works** | 2012-05-03 → 2012-06-18 (+46d) | 2012-08-28 → 2013-02-10 (+166d) |  |  |  |  |  |
| 1.4.3.3.1.3.030 | Install lean concrete for reinforced fdns for toilet bldg | 2012-05-03 → 2012-06-18 A (+46d) | 2012-05-21 → 2012-07-05 A (+45d) |  | 0% → 100% | 122d → none |  | resources SSH-Construction Manhours [7500 h] → SSH-Construction Manhours [272.52 h] |
| 1.4.3.3.1.3.040 | Install reinforced fdns for toilet bldg | 2012-05-17 → 2012-07-02 A (+46d) | 2012-06-16 → 2012-07-31 A (+45d) |  | 0% → 100% | 122d → none |  | resources SSH-Construction Manhours [17500 h] → SSH-Construction Manhours [633.79 h] |
| 1.4.3.3.1.3.050 | Install reinforced columns | 2012-05-31 → 2012-07-16 A (+46d) | 2012-07-05 → 2012-08-20 A (+46d) |  | 0% → 100% | 122d → none |  | resources SSH-Construction Manhours [18000 h] → SSH-Construction Manhours [768.66 h] |
| 1.4.3.3.1.3.060 | Install reinforced roof beams | 2012-06-14 → 2012-12-02 (+171d) | 2012-07-19 → 2013-01-06 (+171d) |  |  | 122d → -121.25d |  | resources SSH-Construction Manhours [18000 h] → SSH-Construction Manhours [768.66 h] |
| 1.4.3.3.1.3.070 | Install reinforced roof slab /paraphet | 2012-06-28 → 2012-12-20 (+175d) | 2012-08-14 → 2013-01-08 (+147d) | 50d → 20d |  | 122d → -121.25d | 1.4.3.3.1.3.060 SS+15d → 1.4.3.3.1.3.060 SS+20d | resources SSH-Construction Manhours [18213 h] → SSH-Construction Manhours [768.66 h] |
| 1.4.3.3.1.3.080 | Install reinforced slab on grade | 2012-07-12 → 2013-01-03 (+175d) | 2012-08-28 → 2013-02-10 (+166d) | 50d → 40d |  | 187d → -71d |  | resources SSH-Construction Manhours [12142 h] → SSH-Construction Manhours [649.86 h] |
| 3 | **Architectural works** | 2012-08-14 → 2012-09-01 (+18d) | 2012-11-20 → 2013-04-21 (+152d) |  |  |  |  |  |
| 1 | **Masonry** | 2012-08-14 → 2012-09-01 (+18d) | 2012-09-16 → 2013-02-16 (+153d) |  |  |  |  |  |
| 1.4.3.3.1.3.090 | Install 200mm thk CMU blocks | 2012-08-14 → 2012-09-01 A (+18d) | 2012-09-06 → 2013-01-27 (+143d) |  | 0% → 85% | 122d → -121.25d | 1.4.3.3.1.3.070 → 1.4.3.3.1.3.070 FF+20d | resources SSH-Construction Manhours [12781.1 h] → SSH-Construction Manhours [462.59 h] |

| ID | Task | Start | Finish | Complete | Total float | Predecessors | Other |
| --- | --- | --- | --- | --- | --- | --- | --- |
| 1.4.3.3.1.3.100 | Install 50 mm thk mortar plastering work | 2012-08-23 → 2012-09-10 A (+18d) | 2012-09-16 → 2013-02-16 (+153d) |  | 122d → -121.25d |  | resources SSH-Construction Manhours [9585.81 h] → SSH-Construction Manhours [347.29 h] |
| 2 | **Floor Finishing** | 2012-10-25 → 2013-03-24 (+150d) | 2012-11-20 → 2013-04-18 (+149d) |  |  |  |  |
| 1.4.3.3.1.3.110 | Install cement toping work | 2012-10-25 → 2013-03-24 (+150d) | 2012-11-17 → 2013-04-15 (+149d) |  | 122d → -118.5d | 1.4.3.3.1.3.140 SS+3d → 1.4.3.3.1.3.140 FF | resources SSH-Construction Manhours [30000 h] → SSH-Construction Manhours [1086.6 h] |
| 1.4.3.3.1.3.120 | Install ceramic tiling work | 2012-10-28 → 2013-03-26 (+149d) | 2012-11-20 → 2013-04-18 (+149d) |  | 122d → -118.5d |  | resources SSH-Construction Manhours [30000 h] → SSH-Construction Manhours [1086.6 h] |
| 3 | **Wall Finishing** | 2012-10-16 → 2013-03-17 (+152d) | 2012-11-20 → 2013-04-21 (+152d) |  |  |  |  |
| 1.4.3.3.1.3.130 | Install phenolic toilet partition | 2012-10-16 → 2013-03-17 (+152d) | 2012-11-07 → 2013-04-09 (+153d) |  | 122d → -121.25d |  | resources SSH-Construction Manhours [30000 h] → SSH-Construction Manhours [1085.9 h] |
| 1.4.3.3.1.3.140 | Install ceramic tiling work | 2012-10-22 → 2013-03-24 (+153d) | 2012-11-14 → 2013-04-15 (+152d) |  | 122d → -121.25d |  | resources SSH-Construction Manhours [30000 h] → SSH-Construction Manhours [1085.9 h] |
| 1.4.3.3.1.3.150 | Install textured painted work on CMU wall | 2012-10-29 → 2013-03-30 (+152d) | 2012-11-20 → 2013-04-21 (+152d) |  | 122.25d → -121.25d |  | resources SSH-Construction Manhours [28500 h] → SSH-Construction Manhours [1011.13 h] |
| 4 | **Ceiling Finihsing** | 2012-09-16 → 2012-10-03 (+17d) | 2012-10-22 → 2013-03-23 (+152d) |  |  |  |  |
| 1.4.3.3.1.3.160 | Install gypsum board ceiling system | 2012-09-16 → 2012-10-03 A (+17d) | 2012-10-09 → 2013-03-10 (+152d) | 0% → 3% | 122d → -121.25d |  | resources SSH-Construction Manhours [12000 h] → SSH-Construction Manhours [434.64 h] |
| 1.4.3.3.1.3.170 | Install painting work | 2012-09-23 → 2013-02-21 (+151d) | 2012-10-15 → 2013-03-17 (+153d) |  | 122d → -121.25d |  | resources SSH-Construction Manhours [10000 h] → SSH-Construction Manhours [361.97 h] |
| 1.4.3.3.1.3.180 | Install roof water proofing system & scrupper | 2012-09-29 → 2013-02-28 (+152d) | 2012-10-22 → 2013-03-23 (+152d) |  | 153d → -90.5d |  | resources SSH-Construction Manhours [10000 h] → SSH-Construction Manhours [361.97 h] |
| 5 | **Doors / Windows / Toilet Accs** | 2012-09-27 → 2013-02-20 (+146d) | 2012-10-31 → 2013-03-25 (+145d) |  |  |  |  |
| 1.4.3.3.1.3.190 | Install doors & windows | 2012-09-27 → 2013-02-20 (+146d) | 2012-10-21 → 2013-03-16 (+146d) |  | 143.5d → -92.75d |  | resources SSH-Construction Manhours [10000 h] → SSH-Construction Manhours [361.97 h] |
| 1.4.3.3.1.3.200 | Install toilet fixtures & accs | 2012-10-04 → 2013-02-27 (+146d) | 2012-10-28 → 2013-03-23 (+146d) |  | 143.5d → -92.75d |  | resources SSH-Construction Manhours [16000 h] → SSH-Construction Manhours [579.29 h] |
| 1.4.3.3.1.3.210 | Install cabinet & counter top | 2012-10-08 → 2013-03-02 (+145d) | 2012-10-31 → 2013-03-25 (+145d) |  | 143.5d → -92.75d |  | resources SSH-Construction Manhours [16000 h] → SSH-Construction Manhours [579.29 h] |
| 4 | **Electrical works** | 2012-08-14 → 2013-01-23 (+162d) | 2012-09-11 → 2013-02-20 (+162d) |  |  |  |  |
| 1.4.3.3.1.3.220 | Install electric conduits / fittings | 2012-08-14 → 2013-01-23 (+162d) | 2012-08-28 → 2013-02-06 (+162d) |  | 161.5d → -92.75d |  | resources SSH-Construction Manhours [3834.32 h] → SSH-Construction Manhours [138.36 h] |
| 1.4.3.3.1.3.230 | Install cables / wires | 2012-08-16 → 2013-01-26 (+163d) | 2012-08-30 → 2013-02-09 (+163d) |  | 161.5d → -92.75d |  | resources SSH-Construction Manhours [5751.49 h] → SSH-Construction Manhours [208.24 h] |
| 1.4.3.3.1.3.240 | Install lighting fixtures | 2012-08-20 → 2013-01-29 (+162d) | 2012-09-03 → 2013-02-12 (+162d) |  | 161.5d → -92.75d |  | resources SSH-Construction Manhours [5751.49 h] → SSH-Construction Manhours [208.24 h] |
| 1.4.3.3.1.3.250 | Install panelboards | 2012-08-22 → 2013-01-31 (+162d) | 2012-09-05 → 2013-02-14 (+162d) |  | 161.5d → -92.75d |  | resources SSH-Construction Manhours [2400 h] → SSH-Construction Manhours [87.35 h] |
| 1.4.3.3.1.3.255 | Install lighting control panel | 2012-08-25 → 2013-02-03 (+162d) | 2012-09-08 → 2013-02-17 (+162d) |  | 161.5d → -92.75d |  | resources SSH-Construction Manhours [2400 h] → SSH-Construction Manhours [87.35 h] |
| 1.4.3.3.1.3.260 | Install disconnect switches | 2012-08-26 → 2013-02-04 (+162d) | 2012-09-09 → 2013-02-18 (+162d) |  | 161.5d → -92.75d |  | resources SSH-Construction Manhours [2400 h] → SSH-Construction Manhours [87.35 h] |
| 1.4.3.3.1.3.270 | Install grounding system | 2012-08-28 → 2013-02-06 (+162d) | 2012-09-11 → 2013-02-20 (+162d) |  | 161.5d → -92.75d |  | resources SSH-Construction Manhours [2400 h] → SSH-Construction Manhours [87.35 h] |
| 5 | **Water Supply System** | 2012-09-06 → 2013-01-27 (+143d) | 2012-09-20 → 2013-02-10 (+143d) |  |  |  |  |
| 1.4.3.3.1.3.280 | Install water supply system | 2012-09-06 → 2013-01-27 (+143d) | 2012-09-20 → 2013-02-10 (+143d) |  | 143.5d → -89.5d |  | resources SSH-Construction Manhours [3600 h] → SSH-Construction Manhours [132.77 h] |
| 6 | **Sewer System** | 2012-09-13 → 2013-02-03 (+143d) | 2012-09-27 → 2013-02-17 (+143d) |  |  |  |  |
| 1.4.3.3.1.3.290 | Install sewer system | 2012-09-13 → 2013-02-03 (+143d) | 2012-09-27 → 2013-02-17 (+143d) |  | 143.5d → -89.5d |  | resources SSH-Construction Manhours [3600 h] → SSH-Construction Manhours [132.77 h] |
| 7 | **HVAC System** | 2012-09-27 → 2013-02-17 (+143d) | 2012-10-11 → 2013-03-03 (+143d) |  |  |  |  |
| 1.4.3.3.1.3.300 | Install HVAC system | 2012-09-27 → 2013-02-17 (+143d) | 2012-10-11 → 2013-03-03 (+143d) |  | 164d → -69d |  | resources SSH-Construction Manhours [9600 h] → SSH-Construction Manhours [349.39 h] |
| 4 | **Snack Booths (4 nos)** | 2012-03-17 → 2012-07-15 (+120d) | 2012-11-13 → 2013-04-06 (+144d) |  |  |  |  |
| 1 | **Snack Booth # 1** | 2012-03-17 → 2012-07-15 (+120d) | 2012-08-11 → 2013-03-14 (+215d) |  |  |  |  |
| 1 | **Civil work** | 2012-03-17 → 2012-07-15 (+120d) | 2012-06-07 → 2013-01-26 (+233d) |  |  |  |  |
| 1.4.3.4.1.010 | Excavation leveling & compaction for snack booth #1 | 2012-03-17 → 2012-07-15 A (+120d) | 2012-03-25 → 2012-07-24 A (+121d) | 0% → 100% | 37.75d → none | 1.4.3.3.1.1.010 SS → 1.4.3.3.1.1.010 FS+45d | resources SSH-Construction Manhours [4000 h]; Excavator [80 h]; Dump Truck [80 h] → SSH-Construction Manhours [186.23 h]; Excavator [80 h]; Dump Truck [80 h] |
| 1.4.3.4.1.015 | Backfill/comp for snack booth #1 | 2012-05-27 → 2013-01-14 (+232d) | 2012-06-07 → 2013-01-26 (+233d) |  | 182.25d → -97.5d |  | resources SSH-Construction Manhours [2000 h]; Compactor [100 h]; Dump Truck [100 h] → SSH-Construction Manhours [97.16 h]; Compactor [100 h]; Dump Truck [100 h] |
| 2 | **Structural work** | 2012-03-21 → 2012-07-21 (+122d) | 2012-05-27 → 2013-01-14 (+232d) |  |  |  |  |
| 1.4.3.4.1.020 | Install lean concrete for reinforced fdns for snack both 1 | 2012-03-21 → 2012-07-21 A (+122d) | 2012-04-08 → 2012-12-05 (+241d) | 0% → 80% | 157d → -104.75d |  | resources SSH-Construction Manhours [10500 h] → SSH-Construction Manhours [242.9 h] |
| 1.4.3.4.1.030 | Install reinforced fdns for snack booth1 | 2012-03-31 → 2012-07-30 A (+121d) | 2012-04-29 → 2012-12-29 (+244d) | 0% → 7% | 157d → -104.75d |  | resources SSH-Construction Manhours [50000 h] → SSH-Construction Manhours [1157.84 h] |
| 1.4.3.4.1.040 | Install reinforced roof slab/paraphet snack booth1 | 2012-04-14 → 2012-12-02 (+232d) | 2012-05-13 → 2012-12-31 (+232d) |  | 157d → -104.75d |  | resources SSH-Construction Manhours [15000 h] → SSH-Construction Manhours [348.16 h] |
| 1.4.3.4.1.050 | Install reinforced slab on grade | 2012-04-28 → 2012-12-16 (+232d) | 2012-05-27 → 2013-01-14 (+232d) |  | 157d → -104.75d |  | resources SSH-Construction Manhours [15000 h] → SSH-Construction Manhours [348.16 h] |
| 3 | **Architectural work** | 2012-05-12 → 2012-12-30 (+232d) | 2012-08-11 → 2013-03-14 (+215d) |  |  |  |  |
| 1.4.3.4.1.060 | Install masonry work for snack booth1 | 2012-05-12 → 2012-12-30 (+232d) | 2012-05-29 → 2013-01-16 (+232d) |  | 157d → -104.75d |  | resources SSH-Construction Manhours [6000 h] → SSH-Construction Manhours [139.27 h] |
| 1.4.3.4.1.070 | Install plastering work | 2012-05-17 → 2013-01-05 (+233d) | 2012-06-04 → 2013-01-22 (+232d) |  | 157d → -104.75d |  | resources SSH-Construction Manhours [3000 h] → SSH-Construction Manhours [69.63 h] |
| 1.4.3.4.1.080 | Install roof proofing system | 2012-05-22 → 2013-01-09 (+232d) | 2012-06-09 → 2013-01-27 (+232d) |  | 157d → -104.75d |  | resources SSH-Construction Manhours [3000 h] → SSH-Construction Manhours [69.63 h] |
| 1.4.3.4.1.090 | Install ceiling system | 2012-05-27 → 2013-01-14 (+232d) | 2012-06-13 → 2013-01-31 (+232d) |  | 175d → -104.75d |  | resources SSH-Construction Manhours [3000 h] → SSH-Construction Manhours [69.63 h] |
| 1.4.3.4.1.100 | Install concret toping, ceramic floor finishes | 2012-05-31 → 2013-01-19 (+233d) | 2012-06-18 → 2013-02-05 (+232d) |  | 175d → -104.75d |  | resources SSH-Construction Manhours [9000 h] → SSH-Construction Manhours [210.52 h] |
| 1.4.3.4.1.110 | Install painting work | 2012-06-05 → 2013-01-23 (+232d) | 2012-06-23 → 2013-02-10 (+232d) |  | 175d → -104.75d |  | resources SSH-Construction Manhours [9000 h] → SSH-Construction Manhours [210.52 h] |
| 1.4.3.4.1.120 | Install plumbing fixture | 2012-06-10 → 2013-01-28 (+232d) | 2012-06-27 → 2013-02-14 (+232d) |  | 175d → -104.75d |  | resources SSH-Construction Manhours [9000 h] → SSH-Construction Manhours [210.52 h] |
| 1.4.3.4.1.130 | Install doors | 2012-06-14 → 2013-02-02 (+233d) | 2012-07-02 → 2013-02-19 (+232d) |  | 175d → -104.75d |  | resources SSH-Construction Manhours [3000 h] → SSH-Construction Manhours [72.87 h] |
| 1.4.3.4.1.140 | Install windows | 2012-06-20 → 2013-02-07 (+232d) | 2012-07-08 → 2013-02-25 (+232d) |  | 175d → -104.75d |  | resources SSH-Construction Manhours [3000 h] → SSH-Construction Manhours [72.87 h] |
| 1.4.3.4.1.150 | Install furniture & kitchen counter top | 2012-06-26 → 2013-02-13 (+232d) | 2012-07-14 → 2013-03-03 (+232d) |  | 175d → -104.75d |  | resources SSH-Construction Manhours [3000 h] → SSH-Construction Manhours [72.87 h] |
| 1.4.3.4.1.160 | Install kitchen & dinnning equipments | 2012-07-02 → 2013-02-19 (+232d) | 2012-07-19 → 2013-03-09 (+233d) |  | 175d → -104.75d |  | resources SSH-Construction Manhours [3000 h] → SSH-Construction Manhours [72.87 h] |
| 1.4.3.4.1.170 | Install wooden trellis | 2012-07-25 → 2013-02-25 (+215d) | 2012-08-11 → 2013-03-14 (+215d) |  | 157d → -104.75d | 1.4.3.4.1.160 SS+6.25d, 1.4.3.4.1.330 → 1.4.3.4.1.160 SS+6.25d, 1.4.3.4.1.330 FF | resources SSH-Construction Manhours [3000 h] → SSH-Construction Manhours [72.87 h] |
| 4 | **Electrical work** | 2012-06-09 → 2013-01-27 (+232d) | 2012-07-12 → 2013-03-02 (+233d) |  |  |  |  |
| 1.4.3.4.1.180 | Install electric conduits | 2012-06-09 → 2013-01-27 (+232d) | 2012-06-26 → 2013-02-13 (+232d) |  | 157d → -104d |  | resources SSH-Construction Manhours [3000 h] → SSH-Construction Manhours [72.87 h] |
| 1.4.3.4.1.190 | Install cables & wires | 2012-06-14 → 2013-02-02 (+233d) | 2012-07-02 → 2013-02-18 (+231d) |  | 157d → -104d |  | resources SSH-Construction Manhours [3000 h] → SSH-Construction Manhours [72.87 h] |
| 1.4.3.4.1.200 | Install lighting fixtures | 2012-06-18 → 2013-02-05 (+232d) | 2012-07-05 → 2013-02-23 (+233d) |  | 157d → -104d |  | resources SSH-Construction Manhours [3000 h] → SSH-Construction Manhours [72.87 h] |
| 1.4.3.4.1.210 | Install panelboards | 2012-06-21 → 2013-02-07 (+231d) | 2012-07-08 → 2013-02-25 (+232d) |  | 157d → -104d |  | resources SSH-Construction Manhours [3000 h] → SSH-Construction Manhours [72.87 h] |
| 1.4.3.4.1.220 | Install grounding system | 2012-06-23 → 2013-02-10 (+232d) | 2012-07-10 → 2013-02-27 (+232d) |  | 157d → -104d |  | resources SSH-Construction Manhours [3000 h] → SSH-Construction Manhours [72.87 h] |
| 1.4.3.4.1.230 | Testing & commissioing of electric system | 2012-06-26 → 2013-02-12 (+231d) | 2012-07-12 → 2013-03-02 (+233d) |  | 157d → -104d |  | resources SSH-Construction Manhours [3000 h] → SSH-Construction Manhours [72.87 h] |
| 5 | **Communciation work** | 2012-06-09 → 2013-01-27 (+232d) | 2012-07-24 → 2013-03-13 (+232d) |  |  |  |  |
| 1.4.3.4.1.240 | Install comm condutis & fittings | 2012-06-09 → 2013-01-27 (+232d) | 2012-06-20 → 2013-02-07 (+232d) |  | 164.75d → -96.25d |  | resources SSH-Construction Manhours [2000 h] → SSH-Construction Manhours [48.58 h] |
| 1.4.3.4.1.250 | Install UTP cable | 2012-06-12 → 2013-01-30 (+232d) | 2012-06-24 → 2013-02-11 (+232d) |  | 167.75d → -93.25d |  | resources SSH-Construction Manhours [4000 h] → SSH-Construction Manhours [89.06 h] |
| 1.4.3.4.1.260 | Install equipment cabinet | 2012-06-17 → 2013-02-03 (+231d) | 2012-06-27 → 2013-02-14 (+232d) |  | 167.75d → -93.25d |  | resources SSH-Construction Manhours [3000 h] → SSH-Construction Manhours [64.77 h] |
| 1.4.3.4.1.270 | Install data network switch | 2012-06-18 → 2013-02-05 (+232d) | 2012-06-30 → 2013-02-17 (+232d) |  | 167.75d → -93.25d |  | resources SSH-Construction Manhours [3000 h] → SSH-Construction Manhours [64.77 h] |
| 1.4.3.4.1.280 | Install copper splice closure | 2012-06-20 → 2013-02-06 (+231d) | 2012-07-02 → 2013-02-18 (+231d) |  | 167.75d → -93.25d |  | resources SSH-Construction Manhours [3000 h] → SSH-Construction Manhours [64.77 h] |
| 1.4.3.4.1.290 | Install patch panel | 2012-06-21 → 2013-02-09 (+233d) | 2012-07-03 → 2013-02-20 (+232d) |  | 167.75d → -93.25d |  | resources SSH-Construction Manhours [3000 h] → SSH-Construction Manhours [64.77 h] |
| 1.4.3.4.1.300 | Install fiber patch panel | 2012-06-25 → 2013-02-11 (+231d) | 2012-07-07 → 2013-02-23 (+231d) |  | 167.75d → -93.25d |  | resources SSH-Construction Manhours [3000 h] → SSH-Construction Manhours [64.77 h] |
| 1.4.3.4.1.310 | Install patch cord | 2012-06-27 → 2013-02-14 (+232d) | 2012-07-09 → 2013-02-26 (+232d) |  | 167.75d → -93.25d |  | resources SSH-Construction Manhours [3000 h] → SSH-Construction Manhours [64.77 h] |
| 1.4.3.4.1.320 | Install rack manager | 2012-07-01 → 2013-02-17 (+231d) | 2012-07-11 → 2013-02-28 (+232d) |  | 167.75d → -93.25d |  | resources SSH-Construction Manhours [3000 h] → SSH-Construction Manhours [64.77 h] |

| ID | Task | Start | Finish | Duration | Complete | Total float | Predecessors | Other |
| --- | --- | --- | --- | --- | --- | --- | --- | --- |
| 1.4.3.4.1.330 | Testing & commissioning of comm system | 2012-07-14 → 2013-03-02 (+231d) | 2012-07-24 → 2013-03-13 (+232d) |  |  | 157d → -104d |  | resources SSH-Construction Manhours [5000 h] → SSH-Construction Manhours [64.77 h] |
| 6 | **Mechanical work** | 2012-06-09 → 2013-01-27 (+232d) | 2012-07-05 → 2013-02-23 (+233d) |  |  |  |  |  |
| 1.4.3.4.1.340 | Install water supply system | 2012-06-09 → 2013-01-27 (+232d) | 2012-06-23 → 2013-02-10 (+232d) |  |  | 164.75d → -96.25d |  | resources SSH-Construction Manhours [7200 h] → SSH-Construction Manhours [166.79 h] |
| 1.4.3.4.1.350 | Install sewer system | 2012-06-16 → 2013-02-02 (+231d) | 2012-06-30 → 2013-02-16 (+231d) |  |  | 164.75d → -96.25d |  | resources SSH-Construction Manhours [7200 h] → SSH-Construction Manhours [166.79 h] |
| 1.4.3.4.1.360 | Install HVAC system | 2012-06-21 → 2013-02-09 (+233d) | 2012-07-05 → 2013-02-23 (+233d) |  |  | 164.75d → -96.25d |  | resources SSH-Construction Manhours [6000 h] → SSH-Construction Manhours [142.5 h] |
| 2 | **Snack Booth # 2** | 2012-04-18 → 2012-07-15 (+88d) | 2012-09-20 → 2013-04-06 (+198d) |  |  |  |  |  |
| 1 | **Civil work** | 2012-04-18 → 2012-07-15 (+88d) | 2012-08-02 → 2013-01-28 (+179d) |  |  |  |  |  |
| 1.4.3.4.2.010 | Excavation leveling & compaction for snack booth #2 | 2012-04-18 → 2012-07-15 A (+88d) | 2012-05-22 → 2012-07-29 A (+68d) | 37.5d → 15d | 0% → 100% | 128.75d → none | 1.4.3.4.1.010 SS+35d → 1.4.3.4.1.010 SS | resources SSH-Construction Manhours [15000 h]; Dump Truck [300 h]; Excavator [300 h] → SSH-Construction Manhours [186.23 h]; Dump Truck [300 h]; Excavator [300 h] |
| 1.4.3.4.2.015 | Backfill/comp for snack booth #2 | 2012-06-28 → 2013-01-14 (+200d) | 2012-08-02 → 2013-01-28 (+179d) | 37.5d → 15d |  | 174d → -67d |  | resources SSH-Construction Manhours [12000 h]; Dump Truck [300 h]; Compactor [300 h] → SSH-Construction Manhours [97.16 h]; Dump Truck [300 h]; Compactor [300 h] |
| 2 | **Structural work** | 2012-04-23 → 2012-07-21 (+89d) | 2012-06-28 → 2013-01-14 (+200d) |  |  |  |  |  |
| 1.4.3.4.2.020 | Install lean concrete for reinforced fdns for snack both | 2012-04-23 → 2012-07-21 A (+89d) | 2012-05-10 → 2012-12-05 (+209d) |  | 0% → 80% | 174d → -98.75d |  | resources SSH-Construction Manhours [7500 h] → SSH-Construction Manhours [173.27 h] |
| 1.4.3.4.2.030 | Install reinforced fdns for snack booth | 2012-05-02 → 2012-07-30 A (+89d) | 2012-05-31 → 2012-12-30 (+213d) |  | 0% → 3% | 174d → -98.75d |  | resources SSH-Construction Manhours [10000 h] → SSH-Construction Manhours [234.81 h] |
| 1.4.3.4.2.040 | Install reinforced roof slab/paraphet snack booth | 2012-05-16 → 2012-12-02 (+200d) | 2012-06-14 → 2012-12-31 (+200d) |  |  | 174d → -98.75d |  | resources SSH-Construction Manhours [10000 h] → SSH-Construction Manhours [234.81 h] |
| 1.4.3.4.2.050 | Install reinforced slab on grade | 2012-05-30 → 2012-12-16 (+200d) | 2012-06-28 → 2013-01-14 (+200d) |  |  | 174d → -98.75d |  | resources SSH-Construction Manhours [10000 h] → SSH-Construction Manhours [234.81 h] |
| 3 | **Architectural work** | 2012-06-13 → 2012-12-30 (+200d) | 2012-09-20 → 2013-04-06 (+198d) |  |  |  |  |  |
| 1.4.3.4.2.060 | Install masonry work for snack booth | 2012-06-13 → 2012-12-30 (+200d) | 2012-07-01 → 2013-01-16 (+199d) |  |  | 174d → -98.75d |  | resources SSH-Construction Manhours [9000 h] → SSH-Construction Manhours [210.52 h] |
| 1.4.3.4.2.070 | Install plastering work | 2012-06-19 → 2013-01-05 (+200d) | 2012-07-07 → 2013-01-22 (+199d) |  |  | 174d → -98.75d |  | resources SSH-Construction Manhours [9000 h] → SSH-Construction Manhours [210.52 h] |
| 1.4.3.4.2.080 | Install roof proofing system | 2012-06-24 → 2013-01-09 (+199d) | 2012-07-11 → 2013-01-27 (+200d) |  |  | 174d → -98.75d |  | resources SSH-Construction Manhours [9000 h] → SSH-Construction Manhours [210.52 h] |
| 1.4.3.4.2.090 | Install ceiling system | 2012-06-28 → 2013-01-14 (+200d) | 2012-07-16 → 2013-01-31 (+199d) |  |  | 194.75d → -68.75d |  | resources SSH-Construction Manhours [9000 h] → SSH-Construction Manhours [210.52 h] |
| 1.4.3.4.2.100 | Install concrete toping, ceramic floor finishes | 2012-07-03 → 2013-01-19 (+200d) | 2012-07-21 → 2013-02-05 (+199d) |  |  | 194.75d → -68.75d |  | resources SSH-Construction Manhours [9000 h] → SSH-Construction Manhours [210.52 h] |
| 1.4.3.4.2.110 | Install painting work | 2012-08-12 → 2013-02-25 (+197d) | 2012-08-28 → 2013-03-14 (+198d) |  |  | 157d → -104.75d | 1.4.3.4.2.100 SS+4d, 1.4.3.4.1.170 → 1.4.3.4.2.100 FF+4d, 1.4.3.4.1.170 FF | resources SSH-Construction Manhours [7500 h] → SSH-Construction Manhours [173.27 h] |
| 1.4.3.4.2.120 | Install plumbing fixture | 2012-08-15 → 2013-02-28 (+197d) | 2012-09-02 → 2013-03-18 (+197d) |  |  | 157d → -104.75d |  | resources SSH-Construction Manhours [7500 h] → SSH-Construction Manhours [173.27 h] |
| 1.4.3.4.2.130 | Install doors | 2012-08-19 → 2013-03-04 (+197d) | 2012-09-05 → 2013-03-21 (+197d) |  |  | 157d → -104.75d |  | resources SSH-Construction Manhours [7500 h] → SSH-Construction Manhours [173.27 h] |
| 1.4.3.4.2.140 | Install windows | 2012-08-21 → 2013-03-06 (+197d) | 2012-09-06 → 2013-03-24 (+199d) |  |  | 157d → -104.75d |  | resources SSH-Construction Manhours [4500 h] → SSH-Construction Manhours [105.26 h] |
| 1.4.3.4.2.150 | Install furniture & kitchen counter top | 2012-08-22 → 2013-03-07 (+197d) | 2012-09-09 → 2013-03-25 (+197d) |  |  | 157d → -104.75d |  | resources SSH-Construction Manhours [4500 h] → SSH-Construction Manhours [105.26 h] |
| 1.4.3.4.2.160 | Install kitchen & dinnning equipments | 2012-08-28 → 2013-03-13 (+197d) | 2012-09-15 → 2013-03-31 (+197d) |  |  | 157d → -104.75d |  | resources SSH-Construction Manhours [4500 h] → SSH-Construction Manhours [105.26 h] |
| 1.4.3.4.2.170 | Install wooden trellis | 2012-09-03 → 2013-03-19 (+197d) | 2012-09-20 → 2013-04-06 (+198d) |  |  | 157d → -104.75d |  | resources SSH-Construction Manhours [4500 h] → SSH-Construction Manhours [105.26 h] |
| 4 | **Electrical work** | 2012-07-11 → 2013-01-27 (+200d) | 2012-08-11 → 2013-02-26 (+199d) |  |  |  |  |  |
| 1.4.3.4.2.180 | Install electric conduits | 2012-07-11 → 2013-01-27 (+200d) | 2012-07-25 → 2013-02-10 (+200d) |  |  | 174d → -98.75d |  | resources SSH-Construction Manhours [6000 h] → SSH-Construction Manhours [139.27 h] |
| 1.4.3.4.2.190 | Install cables & wires | 2012-07-17 → 2013-02-02 (+200d) | 2012-07-31 → 2013-02-14 (+198d) |  |  | 174d → -98.75d |  | resources SSH-Construction Manhours [6000 h] → SSH-Construction Manhours [139.27 h] |
| 1.4.3.4.2.200 | Install lighting fixtures | 2012-07-21 → 2013-02-05 (+199d) | 2012-08-04 → 2013-02-19 (+199d) |  |  | 174d → -98.75d |  | resources SSH-Construction Manhours [6000 h] → SSH-Construction Manhours [139.27 h] |
| 1.4.3.4.2.210 | Install panelboards | 2012-07-24 → 2013-02-07 (+198d) | 2012-08-06 → 2013-02-21 (+199d) |  |  | 174d → -98.75d |  | resources SSH-Construction Manhours [6000 h] → SSH-Construction Manhours [139.27 h] |
| 1.4.3.4.2.220 | Install grounding system | 2012-07-25 → 2013-02-10 (+200d) | 2012-08-08 → 2013-02-24 (+200d) |  |  | 174d → -98.75d |  | resources SSH-Construction Manhours [6000 h] → SSH-Construction Manhours [139.27 h] |
| 1.4.3.4.2.230 | Testing & commissioing of electric system | 2012-07-29 → 2013-02-12 (+198d) | 2012-08-11 → 2013-02-26 (+199d) |  |  | 174d → -98.75d |  | resources SSH-Construction Manhours [6000 h] → SSH-Construction Manhours [139.27 h] |
| 5 | **Communciation work** | 2012-07-11 → 2013-01-27 (+200d) | 2012-08-25 → 2013-03-12 (+199d) |  |  |  |  |  |
| 1.4.3.4.2.240 | Install comm condutis & fittings | 2012-07-11 → 2013-01-27 (+200d) | 2012-07-25 → 2013-02-10 (+200d) |  |  | 178d → -94.75d |  | resources SSH-Construction Manhours [6000 h] → SSH-Construction Manhours [139.27 h] |
| 1.4.3.4.2.250 | Install UTP cable | 2012-07-15 → 2013-01-30 (+199d) | 2012-07-29 → 2013-02-13 (+199d) |  |  | 181d → -91.75d |  | resources SSH-Construction Manhours [6000 h] → SSH-Construction Manhours [139.27 h] |
| 1.4.3.4.2.260 | Install equipment cabinet | 2012-07-19 → 2013-02-03 (+199d) | 2012-08-01 → 2013-02-17 (+200d) |  |  | 181d → -91.75d |  | resources SSH-Construction Manhours [6000 h] → SSH-Construction Manhours [139.27 h] |
| 1.4.3.4.2.270 | Install data network switch | 2012-07-21 → 2013-02-05 (+199d) | 2012-08-04 → 2013-02-19 (+199d) |  |  | 181d → -91.75d |  | resources SSH-Construction Manhours [6000 h] → SSH-Construction Manhours [139.27 h] |
| 1.4.3.4.2.280 | Install copper splice closure | 2012-07-23 → 2013-02-06 (+198d) | 2012-08-06 → 2013-02-20 (+198d) |  |  | 181d → -91.75d |  | resources SSH-Construction Manhours [6000 h] → SSH-Construction Manhours [139.27 h] |
| 1.4.3.4.2.290 | Install patch panel | 2012-07-24 → 2013-02-09 (+200d) | 2012-08-07 → 2013-02-23 (+200d) |  |  | 181d → -91.75d |  | resources SSH-Construction Manhours [6000 h] → SSH-Construction Manhours [139.27 h] |
| 1.4.3.4.2.300 | Install fiber patch panel | 2012-07-28 → 2013-02-11 (+198d) | 2012-08-11 → 2013-02-25 (+198d) |  |  | 181d → -91.75d |  | resources SSH-Construction Manhours [6000 h] → SSH-Construction Manhours [139.27 h] |
| 1.4.3.4.2.310 | Install patch cord | 2012-07-30 → 2013-02-14 (+199d) | 2012-08-13 → 2013-02-28 (+199d) |  |  | 181d → -91.75d |  | resources SSH-Construction Manhours [6000 h] → SSH-Construction Manhours [139.27 h] |
| 1.4.3.4.2.320 | Install rack manager | 2012-08-02 → 2013-02-17 (+199d) | 2012-08-15 → 2013-03-03 (+200d) |  |  | 181d → -91.75d |  | resources SSH-Construction Manhours [6000 h] → SSH-Construction Manhours [139.27 h] |
| 1.4.3.4.2.330 | Testing & commissioning of comm system | 2012-08-12 → 2013-02-26 (+198d) | 2012-08-25 → 2013-03-12 (+199d) |  |  | 174d → -98.75d |  | resources SSH-Construction Manhours [6000 h] → SSH-Construction Manhours [139.27 h] |
| 6 | **Mechanical work** | 2012-07-11 → 2013-01-27 (+200d) | 2012-08-07 → 2013-02-23 (+200d) |  |  |  |  |  |
| 1.4.3.4.2.340 | Install water supply system | 2012-07-11 → 2013-01-27 (+200d) | 2012-07-25 → 2013-02-10 (+200d) |  |  | 178d → -94.75d |  | resources SSH-Construction Manhours [6000 h] → SSH-Construction Manhours [139.27 h] |
| 1.4.3.4.2.350 | Install sewer system | 2012-07-18 → 2013-02-02 (+199d) | 2012-08-01 → 2013-02-16 (+199d) |  |  | 178d → -94.75d |  | resources SSH-Construction Manhours [6000 h] → SSH-Construction Manhours [139.27 h] |
| 1.4.3.4.2.360 | Install HVAC system | 2012-07-24 → 2013-02-09 (+200d) | 2012-08-07 → 2013-02-23 (+200d) |  |  | 178d → -94.75d |  | resources SSH-Construction Manhours [6000 h] → SSH-Construction Manhours [139.27 h] |
| 3 | **Snack Booth # 3** | 2012-05-21 → 2012-07-15 (+55d) | 2012-11-13 → 2013-04-06 (+144d) |  |  |  |  |  |
| 1 | **Civil work** | 2012-05-21 → 2012-07-15 (+55d) | 2012-08-12 → 2013-01-26 (+167d) |  |  |  |  |  |
| 1.4.3.4.3.010 | Excavation leveling & compaction for snack booth 3 | 2012-05-21 → 2012-07-15 A (+55d) | 2012-05-29 → 2012-07-24 A (+56d) |  | 0% → 100% | 128.75d → none | 1.4.3.4.2.010 SS+35d → 1.4.3.4.2.010 SS | resources SSH-Construction Manhours [2400 h]; Excavator [80 h]; Dump Truck [80 h] → SSH-Construction Manhours [186.23 h]; Excavator [80 h]; Dump Truck [80 h] |
| 1.4.3.4.3.015 | Backfill/comp for snack booth 3 | 2012-07-31 → 2013-01-14 (+167d) | 2012-08-12 → 2013-01-26 (+167d) |  |  | 188d → -64.75d |  | resources SSH-Construction Manhours [3000 h]; Dump Truck [100 h]; Compactor [100 h] → SSH-Construction Manhours [97.16 h]; Dump Truck [100 h]; Compactor [100 h] |
| 2 | **Structural work** | 2012-05-26 → 2012-07-21 (+56d) | 2012-07-31 → 2013-01-14 (+167d) |  |  |  |  |  |
| 1.4.3.4.3.020 | Install lean concrete for reinforced fdns for snack both | 2012-05-26 → 2012-07-21 A (+56d) | 2012-06-12 → 2012-12-05 (+176d) |  | 0% → 80% | 128.75d → -100d |  | resources SSH-Construction Manhours [4500 h] → SSH-Construction Manhours [105.26 h] |
| 1.4.3.4.3.030 | Install reinforced fdns for snack booth | 2012-06-04 → 2012-07-30 A (+56d) | 2012-07-03 → 2012-12-30 (+180d) |  | 0% → 3% | 128.75d → -100d |  | resources SSH-Construction Manhours [25000 h] → SSH-Construction Manhours [582.97 h] |
| 1.4.3.4.3.040 | Install reinforced roof slab/paraphet snack booth | 2012-06-18 → 2012-12-02 (+167d) | 2012-07-17 → 2012-12-31 (+167d) |  |  | 128.75d → -100d |  | resources SSH-Construction Manhours [25000 h] → SSH-Construction Manhours [582.97 h] |
| 1.4.3.4.3.050 | Install reinforced slab on grade | 2012-07-02 → 2012-12-16 (+167d) | 2012-07-31 → 2013-01-14 (+167d) |  |  | 128.75d → -100d |  | resources SSH-Construction Manhours [12500 h] → SSH-Construction Manhours [291.49 h] |
| 3 | **Architectural work** | 2012-07-16 → 2012-12-25 (+162d) | 2012-11-13 → 2013-04-06 (+144d) |  |  |  |  |  |
| 1.4.3.4.3.060 | Install masonry work for snack booth | 2012-07-16 → 2012-12-25 (+162d) | 2012-08-08 → 2013-01-17 (+162d) |  |  | 128.75d → -100d | 1.4.3.4.3.050 SS+15d → 1.4.3.4.3.050 SS+10d | resources SSH-Construction Manhours [10000 h] → SSH-Construction Manhours [231.57 h] |
| 1.4.3.4.3.070 | Install plastering work | 2012-07-22 → 2012-12-31 (+162d) | 2012-08-14 → 2013-01-23 (+162d) |  |  | 128.75d → -100d |  | resources SSH-Construction Manhours [10000 h] → SSH-Construction Manhours [231.57 h] |
| 1.4.3.4.3.080 | Install roof proofing system | 2012-07-26 → 2013-01-05 (+163d) | 2012-08-19 → 2013-01-28 (+162d) |  |  | 128.75d → -100d |  | resources SSH-Construction Manhours [10000 h] → SSH-Construction Manhours [231.57 h] |
| 1.4.3.4.3.090 | Install ceiling system | 2012-07-31 → 2013-01-09 (+162d) | 2012-08-23 → 2013-02-02 (+163d) |  |  | 183.75d → -64d |  | resources SSH-Construction Manhours [10000 h] → SSH-Construction Manhours [231.57 h] |
| 1.4.3.4.3.100 | Install concrete toping, ceramic floor finishes | 2012-08-05 → 2013-01-14 (+162d) | 2012-08-28 → 2013-02-06 (+162d) |  |  | 183.75d → -64d |  | resources SSH-Construction Manhours [10000 h] → SSH-Construction Manhours [231.57 h] |
| 1.4.3.4.3.110 | Install painting work | 2012-09-03 → 2013-01-17 (+136d) | 2012-09-26 → 2013-02-10 (+137d) |  |  | 157d → -64d | 1.4.3.4.3.100 SS+4d, 1.4.3.4.2.170 SS → 1.4.3.4.3.100 SS+4d | resources SSH-Construction Manhours [10000 h] → SSH-Construction Manhours [231.57 h] |
| 1.4.3.4.3.120 | Install plumbing fixture | 2012-09-06 → 2013-01-21 (+137d) | 2012-09-30 → 2013-02-13 (+136d) |  |  | 157d → -64d |  | resources SSH-Construction Manhours [8000 h] → SSH-Construction Manhours [186.23 h] |
| 1.4.3.4.3.130 | Install doors | 2012-09-10 → 2013-02-26 (+169d) | 2012-10-03 → 2013-03-21 (+169d) |  |  | 157d → -98.75d | 1.4.3.4.3.120 SS+4d, 1.4.3.4.2.330, 1.4.3.4.3.015 → 1.4.3.4.3.120 SS+4d, 1.4.3.4.2.330 FF+10d, 1.4.3.4.3.015 | resources SSH-Construction Manhours [6000 h] → SSH-Construction Manhours [139.27 h] |
| 1.4.3.4.3.140 | Install windows | 2012-09-12 → 2013-02-28 (+169d) | 2012-10-06 → 2013-03-24 (+169d) |  |  | 157d → -98.75d |  | resources SSH-Construction Manhours [6000 h] → SSH-Construction Manhours [139.27 h] |
| 1.4.3.4.3.150 | Install furniture & kitchen counter top | 2012-09-13 → 2013-03-02 (+170d) | 2012-10-07 → 2013-03-25 (+169d) |  |  | 157d → -98.75d |  | resources SSH-Construction Manhours [6000 h] → SSH-Construction Manhours [139.27 h] |
| 1.4.3.4.3.160 | Install kitchen & dinnning equipments | 2012-09-19 → 2013-03-07 (+169d) | 2012-10-13 → 2013-03-31 (+169d) |  |  | 157d → -98.75d |  | resources SSH-Construction Manhours [6000 h] → SSH-Construction Manhours [139.27 h] |

| ID | Task | Start | Finish | Complete | Total float | Predecessors | Other |
| --- | --- | --- | --- | --- | --- | --- | --- |
| 1.4.3.4.3.170 | Install wooden trellis | 2012-10-22 → 2013-03-13 (+142d) | 2012-11-13 → 2013-04-06 (+144d) |  | 128.75d → -104.75d | 1.4.3.4.3.160 SS+6d, 1.4.3.4.3.330 → 1.4.3.4.3.160 FF, 1.4.3.4.3.330 FF, 1.4.3.4.2.170 FF | resources SSH-Construction Manhours [20000 h] → SSH-Construction Manhours [323.87 h] |
| 4 | **Electrical work** | 2012-08-19 → 2013-01-28 (+162d) | 2012-09-27 → 2013-03-09 (+163d) |  |  |  |  |
| 1.4.3.4.3.180 | Install electric conduits | 2012-08-19 → 2013-01-28 (+162d) | 2012-09-11 → 2013-02-20 (+162d) |  | 128.75d → -100d |  | resources SSH-Construction Manhours [10000 h] → SSH-Construction Manhours [234.81 h] |
| 1.4.3.4.3.190 | Install cables & wires | 2012-08-25 → 2013-02-03 (+162d) | 2012-09-17 → 2013-02-25 (+161d) |  | 128.75d → -100d |  | resources SSH-Construction Manhours [10000 h] → SSH-Construction Manhours [234.81 h] |
| 1.4.3.4.3.200 | Install lighting fixtures | 2012-08-28 → 2013-02-06 (+162d) | 2012-09-20 → 2013-03-02 (+163d) |  | 128.75d → -100d |  | resources SSH-Construction Manhours [10000 h] → SSH-Construction Manhours [234.81 h] |
| 1.4.3.4.3.210 | Install panelboards | 2012-09-01 → 2013-02-09 (+161d) | 2012-09-23 → 2013-03-04 (+162d) |  | 128.75d → -100d |  | resources SSH-Construction Manhours [10000 h] → SSH-Construction Manhours [234.81 h] |
| 1.4.3.4.3.220 | Install grounding system | 2012-09-02 → 2013-02-11 (+162d) | 2012-09-25 → 2013-03-06 (+162d) |  | 128.75d → -100d |  | resources SSH-Construction Manhours [10000 h] → SSH-Construction Manhours [234.81 h] |
| 1.4.3.4.3.230 | Testing & commissioing of electric system | 2012-09-05 → 2013-02-13 (+161d) | 2012-09-27 → 2013-03-09 (+163d) |  | 128.75d → -100d |  | resources SSH-Construction Manhours [10000 h] → SSH-Construction Manhours [234.81 h] |
| 5 | **Communciation work** | 2012-08-19 → 2013-01-28 (+162d) | 2012-10-21 → 2013-04-01 (+162d) |  |  |  |  |
| 1.4.3.4.3.240 | Install comm condutis & fittings | 2012-08-19 → 2013-01-28 (+162d) | 2012-09-11 → 2013-02-20 (+162d) |  | 145.25d → -83.5d |  | resources SSH-Construction Manhours [10000 h] → SSH-Construction Manhours [231.57 h] |
| 1.4.3.4.3.250 | Install UTP cable | 2012-08-22 → 2013-01-31 (+162d) | 2012-09-15 → 2013-02-24 (+162d) |  | 145.75d → -83d |  | resources SSH-Construction Manhours [10000 h] → SSH-Construction Manhours [231.57 h] |
| 1.4.3.4.3.260 | Install equipment cabinet | 2012-08-27 → 2013-02-04 (+161d) | 2012-09-18 → 2013-02-27 (+162d) |  | 145.75d → -83d |  | resources SSH-Construction Manhours [10000 h] → SSH-Construction Manhours [231.57 h] |
| 1.4.3.4.3.270 | Install data network switch | 2012-08-28 → 2013-02-06 (+162d) | 2012-09-20 → 2013-03-02 (+163d) |  | 145.75d → -83d |  | resources SSH-Construction Manhours [10000 h] → SSH-Construction Manhours [231.57 h] |
| 1.4.3.4.3.280 | Install copper splice closure | 2012-08-30 → 2013-02-07 (+161d) | 2012-09-23 → 2013-03-03 (+161d) |  | 145.75d → -83d |  | resources SSH-Construction Manhours [10000 h] → SSH-Construction Manhours [231.57 h] |
| 1.4.3.4.3.290 | Install patch panel | 2012-09-01 → 2013-02-10 (+162d) | 2012-09-24 → 2013-03-05 (+162d) |  | 145.75d → -83d |  | resources SSH-Construction Manhours [6000 h] → SSH-Construction Manhours [139.27 h] |
| 1.4.3.4.3.300 | Install fiber patch panel | 2012-09-04 → 2013-02-12 (+161d) | 2012-09-27 → 2013-03-07 (+161d) |  | 145.75d → -83d |  | resources SSH-Construction Manhours [6000 h] → SSH-Construction Manhours [139.27 h] |
| 1.4.3.4.3.310 | Install patch cord | 2012-09-06 → 2013-02-16 (+163d) | 2012-09-30 → 2013-03-11 (+162d) |  | 145.75d → -83d |  | resources SSH-Construction Manhours [10000 h] → SSH-Construction Manhours [231.57 h] |
| 1.4.3.4.3.320 | Install rack manager | 2012-09-10 → 2013-02-18 (+161d) | 2012-10-02 → 2013-03-13 (+162d) |  | 145.75d → -83d |  | resources SSH-Construction Manhours [10000 h] → SSH-Construction Manhours [231.57 h] |
| 1.4.3.4.3.330 | Testing & commissioning of comm system | 2012-09-29 → 2013-03-09 (+161d) | 2012-10-21 → 2013-04-01 (+162d) |  | 128.75d → -100d |  | resources SSH-Construction Manhours [10000 h] → SSH-Construction Manhours [231.57 h] |
| 6 | **Mechanical work** | 2012-08-19 → 2013-01-28 (+162d) | 2012-09-12 → 2013-02-21 (+162d) |  |  |  |  |
| 1.4.3.4.3.340 | Install water supply system | 2012-08-19 → 2013-01-28 (+162d) | 2012-08-30 → 2013-02-09 (+163d) |  | 145.25d → -83.5d |  | resources SSH-Construction Manhours [5000 h] → SSH-Construction Manhours [114.97 h] |
| 1.4.3.4.3.350 | Install sewer system | 2012-08-26 → 2013-02-03 (+161d) | 2012-09-06 → 2013-02-14 (+161d) |  | 145.25d → -83.5d |  | resources SSH-Construction Manhours [5000 h] → SSH-Construction Manhours [114.97 h] |
| 1.4.3.4.3.360 | Install HVAC system | 2012-09-01 → 2013-02-10 (+162d) | 2012-09-12 → 2013-02-21 (+162d) |  | 145.25d → -83.5d |  | resources SSH-Construction Manhours [5000 h] → SSH-Construction Manhours [114.97 h] |
| 4 | **Snack Booth # 4** | 2012-06-23 → 2012-08-16 (+54d) | 2012-11-04 → 2013-03-17 (+133d) |  |  |  |  |
| 1 | **Civil work** | 2012-06-23 → 2012-08-16 (+54d) | 2012-09-13 → 2013-01-26 (+135d) |  |  |  |  |
| 1.4.3.4.4.010 | Excavation leveling & compaction for snack booth 4 | 2012-06-23 → 2012-08-16 A (+54d) | 2012-07-01 → 2012-12-06 (+158d) | 0% → 50% | 139.5d → -84.25d |  | resources SSH-Construction Manhours [2400 h]; Excavator [80 h]; Dump Truck [80 h] → SSH-Construction Manhours [186.23 h]; Excavator [80 h]; Dump Truck [80 h] |
| 1.4.3.4.4.015 | Backfill/comp for snack booth 4 | 2012-09-02 → 2013-01-14 (+134d) | 2012-09-13 → 2013-01-26 (+135d) |  | 165.5d → -58.25d |  | resources SSH-Construction Manhours [3000 h]; Dump Truck [100 h]; Compactor [100 h] → SSH-Construction Manhours [97.16 h]; Dump Truck [100 h]; Compactor [100 h] |
| 2 | **Structural work** | 2012-06-27 → 2012-08-22 (+56d) | 2012-09-02 → 2013-01-14 (+134d) |  |  |  |  |
| 1.4.3.4.4.020 | Install lean concrete for reinforced fdns for snack both | 2012-06-27 → 2012-08-22 A (+56d) | 2012-07-15 → 2012-12-05 (+143d) | 0% → 80% | 139.5d → -84.25d |  | resources SSH-Construction Manhours [7500 h] → SSH-Construction Manhours [173.27 h] |
| 1.4.3.4.4.030 | Install reinforced fdns for snack booth | 2012-07-07 → 2012-09-01 A (+56d) | 2012-08-05 → 2012-12-30 (+147d) | 0% → 3% | 139.5d → -84.25d |  | resources SSH-Construction Manhours [25000 h] → SSH-Construction Manhours [578.11 h] |
| 1.4.3.4.4.040 | Install reinforced roof slab/paraphet snack booth | 2012-07-21 → 2012-12-02 (+134d) | 2012-08-19 → 2012-12-31 (+134d) |  | 139.5d → -84.25d |  | resources SSH-Construction Manhours [12500 h] → SSH-Construction Manhours [289.87 h] |
| 1.4.3.4.4.050 | Install reinforced slab on grade | 2012-08-04 → 2012-12-16 (+134d) | 2012-09-02 → 2013-01-14 (+134d) |  | 139.5d → -84.25d |  | resources SSH-Construction Manhours [12500 h] → SSH-Construction Manhours [289.87 h] |
| 3 | **Architectural work** | 2012-08-18 → 2012-12-30 (+134d) | 2012-11-04 → 2013-03-17 (+133d) |  |  |  |  |
| 1.4.3.4.4.060 | Install masonry work for snack booth | 2012-08-18 → 2012-12-30 (+134d) | 2012-08-29 → 2013-01-10 (+134d) |  | 139.5d → -84.25d |  | resources SSH-Construction Manhours [5000 h] → SSH-Construction Manhours [276.91 h] |
| 1.4.3.4.4.070 | Install plastering work | 2012-08-22 → 2013-01-03 (+134d) | 2012-09-03 → 2013-01-15 (+134d) |  | 139.5d → -84.25d |  | resources SSH-Construction Manhours [5000 h] → SSH-Construction Manhours [276.91 h] |
| 1.4.3.4.4.080 | Install roof proofing system | 2012-08-27 → 2013-01-08 (+134d) | 2012-09-08 → 2013-01-20 (+134d) |  | 139.5d → -84.25d |  | resources SSH-Construction Manhours [5000 h] → SSH-Construction Manhours [276.91 h] |
| 1.4.3.4.4.090 | Install ceiling system | 2012-09-01 → 2013-01-13 (+134d) | 2012-09-12 → 2013-01-24 (+134d) |  | 153.75d → -70d |  | resources SSH-Construction Manhours [5000 h] → SSH-Construction Manhours [276.91 h] |
| 1.4.3.4.4.100 | Install concrete toping, ceramic floor finishes | 2012-09-05 → 2013-01-17 (+134d) | 2012-09-17 → 2013-01-29 (+134d) |  | 153.75d → -70d |  | resources SSH-Construction Manhours [5000 h] → SSH-Construction Manhours [276.91 h] |
| 1.4.3.4.4.110 | Install painting work | 2012-09-17 → 2013-01-29 (+134d) | 2012-09-29 → 2013-02-10 (+134d) |  | 153.75d → -70d |  | resources SSH-Construction Manhours [5000 h] → SSH-Construction Manhours [276.91 h] |
| 1.4.3.4.4.120 | Install plumbing fixture | 2012-09-22 → 2013-02-02 (+133d) | 2012-10-02 → 2013-02-13 (+134d) |  | 153.75d → -70d |  | resources SSH-Construction Manhours [4000 h] → SSH-Construction Manhours [254.24 h] |
| 1.4.3.4.4.130 | Install doors | 2012-09-25 → 2013-02-05 (+133d) | 2012-10-07 → 2013-02-17 (+133d) |  | 153.75d → -70d |  | resources SSH-Construction Manhours [4000 h] → SSH-Construction Manhours [254.24 h] |
| 1.4.3.4.4.140 | Install windows | 2012-09-26 → 2013-02-07 (+134d) | 2012-10-08 → 2013-02-19 (+134d) |  | 153.75d → -70d |  | resources SSH-Construction Manhours [4000 h] → SSH-Construction Manhours [254.24 h] |
| 1.4.3.4.4.150 | Install furniture & kitchen counter top | 2012-09-29 → 2013-02-10 (+134d) | 2012-10-10 → 2013-02-20 (+133d) |  | 153.75d → -70d |  | resources SSH-Construction Manhours [4000 h] → SSH-Construction Manhours [254.24 h] |
| 1.4.3.4.4.160 | Install kitchen & dinnning equipments | 2012-10-04 → 2013-02-14 (+133d) | 2012-10-16 → 2013-02-26 (+133d) |  | 153.75d → -70d |  | resources SSH-Construction Manhours [4000 h] → SSH-Construction Manhours [254.24 h] |
| 1.4.3.4.4.170 | Install wooden trellis | 2012-10-23 → 2013-03-06 (+134d) | 2012-11-04 → 2013-03-17 (+133d) |  | 139.5d → -84.25d |  | resources SSH-Construction Manhours [7000 h] → SSH-Construction Manhours [323.87 h] |
| 4 | **Electrical work** | 2012-09-08 → 2013-01-20 (+134d) | 2012-10-07 → 2013-02-18 (+134d) |  |  |  |  |
| 1.4.3.4.4.180 | Install electric conduits | 2012-09-08 → 2013-01-20 (+134d) | 2012-09-19 → 2013-01-31 (+134d) |  | 139.5d → -84.25d |  | resources SSH-Construction Manhours [4000 h] → SSH-Construction Manhours [254.24 h] |
| 1.4.3.4.4.190 | Install cables & wires | 2012-09-13 → 2013-01-26 (+135d) | 2012-09-25 → 2013-02-06 (+134d) |  | 149d → -74.75d |  | resources SSH-Construction Manhours [3000 h] → SSH-Construction Manhours [231.57 h] |
| 1.4.3.4.4.200 | Install lighting fixtures | 2012-09-17 → 2013-01-29 (+134d) | 2012-09-29 → 2013-02-10 (+134d) |  | 149d → -74.75d |  | resources SSH-Construction Manhours [3000 h] → SSH-Construction Manhours [231.57 h] |
| 1.4.3.4.4.210 | Install panelboards | 2012-09-20 → 2013-02-02 (+135d) | 2012-10-02 → 2013-02-13 (+134d) |  | 149d → -74.75d |  | resources SSH-Construction Manhours [5000 h] → SSH-Construction Manhours [276.91 h] |
| 1.4.3.4.4.220 | Install grounding system | 2012-09-23 → 2013-02-04 (+134d) | 2012-10-04 → 2013-02-14 (+133d) |  | 149d → -74.75d |  | resources SSH-Construction Manhours [3000 h] → SSH-Construction Manhours [231.57 h] |
| 1.4.3.4.4.230 | Testing & commissioing of electric system | 2012-09-25 → 2013-02-06 (+134d) | 2012-10-07 → 2013-02-18 (+134d) |  | 149d → -74.75d |  | resources SSH-Construction Manhours [4000 h] → SSH-Construction Manhours [254.24 h] |
| 5 | **Communciation work** | 2012-09-19 → 2013-01-31 (+134d) | 2012-10-23 → 2013-03-05 (+133d) |  |  |  |  |
| 1.4.3.4.4.240 | Install comm condutis & fittings | 2012-09-19 → 2013-01-31 (+134d) | 2012-09-26 → 2013-02-07 (+134d) |  | 139.5d → -84.25d |  | resources SSH-Construction Manhours [1800 h] → SSH-Construction Manhours [204.04 h] |
| 1.4.3.4.4.250 | Install UTP cable | 2012-09-24 → 2013-02-04 (+133d) | 2012-09-30 → 2013-02-11 (+134d) |  | 139.5d → -84.25d |  | resources SSH-Construction Manhours [3000 h] → SSH-Construction Manhours [231.57 h] |
| 1.4.3.4.4.260 | Install equipment cabinet | 2012-09-27 → 2013-02-07 (+133d) | 2012-10-04 → 2013-02-14 (+133d) |  | 139.5d → -84.25d |  | resources SSH-Construction Manhours [1800 h] → SSH-Construction Manhours [204.04 h] |
| 1.4.3.4.4.270 | Install data network switch | 2012-10-01 → 2013-02-11 (+133d) | 2012-10-08 → 2013-02-18 (+133d) |  | 139.5d → -84.25d |  | resources SSH-Construction Manhours [1800 h] → SSH-Construction Manhours [204.04 h] |
| 1.4.3.4.4.280 | Install copper splice closure | 2012-10-03 → 2013-02-13 (+133d) | 2012-10-10 → 2013-02-20 (+133d) |  | 139.5d → -84.25d |  | resources SSH-Construction Manhours [2400 h] → SSH-Construction Manhours [216.99 h] |
| 1.4.3.4.4.290 | Install patch panel | 2012-10-04 → 2013-02-16 (+135d) | 2012-10-11 → 2013-02-23 (+135d) |  | 139.5d → -84.25d |  | resources SSH-Construction Manhours [2400 h] → SSH-Construction Manhours [216.99 h] |
| 1.4.3.4.4.300 | Install fiber patch panel | 2012-10-08 → 2013-02-18 (+133d) | 2012-10-15 → 2013-02-25 (+133d) |  | 139.5d → -84.25d |  | resources SSH-Construction Manhours [2400 h] → SSH-Construction Manhours [216.99 h] |
| 1.4.3.4.4.310 | Install patch cord | 2012-10-10 → 2013-02-21 (+134d) | 2012-10-17 → 2013-02-28 (+134d) |  | 139.5d → -84.25d |  | resources SSH-Construction Manhours [2400 h] → SSH-Construction Manhours [216.99 h] |
| 1.4.3.4.4.320 | Install rack manager | 2012-10-14 → 2013-02-24 (+133d) | 2012-10-20 → 2013-03-03 (+134d) |  | 139.5d → -84.25d |  | resources SSH-Construction Manhours [2400 h] → SSH-Construction Manhours [216.99 h] |
| 1.4.3.4.4.330 | Testing & commissioning of comm system | 2012-10-16 → 2013-02-27 (+134d) | 2012-10-23 → 2013-03-05 (+133d) |  | 139.5d → -84.25d | 1.4.3.4.4.320 SS+3d, 1.4.3.4.4.230, 1.4.3.4.4.360 → 1.4.3.4.4.320 SS+3d, 1.4.3.4.4.230, 1.4.3.4.4.360 FF | resources SSH-Construction Manhours [2400 h] → SSH-Construction Manhours [216.99 h] |
| 6 | **Mechanical work** | 2012-09-26 → 2013-02-07 (+134d) | 2012-10-15 → 2013-02-21 (+129d) |  |  |  |  |
| 1.4.3.4.4.340 | Install water supply system | 2012-09-26 → 2013-02-07 (+134d) | 2012-10-04 → 2013-02-14 (+133d) |  | 140.25d → -71d |  | resources SSH-Construction Manhours [3200 h] → SSH-Construction Manhours [236.43 h] |
| 1.4.3.4.4.350 | Install sewer system | 2012-10-03 → 2013-02-14 (+134d) | 2012-10-10 → 2013-02-21 (+134d) |  | 140.25d → -71d |  | resources SSH-Construction Manhours [3200 h] → SSH-Construction Manhours [236.43 h] |
| 1.4.3.4.4.360 | Install HVAC system | 2012-10-10 → 2013-02-16 (+129d) | 2012-10-15 → 2013-02-21 (+129d) |  | 140.25d → -71d | 1.4.3.4.4.350 SS+7d → 1.4.3.4.4.350 FF | resources SSH-Construction Manhours [2400 h] → SSH-Construction Manhours [218.61 h] |
| 5 | **Picnic Shelters (30 nos)** | 2012-03-17 → 2012-06-07 (+82d) | 2012-11-06 → 2013-04-04 (+149d) |  |  |  |  |
| 1 | **Picnic Shelters** | 2012-03-17 → 2012-06-07 (+82d) | 2012-11-06 → 2013-04-04 (+149d) |  |  |  |  |
| 1 | **Civil work** | 2012-03-17 → 2012-06-07 (+82d) | 2012-07-30 → 2013-02-14 (+199d) |  |  |  |  |

| ID | Task | Start | Finish | Duration | Complete | Total float | Predecessors | Other |
| --- | --- | --- | --- | --- | --- | --- | --- | --- |
| 1.4.3.5.1.010 | Excavation for picnic shelters | 2012-03-17 → 2012-06-07 A (+82d) | 2012-05-10 → 2012-12-02 (+206d) |  | 0% → 59% | 37.75d → -119.2d | 1.4.3.4.1.010 SS → 1.4.3.4.1.010 FF+10d | resources SSH-Construction Manhours [24000 h]; Excavator [480 h]; Dump Truck [480 h] → SSH-Construction Manhours [1818.37 h]; Excavator [480 h]; Dump Truck [480 h] |
| 1.4.3.5.1.015 | Backfill/comp for picnic shelters | 2012-06-04 → 2012-12-20 (+199d) | 2012-07-30 → 2013-02-14 (+199d) |  |  | 137.75d → -63.9d |  | resources SSH-Construction Manhours [14400 h]; Dump Truck [480 h]; Compactor [480 h] → SSH-Construction Manhours [1053.27 h]; Dump Truck [480 h]; Compactor [480 h] |
| 2 | **Structural work** | 2012-03-21 → 2012-06-13 (+84d) | 2012-07-14 → 2013-01-17 (+187d) |  |  |  |  |  |
| 1.4.3.5.1.020 | Install lean concrete for reinforced fdns | 2012-03-21 → 2012-06-13 A (+84d) | 2012-05-30 → 2012-12-27 (+211d) |  | 0% → 31% | 44d → -103.9d |  | resources SSH-Construction Manhours [42000 h] → SSH-Construction Manhours [3183.64 h] |
| 1.4.3.5.1.030 | Install reinforced fdns | 2012-04-04 → 2012-06-27 A (+84d) | 2012-06-25 → 2013-01-16 (+205d) | 87.5d → 75d | 0% → 3% | 44d → -103.9d |  | resources SSH-Construction Manhours [140000 h] → SSH-Construction Manhours [10612.1 h] |
| 1.4.3.5.1.040 | Install reinforced roof slab on grade | 2012-04-23 → 2012-11-08 (+199d) | 2012-07-14 → 2013-01-17 (+187d) | 87.5d → 75d |  | 44d → -103.9d |  | resources SSH-Construction Manhours [105000 h] → SSH-Construction Manhours [7969.04 h] |
| 3 | **Architectural work** | 2012-05-12 → 2012-11-22 (+194d) | 2012-09-19 → 2013-04-02 (+195d) |  |  |  |  |  |
| 1.4.3.5.1.050 | Install cement based plaster/textured paintn finish | 2012-05-12 → 2012-11-22 (+194d) | 2012-08-04 → 2013-02-14 (+194d) |  |  | 44d → -103.9d | 1.4.3.5.1.040 SS+20d → 1.4.3.5.1.040 SS+15d | resources SSH-Construction Manhours [57600 h] → SSH-Construction Manhours [4372.04 h] |
| 1.4.3.5.1.060 | Install roofing trellis system | 2012-05-23 → 2012-12-04 (+195d) | 2012-08-15 → 2013-02-26 (+195d) |  |  | 44d → -103.9d |  | resources SSH-Construction Manhours [36000 h] → SSH-Construction Manhours [2732.53 h] |
| 1.4.3.5.1.070 | Install concrete topping, ceramic floor finish | 2012-06-04 → 2012-12-16 (+195d) | 2012-08-27 → 2013-03-10 (+195d) |  |  | 44d → -103.9d |  | resources SSH-Construction Manhours [72000 h] → SSH-Construction Manhours [5465.05 h] |
| 1.4.3.5.1.080 | Install picnic furniture | 2012-06-16 → 2012-12-27 (+194d) | 2012-09-08 → 2013-03-21 (+194d) |  |  | 172.75d → -23.9d |  | resources SSH-Construction Manhours [36000 h] → SSH-Construction Manhours [2732.53 h] |
| 1.4.3.5.1.090 | Install faucet & drain fixtures/plumbing works | 2012-06-27 → 2013-01-08 (+195d) | 2012-09-19 → 2013-04-02 (+195d) |  |  | 172.75d → -23.9d |  | resources SSH-Construction Manhours [36000 h] → SSH-Construction Manhours [2732.53 h] |
| 4 | **Electrical work** | 2012-07-07 → 2012-12-16 (+162d) | 2012-11-06 → 2013-04-04 (+149d) |  |  |  |  |  |
| 1.4.3.5.1.100 | Install electric conduits & fittings | 2012-07-07 → 2012-12-16 (+162d) | 2012-09-29 → 2013-03-10 (+162d) |  |  | 44d → -103.9d | 1.4.3.5.1.070 SS+35d → 1.4.3.5.1.070 SS | resources SSH-Construction Manhours [36000 h] → SSH-Construction Manhours [2732.53 h] |
| 1.4.3.5.1.110 | Install cables & wires | 2012-07-18 → 2012-12-25 (+160d) | 2012-10-10 → 2013-03-19 (+160d) |  |  | 44d → -103.9d | 1.4.3.5.1.100 SS+12.5d → 1.4.3.5.1.100 SS+10d | resources SSH-Construction Manhours [72000 h] → SSH-Construction Manhours [5455.12 h] |
| 1.4.3.5.1.120 | Install lighting fixtures | 2012-08-05 → 2013-01-03 (+151d) | 2012-10-14 → 2013-03-14 (+151d) |  |  | 44d → -103.9d | 1.4.3.5.1.110 SS+18.75d → 1.4.3.5.1.110 SS+10d | resources SSH-Construction Manhours [72000 h] → SSH-Construction Manhours [5455.12 h] |
| 1.4.3.5.1.130 | Install grounding system | 2012-08-16 → 2013-01-13 (+150d) | 2012-10-25 → 2013-03-24 (+150d) |  |  | 44d → -103.9d | 1.4.3.5.1.120 SS+12.5d → 1.4.3.5.1.120 SS+10d | resources SSH-Construction Manhours [43200 h] → SSH-Construction Manhours [3279.03 h] |
| 1.4.3.5.1.140 | Testing & commissioing of electric system | 2012-10-25 → 2013-03-24 (+150d) | 2012-11-06 → 2013-04-04 (+149d) |  |  | 44d → -103.9d |  | resources SSH-Construction Manhours [72000 h] → SSH-Construction Manhours [5465.05 h] |
| 6 | **Fitness Shelters (7 nos)** | 2012-03-17 → 2012-06-17 (+92d) | 2012-11-12 → 2013-04-11 (+150d) |  |  |  |  |  |
| 1 | **Fitness Shelters** | 2012-03-17 → 2012-06-17 (+92d) | 2012-11-12 → 2013-04-11 (+150d) |  |  |  |  |  |
| 1 | **Civil work** | 2012-03-17 → 2012-06-17 (+92d) | 2012-07-21 → 2013-02-10 (+204d) |  |  |  |  |  |
| 1.4.3.6.1.010 | Excavation for picnic shelters | 2012-03-17 → 2012-06-17 A (+92d) | 2012-05-10 → 2012-12-11 (+215d) |  | 0% → 50% | 37.75d → -119.2d | 1.4.3.5.1.010 SS → 1.4.3.5.1.010 FF+10d | resources SSH-Construction Manhours [24000 h]; Excavator [480 h]; Dump Truck [480 h] → SSH-Construction Manhours [247.33 h]; Excavator [480 h]; Dump Truck [480 h] |
| 1.4.3.6.1.015 | Backfill/comp for picnic shelters | 2012-06-04 → 2012-12-25 (+204d) | 2012-07-21 → 2013-02-10 (+204d) |  |  | 95.25d → -111d |  | resources SSH-Construction Manhours [24000 h]; Dump Truck [400 h]; Compactor [400 h] → SSH-Construction Manhours [185.5 h]; Dump Truck [400 h]; Compactor [400 h] |
| 2 | **Structural work** | 2012-03-21 → 2012-06-23 (+94d) | 2012-07-14 → 2013-02-03 (+204d) |  |  |  |  |  |
| 1.4.3.6.1.020 | Install lean concrete for reinforced fdns | 2012-03-21 → 2012-06-23 A (+94d) | 2012-05-30 → 2013-01-03 (+218d) |  | 0% → 27% | 37.75d → -111d |  | resources SSH-Construction Manhours [90000 h] → SSH-Construction Manhours [687.03 h] |
| 1.4.3.6.1.030 | Install reinforced fdns | 2012-04-04 → 2012-07-07 A (+94d) | 2012-06-25 → 2013-01-26 (+215d) |  | 0% → 10% | 37.75d → -111d |  | resources SSH-Construction Manhours [140000 h] → SSH-Construction Manhours [1085.5 h] |
| 1.4.3.6.1.040 | Install reinforced roof slab on grade | 2012-04-23 → 2012-11-13 (+204d) | 2012-07-14 → 2013-02-03 (+204d) |  |  | 37.75d → -111d |  | resources SSH-Construction Manhours [105000 h] → SSH-Construction Manhours [810.69 h] |
| 3 | **Architectural work** | 2012-05-12 → 2012-11-22 (+194d) | 2012-10-23 → 2013-04-11 (+170d) |  |  |  |  |  |
| 1.4.3.6.1.050 | Install cement based plaster/textured paintn finish | 2012-05-12 → 2012-11-22 (+194d) | 2012-07-21 → 2013-01-31 (+194d) |  |  | 37.75d → -106d | 1.4.3.6.1.040 SS+20d → 1.4.3.6.1.040 SS+10d | resources SSH-Construction Manhours [36000 h] → SSH-Construction Manhours [274.81 h] |
| 1.4.3.6.1.060 | Install roofing trellis system | 2012-05-29 → 2012-12-11 (+196d) | 2012-08-07 → 2013-02-19 (+196d) |  |  | 37.75d → -106d | 1.4.3.6.1.050 SS+18.75d → 1.4.3.6.1.050 SS+20d | resources SSH-Construction Manhours [60000 h] → SSH-Construction Manhours [460.31 h] |
| 1.4.3.6.1.070 | Install concrete topping, ceramic floor finish | 2012-06-16 → 2012-12-30 (+197d) | 2012-08-25 → 2013-03-10 (+197d) |  |  | 37.75d → -106d | 1.4.3.6.1.060 SS+18.75d → 1.4.3.6.1.060 SS+20d | resources SSH-Construction Manhours [60000 h] → SSH-Construction Manhours [460.31 h] |
| 1.4.3.6.1.080 | Install fitness furniture | 2012-07-19 → 2012-12-30 (+164d) | 2012-09-27 → 2013-03-10 (+164d) |  |  | 59d → -103.5d | 1.4.3.6.1.070 SS+18.75d, 1.3.1.25.030 → 1.4.3.6.1.070 SS, 1.3.1.25.030 | resources SSH-Construction Manhours [48000 h] → SSH-Construction Manhours [371 h] |
| 1.4.3.6.1.090 | Install aluminium cladding | 2012-08-06 → 2013-01-16 (+163d) | 2012-10-15 → 2013-03-27 (+163d) |  |  | 59d → -103.5d |  | resources SSH-Construction Manhours [36000 h] → SSH-Construction Manhours [274.81 h] |
| 1.4.3.6.1.100 | Install faucet & drain fixtures/plumbing works | 2012-08-23 → 2013-02-10 (+171d) | 2012-10-23 → 2013-04-11 (+170d) |  |  | 59d → -111d |  | resources SSH-Construction Manhours [41600 h] → SSH-Construction Manhours [322.9 h] |
| 4 | **Electrical work** | 2012-07-18 → 2012-12-30 (+165d) | 2012-11-12 → 2013-04-11 (+150d) |  |  |  |  |  |
| 1.4.3.6.1.110 | Install electric conduits & fittings | 2012-07-18 → 2012-12-30 (+165d) | 2012-09-26 → 2013-03-10 (+165d) |  |  | 37.75d → -106d | 1.4.3.6.1.070 SS+35d → 1.4.3.6.1.070 SS | resources SSH-Construction Manhours [60000 h] → SSH-Construction Manhours [460.31 h] |
| 1.4.3.6.1.120 | Install cables & wires | 2012-08-01 → 2013-01-08 (+160d) | 2012-10-10 → 2013-03-19 (+160d) |  |  | 37.75d → -106d | 1.4.3.6.1.110 SS+15d → 1.4.3.6.1.110 SS+10d | resources SSH-Construction Manhours [60000 h] → SSH-Construction Manhours [460.31 h] |
| 1.4.3.6.1.130 | Install lighting fixtures | 2012-08-15 → 2013-01-17 (+155d) | 2012-10-24 → 2013-03-28 (+155d) |  |  | 37.75d → -106d | 1.4.3.6.1.120 SS+15d → 1.4.3.6.1.120 SS+10d | resources SSH-Construction Manhours [36000 h] → SSH-Construction Manhours [274.81 h] |
| 1.4.3.6.1.140 | Install grounding system | 2012-08-29 → 2013-01-27 (+151d) | 2012-11-07 → 2013-04-07 (+151d) |  |  | 37.75d → -106d | 1.4.3.6.1.130 SS+15d → 1.4.3.6.1.130 SS+10d | resources SSH-Construction Manhours [42000 h] → SSH-Construction Manhours [322.9 h] |
| 1.4.3.6.1.150 | Testing & commissioing of electric system | 2012-09-12 → 2013-02-10 (+151d) | 2012-11-12 → 2013-04-11 (+150d) |  |  | 37.75d → -111d | 1.4.3.6.1.140 SS+15d, 1.4.3.6.1.100 SS → 1.4.3.6.1.140 SS+10d, 1.4.3.6.1.100 SS | resources SSH-Construction Manhours [52000 h] → SSH-Construction Manhours [398.48 h] |
| 7 | **Art Work Shelters (8 nos)** | 2012-03-17 → 2012-06-25 (+100d) | 2012-11-07 → 2013-04-18 (+162d) |  |  |  |  |  |
| 1 | **Art Work Shelters** | 2012-03-17 → 2012-06-25 (+100d) | 2012-11-07 → 2013-04-18 (+162d) |  |  |  |  |  |
| 1 | **Civil work** | 2012-03-17 → 2012-06-25 (+100d) | 2012-07-30 → 2013-02-26 (+211d) |  |  |  |  |  |
| 1.4.3.7.1.010 | Excavation for picnic shelters | 2012-03-17 → 2012-06-25 A (+100d) | 2012-05-10 → 2012-12-18 (+222d) |  | 0% → 17% | 42.75d → -119.2d | 1.4.3.6.1.010 SS → 1.4.3.6.1.010 FF+8d | resources SSH-Construction Manhours [24000 h]; Excavator [480 h]; Dump Truck [480 h] → SSH-Construction Manhours [241.09 h]; Excavator [480 h]; Dump Truck [480 h] |
| 1.4.3.7.1.015 | Backfill/comp for picnic shelters | 2012-06-04 → 2013-01-01 (+211d) | 2012-07-30 → 2013-02-26 (+211d) |  |  | 75.25d → -114.2d |  | resources SSH-Construction Manhours [14400 h]; Dump Truck [480 h]; Compactor [480 h] → SSH-Construction Manhours [143.35 h]; Dump Truck [480 h]; Compactor [480 h] |
| 2 | **Structural work** | 2012-03-21 → 2012-06-30 (+101d) | 2012-07-14 → 2013-02-10 (+211d) |  |  |  |  |  |
| 1.4.3.7.1.020 | Install lean concrete for reinforced fdns | 2012-03-21 → 2012-06-30 A (+101d) | 2012-05-19 → 2012-12-24 (+219d) |  | 0% → 10% | 42.75d → -119.2d |  | resources SSH-Construction Manhours [35000 h] → SSH-Construction Manhours [351.86 h] |
| 1.4.3.7.1.030 | Install reinforced fdns | 2012-04-04 → 2012-11-01 (+211d) | 2012-06-25 → 2013-01-22 (+211d) |  |  | 42.75d → -119.2d |  | resources SSH-Construction Manhours [140000 h] → SSH-Construction Manhours [1387.88 h] |
| 1.4.3.7.1.040 | Install reinforced roof slab on grade | 2012-04-23 → 2012-11-20 (+211d) | 2012-07-14 → 2013-02-10 (+211d) |  |  | 42.75d → -119.2d |  | resources SSH-Construction Manhours [80000 h] → SSH-Construction Manhours [794.94 h] |
| 3 | **Architectural work** | 2012-05-12 → 2012-11-29 (+201d) | 2012-10-16 → 2013-04-14 (+180d) |  |  |  |  |  |
| 1.4.3.7.1.050 | Install cement based plaster/textured paintn finish | 2012-05-12 → 2012-11-29 (+201d) | 2012-07-21 → 2013-02-07 (+201d) |  |  | 42.75d → -119.2d | 1.4.3.7.1.040 SS+20d → 1.4.3.7.1.040 SS+10d | resources SSH-Construction Manhours [48000 h] → SSH-Construction Manhours [475.66 h] |
| 1.4.3.7.1.060 | Install roofing trellis system | 2012-05-29 → 2012-12-09 (+194d) | 2012-08-07 → 2013-02-17 (+194d) |  |  | 42.75d → -119.2d | 1.4.3.7.1.050 SS+18.75d → 1.4.3.7.1.050 SS+10d | resources SSH-Construction Manhours [60000 h] → SSH-Construction Manhours [594.25 h] |
| 1.4.3.7.1.070 | Install concrete topping, ceramic floor finish | 2012-06-16 → 2012-12-18 (+185d) | 2012-08-25 → 2013-02-26 (+185d) |  |  | 42.75d → -119.2d | 1.4.3.7.1.060 SS+18.75d → 1.4.3.7.1.060 SS+10d | resources SSH-Construction Manhours [60000 h] → SSH-Construction Manhours [594.25 h] |
| 1.4.3.7.1.080 | Install furniture for art works | 2012-07-03 → 2012-12-27 (+177d) | 2012-09-11 → 2013-03-07 (+177d) |  |  | 66.5d → -77.95d | 1.4.3.7.1.070 SS+18.75d → 1.4.3.7.1.070 SS+10d | resources SSH-Construction Manhours [48000 h] → SSH-Construction Manhours [475.66 h] |
| 1.4.3.7.1.090 | Install aluminium cladding | 2012-07-21 → 2013-01-06 (+169d) | 2012-09-29 → 2013-03-17 (+169d) |  |  | 66.5d → -77.95d | 1.4.3.7.1.080 SS+18.75d → 1.4.3.7.1.080 SS+10d | resources SSH-Construction Manhours [48000 h] → SSH-Construction Manhours [475.66 h] |
| 1.4.3.7.1.100 | Install faucet & drain fixtures/plumbing works | 2012-08-07 → 2013-02-26 (+203d) | 2012-10-16 → 2013-04-14 (+180d) | 75d → 50d |  | 66.5d → -114.2d |  | resources SSH-Construction Manhours [48000 h] → SSH-Construction Manhours [475.66 h] |
| 4 | **Electrical work** | 2012-07-18 → 2012-12-27 (+162d) | 2012-11-07 → 2013-04-18 (+162d) |  |  |  |  |  |
| 1.4.3.7.1.110 | Install electric conduits & fittings | 2012-07-18 → 2012-12-27 (+162d) | 2012-09-26 → 2013-03-07 (+162d) |  |  | 42.75d → -119.2d | 1.4.3.7.1.070 SS+35d → 1.4.3.7.1.070 SS+10d | resources SSH-Construction Manhours [60000 h] → SSH-Construction Manhours [594.25 h] |
| 1.4.3.7.1.120 | Install cables & wires | 2012-08-01 → 2013-01-10 (+162d) | 2012-10-10 → 2013-03-21 (+162d) |  |  | 42.75d → -119.2d |  | resources SSH-Construction Manhours [60000 h] → SSH-Construction Manhours [594.25 h] |
| 1.4.3.7.1.130 | Install lighting fixtures | 2012-08-15 → 2013-01-24 (+162d) | 2012-10-24 → 2013-04-04 (+162d) |  |  | 42.75d → -119.2d |  | resources SSH-Construction Manhours [60000 h] → SSH-Construction Manhours [594.25 h] |
| 1.4.3.7.1.140 | Install grounding system | 2012-08-29 → 2013-02-07 (+162d) | 2012-11-07 → 2013-04-18 (+162d) |  |  | 42.75d → -119.2d |  | resources SSH-Construction Manhours [42000 h] → SSH-Construction Manhours [417.02 h] |
| 4 | **PRE-COMMISSIONING WORKS** | 2012-01-24 → 2012-10-04 (+254d) | 2012-12-29 → 2013-08-05 (+219d) |  |  |  |  |  |
| 1 | **Submit OSPDP (Operating Spare Parts Data Package** | 2012-04-07 → 2012-10-04 (+180d) | 2012-10-20 → 2013-01-24 (+96d) |  |  |  |  |  |
| 1 | **Submit OSPDP** | 2012-04-07 → 2012-10-04 (+180d) | 2012-10-20 → 2013-01-24 (+96d) |  |  |  |  |  |
| 1.4.4.1.010 | Complete Submit OSPDP for elect materials | 2012-04-07 → 2012-10-04 (+180d) | 2012-07-03 → 2012-12-30 (+180d) |  |  | 62.75d → -80.5d | 1.3.2.1.020, 1.4.3.1.1.090, 1.4.3.1.2.090 → 1.3.2.1.020 | resources SSH-Construction Manhours [18000 h] → SSH-Construction Manhours [1905.52 h] |
| 1.4.4.1.020 | Complete Submit OSPDP for mech materials | 2012-06-04 → 2012-10-30 (+148d) | 2012-08-19 → 2013-01-13 (+147d) |  |  | 62.75d → -28.25d | 1.4.4.1.010 SS+62.5d → 1.4.4.1.010 FF+15d | resources SSH-Construction Manhours [15000 h] → SSH-Construction Manhours [1270.35 h] |
| 1.4.4.1.030 | Complete Submit OSPDP Telecomm materials | 2012-08-13 → 2012-11-15 (+94d) | 2012-10-20 → 2013-01-24 (+96d) | 72.5d → 75d |  | 62.75d → -28.25d | 1.4.4.1.020 SS+75d → 1.4.4.1.020 FF+12d | resources SSH-Construction Manhours [16400 h] → SSH-Construction Manhours [1270.35 h] |
| 2 | **Submit O & M (Operating & Maintenance)** | 2012-04-07 → 2012-10-04 (+180d) | 2012-07-21 → 2013-01-16 (+179d) |  |  |  |  |  |
| 1 | **Submit O & M** | 2012-04-07 → 2012-10-04 (+180d) | 2012-07-21 → 2013-01-16 (+179d) |  |  |  |  |  |
| 1.4.4.2.010 | Submit O&M Documents | 2012-04-07 → 2012-10-04 (+180d) | 2012-07-21 → 2013-01-16 (+179d) |  |  | 67.75d → -80.5d |  | resources SSH-Construction Manhours [27200 h] → SSH-Construction Manhours [4453.6 h] |

| ID | Task | Start | Finish | Duration | Total float | Predecessors | Other |
| --- | --- | --- | --- | --- | --- | --- | --- |
| 3 | **Submit Approved Project Record Books** | 2012-07-21 → 2013-01-17 (+180d) | 2012-09-29 → 2013-03-13 (+165d) |  |  |  |  |
| 1 | **Submit Project Records Books** | 2012-07-21 → 2013-01-17 (+180d) | 2012-09-29 → 2013-03-13 (+165d) |  |  |  |  |
| 1.4.4.3.010 | Submit approved project record books | 2012-07-21 → 2013-01-17 (+180d) | 2012-09-29 → 2013-03-13 (+165d) | 75d → 60d | 85.25d → -80.5d |  | resources SSH-Construction Manhours [12000 h] → SSH-Construction Manhours [4453.6 h] |
| 4 | **Submit Pre-Commissioning Activities** | 2012-01-24 → 2012-12-13 (+324d) | 2012-04-02 → 2013-01-28 (+301d) |  |  |  |  |
| 1 | **Submit Pre-commissioning Activites** | 2012-01-24 → 2012-12-13 (+324d) | 2012-04-02 → 2013-01-28 (+301d) |  |  |  |  |
| 1.4.4.4.010 | Submit pre-commissioing activities for all facilities | 2012-01-24 → 2012-12-13 (+324d) | 2012-04-02 → 2013-01-28 (+301d) | 75d → 50d | 99.25d → -32.5d | 1.2.6.200, 1.2.8.010 SS → 1.2.6.200, 1.2.8.010 | resources SSH-Construction Manhours [19200 h] → SSH-Construction Manhours [9527.61 h] |
| 5 | **Submit Red Lined Drawings** | 2012-10-21 → 2013-06-06 (+228d) | 2012-11-19 → 2013-07-06 (+229d) |  |  |  |  |
| 1 | **Submit red lined drawings** | 2012-10-21 → 2013-06-06 (+228d) | 2012-11-19 → 2013-07-06 (+229d) |  |  |  |  |
| 1.4.4.5.010 | Submit complete red lined as built drawings-civil | 2012-10-21 → 2013-06-06 (+228d) | 2012-11-18 → 2013-06-29 (+223d) | 31.25d → 25d | 30d → -202.5d | 1.4.4.2.010 SS+37.5d, 1.4.3.1.1.570, 1.4.3.1.2.560, 1.4.3.2.1.1340, M2.10, 1.4.3.1.2.570, M2.17, M2.14 → 1.4.4.2.010 SS, 1.4.3.1.1.570, 1.4.3.1.2.560, 1.4.3.2.1.1340, M2.10, 1.4.3.1.2.570, M2.17, M2.14 | resources SSH-Construction Manhours [25000 h] → SSH-Construction Manhours [3818.43 h] |
| 1.4.4.5.020 | Submit complete red lined as built drawings-mech | 2012-10-21 → 2013-06-08 (+230d) | 2012-11-18 → 2013-07-01 (+225d) | 31.25d → 25d | 30d → -202.5d | 1.4.4.5.010 SS, 1.4.3.1.2.560, 1.4.3.1.1.570, 1.4.3.2.1.1340, 1.4.3.1.2.570, M2.10, M2.17, M2.14 → 1.4.4.5.010 FF+2d, 1.4.3.1.2.560, 1.4.3.1.1.570, 1.4.3.2.1.1340, 1.4.3.1.2.570, M2.10, M2.17, M2.14 | resources SSH-Construction Manhours [25000 h] → SSH-Construction Manhours [3818.43 h] |
| 1.4.4.5.030 | Submit complete red lined as built drawings-elect | 2012-10-21 → 2013-06-10 (+232d) | 2012-11-18 → 2013-07-03 (+227d) | 31.25d → 25d | 30d → -202.5d | 1.4.4.5.020 SS, Install switchgear SS4, Install switchgear SS5, 1.4.2.7.4.040, 1.4.2.7.4.050, 1.4.2.7.4.070, 1.4.2.7.4.072, Install transformer SS4, Install transformer SS5, Install switchboards SS4, Install switchboards SS5, Install main distribution panel board SS4, Install main distribution panel board SS5, Install circuit breaker SS4 SS, Install circuit breaker SS5 SS, Install annunciator panel SS4 SS, Install annunciator panel SS5 SS, Install battery bank & battery charger with system SS4 SS, Install battery bank & battery charger with system SS5 SS, 1.4.3.1.2.560, 1.4.3.1.1.570, 1.4.3.2.1.1340, 1.4.3.1.2.570, M2.10, M2.17, M2.14 → 1.4.4.5.020 FF+2d, 1.4.2.7.4.040, 1.4.2.7.4.050, 1.4.2.7.4.070, 1.4.2.7.4.072, 1.4.3.1.2.560, 1.4.3.1.1.570, 1.4.3.2.1.1340, 1.4.3.1.2.570, M2.10, M2.17, M2.14 | resources SSH-Construction Manhours [25000 h] → SSH-Construction Manhours [3818.43 h] |
| 1.4.4.5.040 | Submit complete red lined as built drawings-telecomm | 2012-10-21 → 2013-06-11 (+233d) | 2012-11-19 → 2013-07-06 (+229d) | 32.5d → 26d | 30d → -202.5d | 1.4.4.5.030 SS, 1.4.3.1.2.560, 1.4.3.1.1.570, 1.4.3.2.1.1340, 1.4.3.1.2.570, M2.10, M2.17, M2.14 → 1.4.4.5.030 FF+3d, 1.4.3.1.2.560, 1.4.3.1.1.570, 1.4.3.2.1.1340, 1.4.3.1.2.570, M2.10, M2.17, M2.14 | resources SSH-Construction Manhours [26000 h] → SSH-Construction Manhours [3818.43 h] |
| 7 | **MCC - Mechanical Completion Certificate** | 2012-12-18 → 2013-07-06 (+200d) | 2012-12-29 → 2013-08-05 (+219d) |  |  |  |  |
| 1 | **MCC** | 2012-12-18 → 2013-07-06 (+200d) | 2012-12-29 → 2013-08-05 (+219d) |  |  |  |  |
| 1.4.4.6.010 | Mechanical Completion of all works -MCC | 2012-12-18 → 2013-07-06 (+200d) | 2012-12-29 → 2013-08-03 (+217d) | 12.5d → 30d | 0d → -202d | 1.4.4.5.040, 1.4.4.3.010, 1.4.4.4.010, M2.20, M2.19, M2.17, M2.16, M2.15, M2.18, M2.09, M2.14, 1.4.3.1.1.780, M2.10, M2.11, M2.12, M2.13, Z1.1060, 1.4.2.5.3.110, 1.4.2.5.4.050, 1.4.3.1.1.570, 1.4.2.5.6.020D, Install Turfin & ground cover, natural stone boulder/sculptured(1each large & 2 small), 1.4.3.6.1.150, 1.4.3.7.1.140, 1.4.3.7.1.100, 1.4.3.5.1.140, 1.4.2.5.6.010D, 1.4.3.1.2.570 → 1.4.4.5.040 FF, 1.4.4.3.010, 1.4.4.4.010, M2.19, M2.17, M2.16, M2.15, M2.18, M2.09, M2.14, 1.4.3.1.1.780, M2.10, M2.11, M2.12, M2.13, Z1.1060, 1.4.2.5.3.110, 1.4.2.5.4.050, 1.4.3.1.1.570, 1.4.2.5.6.020D, 1.4.3.6.1.150, 1.4.3.7.1.140, 1.4.3.7.1.100, 1.4.3.5.1.140, 1.4.2.5.6.010D, 1.4.3.1.2.570, M2.20 | resources SSH-Construction Manhours [100000 h] → SSH-Construction Manhours [12725.6 h] |
| 5 | **DEMOBILIZATION** | 2012-12-30 → 2013-08-05 (+218d) | 2013-06-29 → 2014-01-04 (+189d) |  |  |  |  |
| 1 | **Demobilization** | 2012-12-30 → 2013-08-05 (+218d) | 2013-06-29 → 2014-01-04 (+189d) |  |  |  |  |
| 1 | **Demobilization** | 2012-12-30 → 2013-08-05 (+218d) | 2013-06-29 → 2014-01-04 (+189d) |  |  |  |  |
| 1.4.5.1.010 | Demobilization of equipments & manpower | 2013-06-11 → 2013-08-05 (+55d) | 2013-06-29 → 2014-01-04 (+189d) | 20d → 163d | 0d → -202.5d | 1.4.5.1.020 → 1.4.4.6.010, M2.22 | resources SSH-Construction Manhours [25500 h]; Trailer [160 h] → SSH-Construction Manhours [7334.16 h]; Trailer [160 h] |
| 1.4.5.1.020 | Removal of temporary offices | 2013-05-19 → 2013-08-05 (+78d) | 2013-06-10 → 2014-01-04 (+208d) | 25d → 163d | 0d → -202.5d | Touch up of roads according to the existing roads → 1.4.5.1.010 SS | resources SSH-Construction Manhours [30000 h]; Crane [200 h]; Trailer [200 h] → SSH-Construction Manhours [7330.84 h]; Truck Crane [200 ea]; Trailer [200 h] |
